# IMPACT BOOM

Schedule from MS Project, 2000-05-26 to 2004-08-17, status date 2003-05-31, A marks actual dates.
IMPACT BOOM Development With I & T
NASA GSFC
Status Date: 05/31/2003 / Baseline Date: 01/31/2003 R1

## Calendars

- Standard w/ 10 Gov't Holidays: Mon-Fri 08:00-12:00, 13:00-17:00; Sat-Sun off. Exceptions (off unless hours are given): 2000-05-29, 2000-07-04, 2000-09-04, 2000-10-09, 2000-11-13, 2000-11-23, 2000-12-25, 2001-01-01, 2001-01-15, 2001-02-19, 2001-05-28, 2001-07-04, 2001-09-03, 2001-10-08, 2001-11-12, 2001-11-22, 2001-12-25, 2002-01-01, 2002-01-14, 2002-02-18, 2002-05-27, 2002-07-04, 2002-09-02, 2002-10-07, 2002-11-11, 2002-11-28, 2002-12-25, 2003-01-01, 2003-01-13, 2003-02-17, 2003-05-26, 2003-07-04, 2003-09-01, 2003-10-06, 2003-11-10, 2003-11-27, 2003-12-25, 2004-01-01, 2004-01-12, 2004-02-16, 2004-05-31, 2004-07-05.

## Resources

| Resource |
| --- |
| UCB-BOOM |

## Schedule

| ID | WBS | Task | Type | Duration | Start | Finish | Predecessors | Complete | Remaining | Baseline start | Baseline finish | Baseline duration | Total slack | Free slack | Constraint | Text11 | Text12 | Text13 | Text14 | Text16 | Text28 | Text17 | Text20 | Text21 | Text22 | Text23 |
| --- | --- | --- | --- | --- | --- | --- | --- | --- | --- | --- | --- | --- | --- | --- | --- | --- | --- | --- | --- | --- | --- | --- | --- | --- | --- | --- |
| 1 | 1 | **Management** |  | 535.75d | 2002-07-01 A | 2004-08-17 |  |  | 535.75d | 2002-07-01 | 2004-09-15 | 556d | 0d |  |  | STEREO | IMPACT | Boom Suite | Boom | Boom | UC-B |  |  |  |  |  |
| 2 | 1.1 | **Milestones** |  | 535.75d | 2002-07-01 A | 2004-08-17 |  |  | 535.75d | 2002-07-01 | 2004-09-15 | 556d | 0d |  |  | STEREO | IMPACT | Boom Suite | Boom | Boom | UC-B |  |  |  |  |  |
| 3 | 1.1.1 | **Contingency Blocks** |  | 37d | 2004-06-24 | 2004-08-17 |  |  |  | 2004-07-15 | 2004-09-15 | 44d | 0d |  |  | STEREO | IMPACT | Boom Suite | Boom | Boom | UC-B |  |  |  |  |  |
| 4 | 1.1.1.1 | BOOM Suite FM 1 Contingency |  | 35d | 2004-06-24 | 2004-08-13 | 8 |  |  | 2004-07-15 | 2004-09-01 | 35d | 2d | 0d |  | STEREO | IMPACT | Boom Suite | Boom | Boom | UC-B |  |  |  |  |  |
| 5 | 1.1.1.2 | BOOM Suite FM 2 Contingency |  | 35d | 2004-06-28 | 2004-08-17 | 10 |  |  | 2004-07-28 | 2004-09-15 | 35d | 0d |  |  | STEREO | IMPACT | Boom Suite | Boom | Boom | UC-B |  |  |  |  |  |
| 6 | 1.1.2 | **Receivables** |  | 270.75d | 2003-05-31 | 2004-06-28 |  |  |  | 2002-12-09 | 2004-07-27 | 410d | 35d |  |  | STEREO | IMPACT | Boom Suite | Boom | Boom | UC-B |  |  |  |  |  |
| 7 | 1.2.6.2.5 | BOOM Suite FM 1 Complete | milestone | 0d | 2004-06-24 | 2004-06-24 |  |  |  | 2004-07-14 | 2004-07-14 | 0d | 2d | 0d |  | STEREO | IMPACT | Boom Suite | Boom | Boom | UC-B |  |  |  |  |  |
| 8 | 1.1.2.2 | Receive BOOM FM 1 For BOOM Suite Delivery | milestone | 0d | 2004-06-24 | 2004-06-24 | 7 |  |  | 2004-07-14 | 2004-07-14 | 0d | 2d | 0d |  | STEREO | IMPACT | Boom Suite | Boom | Boom | UC-B |  |  |  |  |  |
| 9 | 1.2.6.3.5 | BOOM Suite FM 2 Complete | milestone | 0d | 2004-06-28 | 2004-06-28 |  |  |  | 2004-07-23 | 2004-07-23 | 0d | 0d |  |  | STEREO | IMPACT | Boom Suite | Boom | Boom | UC-B |  |  |  |  |  |
| 10 | 1.1.2.4 | Receive BOOM FM 2 For BOOM Suite Delivery | milestone | 0d | 2004-06-28 | 2004-06-28 | 9 |  |  | 2004-07-27 | 2004-07-27 | 0d | 0d |  |  | STEREO | IMPACT | Boom Suite | Boom | Boom | UC-B |  |  |  |  |  |
| 11 | 1.1.13 | Instrument CDR | milestone | 3d | 2002-11-20 A | 2002-11-22 A |  | 100% |  | 2002-11-20 | 2002-11-22 | 3d |  |  | finish no earlier than 2002-11-22 | STEREO | IMPACT | Boom Suite | Boom | Boom | UC-B | Boom |  |  |  |  |
| 12 | 1.1.2.6 | Receive RFAs From Instrument CDR | milestone | 0d | 2003-05-31 | 2003-05-31 | 11FS+10d |  |  | 2002-12-09 | 2002-12-09 | 0d | 325d |  | start no earlier than 2003-05-31 | STEREO | IMPACT | Boom Suite | Boom | Boom | UC-B |  |  |  |  |  |
| 13 | 1.1.3 | **Deliverables** |  | 535.75d | 2002-07-01 A | 2004-08-17 |  |  | 535.75d | 2002-07-01 | 2004-09-15 | 556d | 0d |  |  | STEREO | IMPACT | Boom Suite | Boom | Boom | UC-B |  |  |  |  |  |
| 14 | 1.1.3.1 | Deliver BOOM Suite FM 1 to APL | milestone | 0d | 2004-08-13 | 2004-08-13 | 4 |  |  | 2004-09-01 | 2004-09-01 | 0d | 2d |  | finish no later than 2004-09-01 | STEREO | IMPACT | Boom Suite | Boom | Boom | UC-B |  | FM 1 Del | Deliver BOOM Suite FM 1L / Bar 2 IMPACT #1 DEL | BOOM Suite - FM 1 Delivery to APL | Deliver BOOM Suite FM 1 to APL |
| 15 | 1.1.3.2 | Deliver BOOM Suite FM 2 to APL | milestone | 0d | 2004-08-17 | 2004-08-17 | 5 |  |  | 2004-09-15 | 2004-09-15 | 0d | 0d |  | finish no later than 2004-09-15 | STEREO | IMPACT | Boom Suite | Boom | Boom | UC-B |  | FM 2 Del | Deliver BOOM Suite FM 2L / Bar 2 IMPACT #2 DEL | BOOM Suite - FM 2 Delivery to APL | Deliver BOOM Suite FM 2 to APL |
| 16 | 1.1.3.3 | Deliver Thermal Models | milestone | 0d | 2002-07-01 A | 2002-07-01 A |  | 100% |  | 2002-07-01 | 2002-07-01 | 0d |  |  | start no earlier than 2002-07-01 | STEREO | IMPACT | Boom Suite | Boom | Boom | UC-B |  |  |  |  |  |
| 17 | 2 | BOOM - Boom Structure |  | 900.75d | 2000-12-11 A | 2004-07-13 |  | 57% | 390.09d | 2000-01-03 | 2004-07-06 | 1133d | 44.25d |  |  | STEREO | IMPACT | Boom Suite | Boom | Boom | UC-B |  |  |  |  |  |
| 18 | 3 | MAG - Magnetometer |  | 804.2d | 2000-09-01 A | 2003-11-18 |  | 82% | 143.11d | 2000-09-01 | 2003-12-01 | 813d | 202.1d |  |  | STEREO | IMPACT | Boom Suite | Boom | MAG | GSFC |  |  |  |  |  |
| 19 | 4 | STE - Suprathermal Electron Telescope and SWEA - Solar Wind Electron Analyzer |  | 795d | 2001-03-06 A | 2004-05-03 |  | 46% | 427.14d | 2001-03-06 | 2004-05-04 | 796d | 93d |  |  | STEREO | IMPACT | Boom Suite | SSI | SWEA/STE-D | UC-B |  |  |  |  |  |
| 20 | 5 | **Emulators/Simulators/GSE** |  | 250d | 2002-07-01 A | 2003-06-27 |  | 44% | 139.95d | 2000-01-03 | 2002-12-30 | 752d | 285.75d |  |  | STEREO | IMPACT | Boom Suite | Boom | Boom | UC-B |  |  |  |  |  |
| 21 | 5.1 | **Simulators** |  | 168.7d | 2002-10-01 A | 2003-06-04 |  | 10% | 151.83d | 2002-10-01 | 2002-12-04 | 43.7d | 303.05d |  |  | STEREO | IMPACT | Boom Suite | Boom | Boom | UC-B |  |  |  |  |  |
| 22 | 5.1.1 | SWEA/STE/LVPS Mass Dummy |  | 3d | 2002-10-01 A | 2003-06-04 |  | 10% | 2.7d | 2002-10-01 | 2002-12-04 | 3d | 303.05d |  | start no earlier than 2002-09-30 | STEREO | IMPACT | Boom Suite | Boom | Boom | UC-B |  |  |  |  |  |
| 23 | 5.2 | **GSE** |  | 250d | 2002-07-01 A | 2003-06-27 |  | 45% | 137.47d | 2000-01-03 | 2002-12-30 | 752d | 285.75d |  |  | STEREO | IMPACT | Boom Suite | Boom | Boom | UC-B |  |  |  |  |  |
| 24 | 5.2.1 | Design GSE Fixtures |  | 5.75d | 2002-09-03 A | 2002-10-02 A |  | 100% |  | 2002-09-03 | 2002-10-02 | 5.75d |  |  | start no earlier than 2002-08-31 | STEREO | IMPACT | Boom Suite | Boom | Boom | UC-B |  |  |  |  |  |
| 25 | 5.2.2 | Inspect GSE Fixtures |  | 1d | 2002-10-07 A | 2003-06-02 |  | 50% | 0.5d | 2002-10-07 | 2002-10-08 | 1d | 305.25d |  | start no earlier than 2002-06-30 | STEREO | IMPACT | Boom Suite | Boom | Boom | UC-B |  |  |  |  |  |
| 26 | 5.2.3 | Inspect Reworked GSE Fixtures |  | 1d | 2003-06-02 | 2003-06-02 |  |  |  | 2000-01-03 | 2000-01-03 | 1d | 324d |  | start no earlier than 2003-05-31 | STEREO | IMPACT | Boom Suite | Boom | Boom | UC-B |  |  |  |  |  |
| 27 | 5.2.4 | GSE Track & Trolleys |  | 20d | 2002-09-03 A | 2003-06-20 |  | 25% | 15d | 2002-09-03 | 2002-09-30 | 20d | 290.75d |  | start no earlier than 2002-08-31 | STEREO | IMPACT | Boom Suite | Boom | Boom | UC-B |  |  |  |  |  |
| 28 | 5.2.5 | GSE Chamber Modifications |  | 20d | 2003-06-02 | 2003-06-27 |  |  |  | 2002-12-02 | 2002-12-30 | 20d | 305d |  | start no earlier than 2003-05-31 | STEREO | IMPACT | Boom Suite | Boom | Boom | UC-B |  |  |  |  |  |
| 29 | 5.2.6 | GSE Vertical Deployment Fixture |  | 14d | 2002-10-01 A | 2002-10-21 A |  | 100% |  | 2002-10-01 | 2002-10-21 | 14d |  |  | start no earlier than 2002-09-30 | STEREO | IMPACT | Boom Suite | Boom | Boom | UC-B |  |  |  |  |  |
| 30 | 5.2.7 | Clean Room Facility |  | 20d | 2002-07-02 A | 2002-09-16 A |  | 100% |  | 2002-07-02 | 2002-09-16 | 20d |  |  | start no earlier than 2002-07-01 | STEREO | IMPACT | Boom Suite | Boom | Boom | UC-B |  |  |  |  |  |
| 31 | 5.2.8 | Shipping Containers |  | 20d | 2003-06-02 | 2003-06-27 |  |  |  | 2002-12-02 | 2002-12-30 | 20d | 305d |  | start no earlier than 2003-05-31 | STEREO | IMPACT | Boom Suite | Boom | Boom | UC-B |  |  |  |  |  |
| 32 | 5.2.9 | Video Camera Available |  | 1d | 2002-07-01 A | 2002-07-01 A |  | 100% |  | 2002-07-01 | 2002-07-01 | 1d |  |  | start no earlier than 2002-07-01 | STEREO | IMPACT | Boom Suite | Boom | Boom | UC-B |  |  |  |  |  |
| 33 | 6 | SWEA - Solar Wind Electron Analyzer (CESR) |  | 883d | 2000-08-05 A | 2004-02-16 |  | 90% | 92.12d | 2000-08-05 | 2004-02-16 | 883d | 148d |  |  | STEREO | IMPACT | Boom Suite | Boom | Boom | UC-B |  |  |  |  |  |
| 34 | 7 | STE - Suprathermal Electron Telescope |  | 977d | 2000-05-26 A | 2004-04-19 |  | 76% | 231.08d | 2000-05-26 | 2004-04-19 | 977d | 97.3d |  |  | STEREO | IMPACT | Boom Suite | Boom | Boom | UC-B |  |  |  |  |  |
| 35 | 8 | BOOM I & T |  | 510.75d | 2002-07-01 A | 2004-07-13 |  |  | 510.75d | 2002-07-01 | 2004-07-27 | 521d | 25d |  |  | STEREO | IMPACT | Boom Suite | Boom | Boom | UC-B |  |  |  |  |  |

Notes:
- 4: Removed 51 days of duration 1/9/03
- 5: Removed 19 days of duration 1/9/03
