# IDPU

Schedule from MS Project, 2000-06-09 to 2004-07-12, status date 2003-05-31, A marks actual dates.
IDPU-IMPACT Data Processing Unit Development Sche
NASA GSFC
Status Date: 05/31/2003 / Baseline Date: 01/31/2003 R1

## Calendars

- Standard w/ 10 Gov't Holidays: Mon-Fri 08:00-12:00, 13:00-17:00; Sat-Sun off. Exceptions (off unless hours are given): 2000-07-04, 2000-09-04, 2000-10-09, 2000-11-13, 2000-11-23, 2000-12-25, 2001-01-01, 2001-01-15, 2001-02-19, 2001-05-28, 2001-07-04, 2001-09-03, 2001-10-08, 2001-11-12, 2001-11-22, 2001-12-25, 2002-01-01, 2002-01-14, 2002-02-18, 2002-05-27, 2002-07-04, 2002-09-02, 2002-10-07, 2002-11-11, 2002-11-28, 2002-12-25, 2003-01-01, 2003-01-13, 2003-02-17, 2003-05-26, 2003-07-04, 2003-09-01, 2003-10-06, 2003-11-10, 2003-11-27, 2003-12-25, 2004-01-01, 2004-01-12, 2004-02-16, 2004-05-31, 2004-07-05.

## Schedule

| ID | WBS | Task | Type | Duration | Start | Finish | Predecessors | Complete | Remaining | Baseline start | Baseline finish | Baseline duration | Total slack | Free slack | Constraint | Text11 | Text12 | Text28 | Text13 | Text14 | Text23 | Text16 | Text17 |
| --- | --- | --- | --- | --- | --- | --- | --- | --- | --- | --- | --- | --- | --- | --- | --- | --- | --- | --- | --- | --- | --- | --- | --- |
| 1 | 1 | **Management** |  | 988d | 2000-06-09 A | 2004-05-17 |  | 97% | 25.46d | 2000-01-01 | 2004-06-04 | 1112d | 38d |  |  | STEREO | IMPACT | UC-B |  |  |  |  |  |
| 2 | 1.1 | **Milestones** |  | 988d | 2000-06-09 A | 2004-05-17 |  | 97% | 25.53d | 2000-01-01 | 2004-06-04 | 1112d | 38d |  |  | STEREO | IMPACT | UC-B |  |  |  |  |  |
| 3 | 1.1.1 | IDPU FM 1 Complete | milestone | 0d | 2004-02-10 | 2004-02-10 | 9 |  |  | 2004-02-10 | 2004-02-10 | 0d | 106d |  |  | STEREO | IMPACT |  | IDPU | IDPU | FM 1 Ready |  |  |
| 4 | 1.1.2 | IDPU FM 2 Complete | milestone | 0d | 2004-03-30 | 2004-03-30 | 10 |  |  | 2004-03-30 | 2004-03-30 | 0d | 72d |  |  | STEREO | IMPACT |  | IDPU | IDPU | FM 2 Ready |  |  |
| 5 | 1.1.3 | **Contingency Blocks** |  | 733d | 2001-04-27 A | 2004-03-30 |  | 97% | 19.29d | 2001-04-27 | 2004-03-30 | 733d | 72d |  |  | STEREO | IMPACT | UC-B |  |  |  |  |  |
| 6 | 1.1.3.1 | IDPU System Design Contingency |  | 170d | 2001-04-27 A | 2001-12-31 A | 120 | 100% |  | 2001-04-27 | 2001-12-31 | 170d |  |  |  | STEREO | IMPACT | UC-B | IDPU | IDPU |  | IDPU | SEP DPU |
| 7 | 1.1.3.2 | IDPU ETU Contingency |  | 20d | 2003-02-10 A | 2003-03-10 A | 161 | 100% |  | 2003-02-25 | 2003-02-25 | 20d |  |  |  | STEREO | IMPACT | UC-B | IDPU | IDPU |  | IDPU |  |
| 8 | 1.1.3.3 | Second IDPU ETU Contingency | milestone | 0d | 2002-09-16 A | 2002-09-16 A | 151 | 100% |  | 2002-09-16 | 2002-09-16 | 0d |  |  |  | STEREO | IMPACT | UC-B | IDPU | IDPU |  | IDPU |  |
| 9 | 1.1.3.4 | IDPU FM 1 Contingency |  | 10d | 2004-01-28 | 2004-02-10 | 171 |  |  | 2003-12-19 | 2004-02-10 | 35d | 0d |  |  | STEREO | IMPACT | UC-B | IDPU | IDPU |  | IDPU |  |
| 10 | 1.1.3.5 | IDPU FM 2 Contingency | milestone | 0d | 2004-03-30 | 2004-03-30 | 178 |  |  | 2004-03-03 | 2004-03-30 | 20d | 68d | 0d |  | STEREO | IMPACT | UC-B | IDPU | IDPU |  | IDPU |  |
| 11 | 1.1.3.6 | (OBSOLETE)IDPU S/W Build 1 to UNH Contingency | milestone | 0d | 2003-05-31 | 2003-05-31 |  |  |  | 2002-11-30 | 2002-11-30 | 0d | 280d | 0d | start no earlier than 2003-05-31 | STEREO | IMPACT | UC-B | IDPU | IDPU |  | IDPU |  |
| 12 | 1.1.3.7 | IDPU S/W Build 2 to UNH Contingency | milestone | 0d | 2003-05-31 | 2003-05-31 | 155 |  |  | 2003-04-03 | 2003-04-03 | 0d | 280d | 0d | start no earlier than 2003-05-31 | STEREO | IMPACT | UC-B | IDPU | IDPU |  | IDPU |  |
| 13 | 1.1.3.8 | IDPU S/W Build 3 to UNH Contingency | milestone | 0d | 2004-01-08 | 2004-01-08 | 157 |  |  | 2004-01-09 | 2004-01-09 | 0d | 128d | 0d |  | STEREO | IMPACT | UC-B | IDPU | IDPU |  | IDPU |  |
| 14 | 1.1.3.9 | IDPU Simulator Hardware Contingency For MAG |  | 156d | 2001-09-14 A | 2002-04-30 A | 181 | 100% |  | 2001-09-14 | 2002-04-30 | 156d |  |  |  | STEREO | IMPACT | UC-B | IDPU | IDPU |  | IDPU |  |
| 15 | 1.1.3.10 | IDPU Simulator Software Contingency MAG |  | 1d | 2002-07-03 A | 2002-07-03 A | 183 | 100% |  | 2002-07-03 | 2002-07-03 | 1d |  |  |  | STEREO | IMPACT | UC-B | IDPU | IDPU |  | IDPU |  |
| 16 | 1.1.3.11 | IDPU Simulator Hardware Contingency For CIT | milestone | 0d | 2002-12-16 A | 2002-12-16 A | 181 | 100% |  | 2002-12-16 | 2002-12-16 | 0d |  |  | start no earlier than 2002-11-30 | STEREO | IMPACT | UC-B | IDPU | IDPU |  | IDPU |  |
| 17 | 1.1.3.12 | IDPU Simulator Software Contingency For CIT | milestone | 0d | 2002-12-16 A | 2002-12-16 A | 184 | 100% |  | 2002-12-16 | 2002-12-16 | 0d |  |  | start no earlier than 2002-11-30 | STEREO | IMPACT | UC-B | IDPU | IDPU |  | IDPU |  |
| 18 | 1.1.3.13 | IDPU Simulator Hardware Contingency For UNH | milestone | 0d | 2002-08-01 A | 2002-08-01 A | 181 | 100% |  | 2002-08-01 | 2002-08-01 | 0d |  |  |  | STEREO | IMPACT | UC-B | IDPU | IDPU |  | IDPU |  |
| 19 | 1.1.3.14 | IDPU Simulator Software Contingency For UNH | milestone | 0d | 2002-10-31 A | 2002-10-31 A | 185 | 100% |  | 2002-10-31 | 2002-10-31 | 0d |  |  |  | STEREO | IMPACT | UC-B | IDPU | IDPU |  | IDPU |  |
| 20 | 1.1.3.15 | IDPU Simulator Hardware GSE Contingency for UCB (SWEA/STE) |  | 22d | 2002-08-01 A | 2002-08-30 A | 181 | 100% |  | 2002-08-01 | 2002-08-30 | 22d |  |  | start no earlier than 2002-07-31 | STEREO | IMPACT | UC-B | IDPU | IDPU |  | IDPU |  |
| 21 | 1.1.3.16 | IDPU Simulator Software Contingency For UCB (SWEA/STE) | milestone | 0d | 2002-11-28 A | 2002-11-28 A | 186 | 100% |  | 2002-11-28 | 2002-11-28 | 0d |  |  | start no earlier than 2002-10-31 | STEREO | IMPACT | UC-B | IDPU | IDPU |  | IDPU |  |
| 22 | 1.1.3.17 | MAG Science Display GSE Contingency |  | 1d | 2003-02-03 A | 2003-02-03 A | 191 | 100% |  | 2003-01-16 | 2003-01-16 | 1d |  |  |  | STEREO | IMPACT | UC-B | Boom Suite | MAG |  | IDPU |  |
| 23 | 1.1.3.18 | SWEA Science Display GSE Contingency | milestone | 0d | 2003-06-27 | 2003-06-27 | 192 |  |  | 2003-02-13 | 2003-02-13 | 0d | 260d | 0d | start no earlier than 2003-05-31 | STEREO | IMPACT | UC-B | Boom Suite | SWEA |  | IDPU |  |
| 24 | 1.1.3.19 | STE Science Display GSE Contingency | milestone | 0d | 2003-07-14 | 2003-07-14 | 193 |  |  | 2003-02-28 | 2003-02-28 | 0d | 250d | 0d |  | STEREO | IMPACT | UC-B | Boom Suite | STE |  | IDPU |  |

Notes:
- 7: Removed 35 days of duration 1/9/03
- 8: Removed 39 days of duration 1/9/03
- 9: Removed 24 days of duration 1/9/03
- 11: Removed 19 days of duration 1/9/03, Per Dave Curtis e-mail UNH doesn't receive Build 1
- 12: Removed 7 days of duration 1/9/03
- 13: Removed 5 days of duration 1/9/03
- 16: Removed 1 day of duration 1/9/03
- 18: Removed 65 days of duration 1/9/03
- 19: Removed 2 days of duration 1/9/03

| ID | WBS | Task | Type | Duration | Start | Finish | Predecessors | Complete | Remaining | Baseline start | Baseline finish | Baseline duration | Total slack | Free slack | Constraint | Text11 | Text12 | Text28 | Text14 | Text23 | Text13 | Text16 | Text21 |
| --- | --- | --- | --- | --- | --- | --- | --- | --- | --- | --- | --- | --- | --- | --- | --- | --- | --- | --- | --- | --- | --- | --- | --- |
| 25 | 1.1.4 | **Receivables** |  | 988d | 2000-06-09 A | 2004-05-17 |  | 99% | 0d | 2000-06-09 | 2004-06-04 | 1001d | 38d |  |  | STEREO | IMPACT | UC-B |  |  |  |  |  |
| 26 | 1.1.3.3.1 | Deliver IDPU ETU LVPS |  | 1d | 2003-02-05 A | 2003-02-05 A |  | 100% |  | 2003-02-10 | 2003-02-10 | 1d |  |  | finish no later than 2003-02-10 | STEREO | IMPACT |  |  |  |  |  |  |
| 27 | 1.1.4.2 | Receive ETU IDPU LVPS From UC-B | milestone | 0d | 2003-02-05 A | 2003-02-05 A | 26 | 100% |  | 2003-02-10 | 2003-02-10 | 0d |  |  |  | STEREO | IMPACT |  | IDPU | ETU LVPS Received |  |  |  |
| 28 | 1.1.3.4.2 | Deliver IDPU FM 1 LVPS | milestone | 0d | 2003-08-20 | 2003-08-20 |  |  |  | 2003-10-08 | 2003-10-08 | 0d | 37d | 0d |  | STEREO | IMPACT |  |  |  |  |  |  |
| 29 | 1.1.4.4 | Receive FM 1 IDPU LVPS From UC-B | milestone | 0d | 2003-08-20 | 2003-08-20 | 28 |  |  | 2003-10-08 | 2003-10-08 | 0d | 58d |  |  | STEREO | IMPACT |  | IDPU | FM 1 LVPS Received |  |  |  |
| 30 | 1.1.3.5.2 | Deliver IDPU FM 2 LVPS | milestone | 0d | 2003-11-17 | 2003-11-17 |  |  |  | 2004-01-05 | 2004-01-05 | 0d | 36d | 0d |  | STEREO | IMPACT |  |  |  |  |  |  |
| 31 | 1.1.4.6 | Receive FM 2 IDPU LVPS From UC-B | milestone | 0d | 2003-11-17 | 2003-11-17 | 30 |  |  | 2004-01-05 | 2004-01-05 | 0d | 118d | 52d |  | STEREO | IMPACT |  | IDPU | FM 2 LVPS Received |  |  |  |
| 32 | 1.1.5.1 | Deliver ETU MAG to UC-B For IDPU Test |  | 1d | 2003-01-20 A | 2003-01-20 A |  | 100% |  | 2003-01-20 | 2003-01-20 | 1d |  |  | start no earlier than 2002-07-31 | STEREO | IMPACT |  |  |  |  |  |  |
| 33 | 1.1.4.8 | Receive ETU MAG From GSFC For ETU IDPU Test |  | 1d | 2003-01-20 A | 2003-01-20 A | 32 | 100% |  | 2003-01-20 | 2003-01-20 | 1d |  |  |  | STEREO | IMPACT | UC-B | IDPU | ETU MAG For ETU I & T Received | Boom Suite | MAG |  |
| 34 | 1.1.5.3 | Deliver MAG FM 1 For IDPU/Boom Suite FM 1 I & T | milestone | 0d | 2003-10-03 | 2003-10-03 |  |  |  | 2003-06-30 | 2003-06-30 | 0d | 0.8d | 0d | finish no later than 2003-10-03 | STEREO | IMPACT |  |  |  |  |  |  |
| 35 | 1.1.4.10 | Receive FM 1 MAG From GSFC For FM 1 IDPU Test | milestone | 0d | 2003-10-13 | 2003-10-13 | 34FS+5d |  |  | 2003-07-08 | 2003-07-08 | 0d | 22.8d |  |  | STEREO | IMPACT | UC-B | IDPU | FM 1 MAG For ETU I & T Received | Boom Suite | MAG |  |
| 36 | 1.1.5.5 | Deliver MAG FM 2 For IDPU/BOOM Suite FM 2 I & T | milestone | 0d | 2003-11-18 | 2003-11-18 |  |  |  | 2003-12-01 | 2003-12-01 | 0d | 0d |  | finish no later than 2003-11-18 | STEREO | IMPACT |  |  |  |  |  |  |
| 37 | 1.1.4.12 | Receive FM 2 MAG From GSFC For FM 2IDPU Test | milestone | 0d | 2003-11-25 | 2003-11-25 | 36FS+5d |  |  | 2003-12-08 | 2003-12-08 | 0d | 88.1d | 46.8d |  | STEREO | IMPACT | UC-B | IDPU | FM 2 MAG For ETU I & T Received | Boom Suite | MAG |  |
| 38 | 1.2.7.9 | Deliver IDPU ETU to UC-B W/ SEP ETU/IDPU ETU I/F Test Results | milestone | 0d | 2003-05-09 A | 2003-05-09 A |  | 100% |  | 2003-07-29 | 2003-07-29 | 0d |  |  |  | STEREO | IMPACT |  |  |  |  |  |  |
| 39 | 1.1.4.14 | Receive ETU IDPU Back From CIT SEP/IDPU I/F Test | milestone | 0d | 2003-05-09 A | 2003-05-09 A | 38 | 100% |  | 2003-07-29 | 2003-07-29 | 0d |  |  |  | STEREO | IMPACT | UC-B | IDPU |  | SEP Package | IDPU |  |
| 40 | 1.1.3.5 | Deliver SWEA/STE-D ETU For IDPU Interface Test | milestone | 0d | 2003-06-27 | 2003-06-27 |  |  |  | 2003-05-02 | 2003-05-02 | 0d | 221d | 0d |  | STEREO | IMPACT |  |  |  |  |  |  |
| 41 | 1.1.4.16 | Receive ETU SWEA/STE-D For ETU IDPU Test | milestone | 0d | 2003-06-27 | 2003-06-27 | 40 |  |  | 2003-05-02 | 2003-05-02 | 0d | 250d | 0d |  | STEREO | IMPACT | UC-B | IDPU | ETU SWEA/STE-D I/F For ETU I & T Received | Boom Suite | SWEA/STE-D |  |
| 42 | 1.1.3.9 | (OBSOLETE) Deliver STE-U ETU Interface for IDPU STE-U Interface Test | milestone | 0d | 2003-07-21 | 2003-07-21 |  |  |  | 2003-03-24 | 2003-03-24 | 0d | 206d | 0d | start no earlier than 2003-02-01 | STEREO | IMPACT |  |  |  |  |  |  |
| 43 | 1.1.4.18 | (OBSOLETE) Receive ETU STE-U For ETU IDPU Test | milestone | 0d | 2003-07-21 | 2003-07-21 | 42 |  |  | 2003-03-24 | 2003-03-24 | 0d | 235d | 0d |  | STEREO | IMPACT | UC-B | IDPU |  | Boom Suite | STE-U |  |
| 44 | 1.1.4.19 | Receive Emulator #1 Hardware From APL | milestone | 0d | 2001-06-22 A | 2001-06-22 A |  | 100% |  | 2001-06-22 | 2001-06-22 | 0d |  |  | start no earlier than 2001-06-22 | STEREO | IMPACT | UC-B | IDPU |  | S/C |  | Emulator #1 H/W to UCB |
| 45 | 1.1.4.20 | Receive Emulator Interim Software (Telemetry) From APL | milestone | 0d | 2002-07-01 A | 2002-07-01 A |  | 100% |  | 2002-07-01 | 2002-07-01 | 0d |  |  | start no earlier than 2002-07-01 | STEREO | IMPACT | UC-B | IDPU |  | S/C |  | Emulator Interim S/W (Telem.) |
| 46 | 1.1.4.21 | Receive Emulator Hardware #2 From APL | milestone | 0d | 2002-12-02 A | 2002-12-02 A |  | 100% |  | 2002-12-02 | 2002-12-02 | 0d |  |  | start no earlier than 2003-01-15 | STEREO | IMPACT | UC-B | IDPU |  | S/C |  | Emulator H/W #2 & Full S/W to UCB |
| 47 | 1.1.4.22 | Receive Emulator Full Software from APL | milestone | 0d | 2002-12-02 A | 2002-12-02 A |  | 100% |  | 2002-12-02 | 2002-12-02 | 0d |  |  | start no earlier than 2003-01-15 | STEREO | IMPACT | UC-B | IDPU |  | S/C |  | Emulator H/W #2 & Full S/W to UCB |
| 48 | 1.1.4.23 | Receive PLASTIC Software Requirements SPEC From UNH | milestone | 0d | 2001-06-01 A | 2001-06-01 A |  | 100% |  | 2001-06-01 | 2001-06-01 | 0d |  |  | start no earlier than 2001-06-01 | STEREO | PLASTIC | UC-B | IDPU |  | PLASTIC |  |  |
| 49 | 1.1.4.24 | Receive Final PLASTIC Software Requirements SPEC From UNH | milestone | 0d | 2002-07-31 A | 2002-07-31 A |  | 100% |  | 2002-07-31 | 2002-07-31 | 0d |  |  | start no earlier than 2002-07-31 | STEREO | IMPACT | UC-B | IDPU |  | PLASTIC |  |  |
| 50 | 1.1.4.25 | Receive IDPU/Instrument Interface SPEC Draft | milestone | 0d | 2000-06-09 A | 2000-06-09 A |  | 100% |  | 2000-06-09 | 2000-06-09 | 0d |  |  | start no earlier than 2002-06-30 | STEREO | IMPACT | UC-B | IDPU |  | IDPU | IDPU |  |
| 51 | 1.1.4.26 | Receive PLASTIC Simulator From UNH | milestone | 0d | 2003-04-23 A | 2003-04-23 A |  | 100% |  | 2002-12-01 | 2002-12-01 | 0d |  |  | start no earlier than 2003-04-30 | STEREO | PLASTIC | UC-B | IDPU |  | PLASTIC |  |  |
| 52 | 1.2.6.2.1 | Deliver IDPU FM 1 After BOOM Suite/IDPU I & T | milestone | 0d | 2004-04-19 | 2004-04-19 |  |  |  | 2004-04-08 | 2004-04-08 | 0d | 58d | 0d |  | STEREO | IMPACT |  |  |  |  |  |  |
| 53 | 1.1.4.28 | Receive IDPU FM 1 From BOOM Suite/IDPU I & T | milestone | 0d | 2004-04-19 | 2004-04-19 | 52 |  |  | 2004-04-08 | 2004-04-08 | 0d | 58d |  |  | STEREO | IMPACT | UC-B | IDPU |  | IDPU | IDPU |  |
| 54 | 1.2.6.3.1 | Deliver IDPU FM 2 After BOOM Suite/IDPU I & T | milestone | 0d | 2004-05-17 | 2004-05-17 |  |  |  | 2004-06-09 | 2004-06-09 | 0d | 38d | 0d |  | STEREO | IMPACT |  |  |  |  |  |  |
| 55 | 1.1.4.30 | Receive IDPU FM 2 From BOOM Suite/IDPU I & T | milestone | 0d | 2004-05-17 | 2004-05-17 | 54 |  |  | 2004-06-04 | 2004-06-04 | 0d | 38d |  |  | STEREO | IMPACT | UC-B | IDPU |  | IDPU | IDPU |  |
| 56 | 1.2.7.11 | Deliver IDPU FM 1 to UC-B From SEP FM 1/ IDPU FM 1 Testing | milestone | 0d | 2004-04-21 | 2004-04-21 |  |  |  | 2004-04-08 | 2004-04-08 | 0d | -8.75d | 0d |  | STEREO | IMPACT |  |  |  |  |  |  |
| 57 | 1.1.4.32 | Receive IDPU FM 2 From SEP Package/IDPU I & T | milestone | 0d | 2004-04-21 | 2004-04-21 | 56 |  |  | 2004-04-08 | 2004-04-08 | 0d | -8.75d | 0d |  | STEREO | IMPACT | UC-B | IDPU |  | IDPU | IDPU |  |
| 58 | 1.1.4.33 | Receive FM 1 STE-U I/F For IDPU/STE-U I/F Testing | milestone | 0d | 2003-11-13 | 2003-11-13 | 59 |  |  | 2003-09-17 | 2003-09-17 | 0d | -4d | 0d |  | STEREO | IMPACT |  | IDPU |  | Boom Suite |  |  |
| 59 | 1.1.3.11 | Deliver STE-U FM 1 Interface For IDPU FM 1 I & T | milestone | 0d | 2003-11-13 | 2003-11-13 |  |  |  | 2003-09-17 | 2003-09-17 | 0d | -4d | 0d |  | STEREO | IMPACT |  |  |  |  |  |  |
| 60 | 1.1.3.15 | Deliver STE-U FM 2 Interface For IDPU FM 2 I & T | milestone | 0d | 2003-12-12 | 2003-12-12 |  |  |  | 2003-10-16 | 2003-10-16 | 0d | 81d | 0d |  | STEREO | IMPACT |  |  |  |  |  |  |
| 61 | 1.1.4.36 | Receive FM 2 STE-U I/F For IDPU/STE-U I/F Testing | milestone | 0d | 2003-12-12 | 2003-12-12 | 60 |  |  | 2003-10-16 | 2003-10-16 | 0d | 81d | 34d |  | STEREO | IMPACT |  | IDPU |  | Boom Suite |  |  |

Notes:
- 43: Same as for STE-D only need one board for ETU purposes. The flight boards will need to be built
- 46: Delivery Delayed per 11/30/02 schedule. Date moved from 12/2/02 to 1/15/03. / Per Dave actually got it early sent it back for correct Actel, problem was on APL side so testing completed in December.
- 47: Delivery Delayed per 11/30/02 schedule. Date moved from 12/2/02 to 1/15/03. / Per Dave actually got H/W early sent it back for correct Actel, problem was on APL side so testing completed in December.

| ID | WBS | Task | Type | Duration | Start | Finish | Predecessors | Complete | Remaining | Baseline start | Baseline finish | Baseline duration | Total slack | Free slack | Constraint | Text11 | Text12 | Text28 | Text13 | Text14 | Text16 | Text21 | Text20 | Text22 | Text23 |
| --- | --- | --- | --- | --- | --- | --- | --- | --- | --- | --- | --- | --- | --- | --- | --- | --- | --- | --- | --- | --- | --- | --- | --- | --- | --- |
| 62 | 1.1.5 | **Deliverables** |  | 538.75d | 2002-03-01 A | 2004-04-21 |  | 99% | 0d | 2000-01-01 | 2004-04-08 | 1072d | 56.25d |  |  | STEREO | IMPACT | UC-B |  |  |  |  |  |  |  |
| 63 | 1.1.5.1 | Deliver MAG/DCB PWB Form Factor | milestone | 0d | 2002-03-01 A | 2002-03-01 A |  | 100% |  | 2002-03-01 | 2002-03-01 | 0d |  |  |  | STEREO | IMPACT | UC-B | Boom Suite | MAG | IDPU |  |  |  |  |
| 64 | 1.1.4.6 | Receive MAG/DCB PWB Form Factor | milestone | 0d | 2002-03-01 A | 2002-03-01 A | 63 | 100% |  | 2002-03-01 | 2002-03-01 | 0d |  |  |  | STEREO | IMPACT |  |  |  |  |  |  |  |  |
| 65 | 1.1.5.3 | Deliver IDPU Simulator GSE Hardware to GSFC |  | 1d | 2002-07-03 A | 2002-07-03 A | 14 | 100% |  | 2002-07-03 | 2002-07-03 | 1d |  |  | start no earlier than 2002-07-01 | STEREO | IMPACT | UC-B | IDPU | MAG | IDPU |  |  |  |  |
| 66 | 1.1.4.2 | Receive MAG IDPU Simulator GSE Hardware From UC-B | milestone | 0d | 2002-07-03 A | 2002-07-03 A | 65 | 100% |  | 2002-07-03 | 2002-07-03 | 0d |  |  | start no earlier than 2002-07-01 | STEREO | IMPACT |  |  |  |  |  |  |  |  |
| 67 | 1.1.5.5 | Deliver IDPU Simulator Software to GSFC | milestone | 0d | 2002-07-03 A | 2002-07-03 A | 15 | 100% |  | 2002-07-03 | 2002-07-03 | 0d |  |  |  | STEREO | IMPACT | UC-B | IDPU | MAG | IDPU |  |  |  |  |
| 68 | 1.1.5.6 | Deliver IDPU Simulator GSE Hardware to CIT | milestone | 0d | 2002-12-16 A | 2002-12-16 A | 16 | 100% |  | 2002-12-16 | 2002-12-16 | 0d |  |  | start no earlier than 2002-11-30 | STEREO | IMPACT | UC-B | IDPU | SEP Cen | IDPU |  |  |  |  |
| 69 | 1.1.5.7 | Deliver IDPU Simulator Software to CIT | milestone | 0d | 2002-12-16 A | 2002-12-16 A | 17 | 100% |  | 2002-12-16 | 2002-12-16 | 0d |  |  | start no earlier than 2002-11-30 | STEREO | IMPACT | UC-B | IDPU | SEP Cen | IDPU | SEP IDPU Sim to CIT |  |  |  |
| 70 | 1.1.5.8 | Deliver IDPU Simulator GSE Hardware to UNH |  | 1d | 2002-11-29 A | 2002-11-29 A | 18 | 100% |  | 2002-11-29 | 2002-11-29 | 1d |  |  | start no earlier than 2002-11-30 | STEREO | IMPACT | UC-B | IDPU |  | IDPU |  |  |  |  |
| 71 | 1.1.5.9 | Deliver IDPU Simulator Software to UNH |  | 1d | 2002-11-29 A | 2002-11-29 A | 19 | 100% |  | 2002-11-29 | 2002-11-29 | 1d |  |  | start no earlier than 2002-11-30 | STEREO | IMPACT | UC-B | IDPU |  | IDPU | SWEA/STE IDPU Sim to CIT |  |  |  |
| 72 | 1.1.5.10 | Deliver IDPU Simulator GSE Hardware for SWEA/STE | milestone | 0d | 2002-08-30 A | 2002-08-30 A | 20 | 100% |  | 2002-08-30 | 2002-08-30 | 0d |  |  | start no earlier than 2002-05-31 | STEREO | IMPACT | UC-B | IDPU | SSI | IDPU |  |  |  |  |
| 73 | 1.1.2.14 | Receive IDPU Simulator Hardware GSE From UC-B | milestone | 0d | 2002-11-29 A | 2002-11-29 A | 72 | 100% |  | 2002-11-29 | 2002-11-29 | 0d |  |  | start no earlier than 2002-11-30 | STEREO | IMPACT |  |  |  |  |  |  |  |  |
| 74 | 1.1.5.12 | Deliver IDPU Simulator Software for SWEA/STE | milestone | 0d | 2002-11-29 A | 2002-11-29 A | 21 | 100% |  | 2002-11-29 | 2002-11-29 | 0d |  |  | start no earlier than 2002-10-31 | STEREO | IMPACT | UC-B | IDPU | SSI | IDPU |  |  |  |  |
| 75 | 1.1.2.16 | Receive IDPU Simulator Software From UC-B | milestone | 0d | 2002-11-29 A | 2002-11-29 A | 74 | 100% |  | 2002-11-29 | 2002-11-29 | 0d |  |  | start no earlier than 2002-11-30 | STEREO | IMPACT |  |  |  |  |  |  |  |  |
| 76 | 1.1.5.14 | Deliver IDPU GSE Harness to UNH | milestone | 0d | 2003-05-31 | 2003-05-31 |  |  |  | 2002-11-30 | 2002-11-30 | 0d | 280d |  | start no earlier than 2003-05-31 | STEREO | IMPACT | UC-B | IDPU |  | IDPU |  |  |  |  |
| 77 | 1.1.5.15 | Deliver IDPU Flight Harness to UNH | milestone | 0d | 2003-05-31 | 2003-05-31 |  |  |  | 2002-11-30 | 2002-11-30 | 0d | 280d |  | start no earlier than 2003-05-31 | STEREO | IMPACT | UC-B | IDPU |  | IDPU |  |  |  |  |
| 78 | 1.1.5.16 | Deliver IDPU Flight Actels to UNH | milestone | 0d | 2003-05-31 | 2003-05-31 |  |  |  | 2002-11-30 | 2002-11-30 | 0d | 280d |  | start no earlier than 2003-05-31 | STEREO | IMPACT | UC-B | IDPU |  | IDPU |  |  |  |  |
| 79 | 1.1.5.17 | Deliver IMPACT IDPU Command & Display GSE Revision 1 | milestone | 0d | 2002-12-17 A | 2002-12-17 A | 190 | 100% |  | 2002-12-17 | 2002-12-17 | 0d |  |  |  | STEREO | IMPACT | UC-B | IDPU | IDPU | IDPU | C&D GSE Rev. 1 Avail |  |  |  |
| 80 | 1.1.4.4 | Receive MAG IDPU Simulator Software From UC-B | milestone | 0d | 2002-07-03 A | 2002-07-03 A | 67 | 100% |  | 2002-07-03 | 2002-07-03 | 0d |  |  | start no earlier than 2002-05-31 | STEREO | IMPACT |  |  |  |  |  |  |  |  |
| 81 | 1.1.5.19 | Deliver ETU MAG/IDPU Test Results |  | 1d | 2003-01-28 A | 2003-01-28 A | 162 | 100% |  | 2003-01-28 | 2003-01-28 | 1d |  |  |  | STEREO | IMPACT | UC-B | Boom Suite | MAG | IDPU |  |  |  |  |
| 82 | 1.1.5.20 | Deliver IDPU ETU/IDPU LVPS I/F Test Results |  | 1d | 2003-02-10 A | 2003-02-10 A | 161 | 100% |  | 2003-02-25 | 2003-02-25 | 1d |  |  |  | STEREO | IMPACT |  |  | PS |  |  |  |  |  |
| 83 | 1.1.2.4 | Receive IDPU LVPS ETU/IDPU ETU I/F Test Results |  | 1d | 2003-02-14 A | 2003-02-14 A | 82 | 100% |  | 2003-02-25 | 2003-02-25 | 1d |  |  |  | STEREO | IMPACT |  |  |  |  |  |  |  |  |
| 84 | 1.1.5.22 | Deliver ETU IDPU to CIT For SEP/IDPU I/F Test | milestone | 0d | 2003-05-08 A | 2003-05-08 A | 163 | 100% |  | 2003-05-16 | 2003-05-16 | 0d |  |  | finish no earlier than 2003-05-01 | STEREO | IMPACT | UC-B | SEP Package | SEP Cen | IDPU |  |  |  |  |
| 85 | 1.2.6.10.2 | Receive ETU IDPU From UC-B For SEP ETU/IDPU ETU I/F Test | milestone | 0d | 2003-05-08 A | 2003-05-08 A | 84 | 100% |  | 2003-05-23 | 2003-05-23 | 0d |  |  | start no earlier than 2003-05-23 | STEREO | IMPACT |  |  |  |  |  |  |  |  |
| 86 | 1.1.5.24 | Deliver IDPU ETU | milestone | 0d | 2003-02-15 A | 2003-02-15 A | 7 | 100% |  | 2003-02-25 | 2003-02-25 | 1d |  |  |  | STEREO | IMPACT | UC-B | IDPU | IDPU | IDPU | ETU Cmplt. | ETU IDPU | IDPU - ETU Complete (Final Testing) | IDPU - ETU Complete (Final Testing) |
| 87 | 1.1.5.25 | Deliver Second IDPU ETU to UNH | milestone | 0d | 2003-03-31 A | 2003-03-31 A | 8 | 100% |  | 2002-11-30 | 2002-11-30 | 0d |  |  | start no earlier than 2003-03-31 | STEREO | IMPACT | UC-B | IDPU |  | IDPU |  |  |  |  |
| 88 | 1.1.5.26 | (Obsolete) Deliver IDPU S/W Build 1 to UNH | milestone | 0d | 2003-05-31 | 2003-05-31 | 11 |  |  | 2002-11-30 | 2002-11-30 | 0d | 280d |  | start no earlier than 2003-05-31 | STEREO | IMPACT | UC-B | IDPU |  | IDPU |  |  |  |  |
| 89 | 1.1.5.27 | Deliver IDPU S/W Build 2 to UNH | milestone | 0d | 2003-05-31 | 2003-05-31 | 12 |  |  | 2003-04-03 | 2003-04-03 | 0d | 280d |  | start no earlier than 2003-05-31 | STEREO | IMPACT | UC-B | IDPU |  | IDPU |  |  |  |  |
| 90 | 1.1.5.28 | Deliver IDPU S/W Build 3 to UNH | milestone | 0d | 2004-01-08 | 2004-01-08 | 13 |  |  | 2004-01-09 | 2004-01-09 | 0d | 128d |  |  | STEREO | IMPACT | UC-B | IDPU |  | IDPU |  |  |  |  |
| 91 | 1.1.5.29 | Deliver IDPU FM 1 For BOOM Suite I & T | milestone | 0d | 2004-02-10 | 2004-02-10 | 9 |  |  | 2004-02-10 | 2004-02-10 | 0d | 0d |  | finish no later than 2004-02-10 | STEREO | IMPACT | UC-B | IDPU | IDPU | IDPU |  | FM 1 IDPU | IDPU - FM 1 Ready For Boom Suite I & T | FM 1 IDPU Delivery for BOOM Suite I & T |
| 92 | 1.2.5.2.12 | Receive IDPU FM 1 For BOOM Suite/IDPU I & T | milestone | 0d | 2004-02-18 | 2004-02-18 | 91FS+5d |  |  | 2004-02-18 | 2004-02-18 | 0d | 37d |  |  | STEREO | IMPACT |  |  |  |  |  |  |  |  |
| 93 | 1.1.5.31 | Deliver IDPU FM 2 For BOOM Suite I & T | milestone | 0d | 2004-04-21 | 2004-04-21 | 57 |  |  | 2004-04-08 | 2004-04-08 | 0d | -8.75d | 0d | finish no later than 2004-04-08 | STEREO | IMPACT | UC-B | IDPU | IDPU | IDPU |  | FM2 IDPU | IDPU - FM 2 Ready For Boom Suite I & T | FM 2 IDPU Delivery for BOOM Suite I & T |
| 94 | 1.2.5.3.8 | Receive IDPU FM 2 For BOOM Suite/IDPU I & T | milestone | 0d | 2004-04-21 | 2004-04-21 | 93 |  |  | 2004-04-08 | 2004-04-08 | 0d | 10d |  |  | STEREO | IMPACT |  |  |  |  |  |  |  |  |
| 95 | 1.1.5.33 | Deliver IDPU FM 2 For SEP Package/IDPU I & T | milestone | 0d | 2004-03-30 | 2004-03-30 | 10 |  |  | 2004-03-30 | 2004-03-30 | 0d | 72d | 0d |  | STEREO | IMPACT | UC-B | SEP Package | IDPU | IDPU |  | FM IDPU to CIT |  |  |
| 96 | 1.1.5.6.3 | Receive IDPU FM 2 From UC-B For SEP FM 1/IDPU FM 1 Testing | milestone | 0d | 2004-03-30 | 2004-03-30 | 95 |  |  | 2004-03-30 | 2004-03-30 | 0d | 815.5d |  |  | STEREO | IMPACT |  |  |  |  |  |  |  |  |
| 97 | 1.1.5.35 | Deliver IDPU FM 1 For Final BOOM Suite I & T | milestone | 0d | 2004-02-10 | 2004-02-10 | 9 |  |  | 2000-01-01 | 2000-01-01 | 0d | 79d | 4d | start no earlier than 2003-04-30 | STEREO | IMPACT | UC-B | Boom Suite | IDPU | IDPU |  |  |  |  |
| 98 | 1.2.5.2.16 | Receive IDPU FM 1 For Final BOOM Suite I & T | milestone | 0d | 2004-02-18 | 2004-02-18 | 97FS+5d |  |  | 2003-02-01 | 2003-02-01 | 0d | 79d |  | start no earlier than 2003-05-31 | STEREO | IMPACT |  |  |  |  |  |  |  |  |
| 99 | 1.1.5.37 | Deliver IDPU FM 2 For Final BOOM Suite I & T | milestone | 0d | 2004-03-30 | 2004-03-30 | 10 |  |  | 2000-01-01 | 2000-01-01 | 0d | 68d | 0d | start no earlier than 2003-04-30 | STEREO | IMPACT | UC-B | Boom Suite | IDPU | IDPU |  |  |  |  |
| 100 | 1.2.5.3.12 | Receive IDPU FM 2 For Final BOOM Suite I & T | milestone | 0d | 2004-03-30 | 2004-03-30 | 99 |  |  | 2003-02-01 | 2003-02-01 | 0d | -4d | 0d | start no earlier than 2003-05-31 | STEREO | IMPACT |  |  |  |  |  |  |  |  |
| 101 | 1.1.4.8 | Receive ETU MAG/IDPU Test Results |  | 1d | 2003-01-28 A | 2003-01-28 A | 81 | 100% |  | 2003-01-28 | 2003-01-28 | 1d |  |  |  | STEREO | IMPACT |  |  |  |  |  |  |  |  |
| 102 | 1.1.5.40 | Deliver MAG Science Display GSE |  | 1d | 2003-02-03 A | 2003-02-03 A | 22 | 100% |  | 2003-01-16 | 2003-01-16 | 1d |  |  |  | STEREO | IMPACT | UC-B | Boom Suite | GSE | IDPU | MAG Sci. Disp. Avail |  |  |  |
| 103 | 1.1.5.41 | Deliver SWEA Science Display GSE | milestone | 0d | 2003-06-27 | 2003-06-27 | 23 |  |  | 2003-02-13 | 2003-02-13 | 0d | 260d |  | start no earlier than 2003-05-31 | STEREO | IMPACT | UC-B | Boom Suite | GSE | IDPU | SWEA Sci. Disp. Avail |  |  |  |
| 104 | 1.1.5.42 | Deliver STE Science Display GSE | milestone | 0d | 2003-07-14 | 2003-07-14 | 24 |  |  | 2003-02-28 | 2003-02-28 | 0d | 250d |  |  | STEREO | IMPACT | UC-B | Boom Suite | GSE | IDPU | STE Sci. Disp. Avail |  |  |  |
| 105 | 1.1.5.43 | Deliver FM 1 MAG For FM 1 Boom Suite I & T | milestone | 0d | 2003-12-12 | 2003-12-12 | 167 |  |  | 2003-11-05 | 2003-11-05 | 0d | 58d | 0d |  | STEREO | IMPACT |  |  | MAG |  |  |  |  |  |
| 106 | 1.2.5.2.10 | Receive MAG FM 1 For BOOM Suite I & T | milestone | 0d | 2003-12-12 | 2003-12-12 | 105 |  |  | 2003-11-05 | 2003-11-05 | 0d | 58d |  |  | STEREO | IMPACT |  |  |  |  |  |  |  |  |
| 107 | 1.1.5.45 | Deliver FM 2 MAG For FM 2 Boom Suite I & T | milestone | 0d | 2004-02-17 | 2004-02-17 | 174 |  |  | 2004-01-19 | 2004-01-19 | 0d | 65d | 0d |  | STEREO | IMPACT |  |  | MAG |  |  |  |  |  |
| 108 | 1.2.5.3.6 | Receive MAG FM 2 For BOOM Suite I & T | milestone | 0d | 2004-02-17 | 2004-02-17 | 107 |  |  | 2004-01-19 | 2004-01-19 | 0d | 65d |  |  | STEREO | IMPACT |  |  |  |  |  |  |  |  |

Notes:
- 93: Added pred 87 and dropping 131 to see what happens in SEP
- 102: FNL of 12/27/02 removed 1/9/03
- 103: FNL of 1/24/03 removed 1/9/03
- 104: FNL of 2/7/03 removed 1/9/03

| ID | WBS | Task | Type | Duration | Start | Finish | Predecessors | Complete | Remaining | Baseline start | Baseline finish | Baseline duration | Total slack | Constraint | Text11 | Text12 | Text28 | Text13 | Text14 | Text16 | Text23 | Text21 |
| --- | --- | --- | --- | --- | --- | --- | --- | --- | --- | --- | --- | --- | --- | --- | --- | --- | --- | --- | --- | --- | --- | --- |
| 109 | 1.2 | **Documentation** |  | 1d | 2001-06-07 A | 2001-06-07 A |  | 100% |  | 2001-06-07 | 2001-06-07 | 1d |  |  | STEREO | IMPACT | UC-B |  |  |  |  |  |
| 110 | 1.2.1 | IDPU Flight Software Requirements Draft | milestone | 1d | 2001-06-07 A | 2001-06-07 A |  | 100% |  | 2001-06-07 | 2001-06-07 | 1d |  | start no earlier than 2001-06-07 | STEREO | IMPACT | UC-B | IDPU | IDPU | IDPU |  |  |
| 111 | 2 | **IDPU** |  | 775d | 2001-01-02 A | 2004-02-03 |  | 81% | 147.99d | 2001-01-02 | 2004-01-09 | 759d | 71.75d |  | STEREO | IMPACT | UC-B | IDPU | IDPU | IDPU |  |  |
| 112 | 2.1 | **Design, Manufacture, Assembly and Test** |  | 775d | 2001-01-02 A | 2004-02-03 |  | 81% | 147.99d | 2001-01-02 | 2004-01-09 | 759d | 71.75d |  | STEREO | IMPACT | UC-B | IDPU | IDPU | IDPU |  |  |
| 113 | 2.1.1 | **Procurements** |  | 393d | 2001-09-11 A | 2003-04-07 A |  | 100% |  | 2001-09-11 | 2003-06-20 | 446d |  |  | STEREO | IMPACT | UC-B | IDPU | IDPU | IDPU |  |  |
| 114 | 2.1.1.1 | **ETU** |  | 393d | 2001-09-11 A | 2003-04-07 A |  | 100% |  | 2001-09-11 | 2002-12-06 | 311d |  |  | STEREO | IMPACT | UC-B | IDPU | IDPU | IDPU |  |  |
| 115 | 2.1.1.1.1 | Procure IDPU Long Lead Parts |  | 241d | 2001-09-11 A | 2003-04-07 A | 120 | 100% |  | 2001-09-11 | 2002-12-06 | 241d |  |  | STEREO | IMPACT | UC-B | IDPU | IDPU | IDPU |  |  |
| 116 | 2.1.1.2 | **FM 1 & FM 2** |  | 5d | 2003-03-25 A | 2003-03-31 A |  | 100% |  | 2003-06-16 | 2003-06-20 | 5d |  |  | STEREO | IMPACT |  |  |  |  |  |  |
| 117 | 2.1.1.2.1 | Procure Flight IDPU Printed Wiring Boards |  | 5d | 2003-03-25 A | 2003-03-31 A | 126 | 100% |  | 2003-06-16 | 2003-06-20 | 5d |  |  | STEREO | IMPACT |  |  |  |  | Flight IDPU Printed Wiring Boards Ordered |  |
| 118 | 2.1.2 | **Design** |  | 558d | 2001-01-02 A | 2003-03-24 A |  | 100% |  | 2001-01-02 | 2003-06-13 | 616d |  |  | STEREO | IMPACT | UC-B | IDPU | IDPU | IDPU |  |  |
| 119 | 2.1.2.1 | **ETU** |  | 338d | 2001-01-02 A | 2002-05-06 A |  | 100% |  | 2001-01-02 | 2002-05-06 | 338d |  |  | STEREO | IMPACT | UC-B | IDPU | IDPU | IDPU |  |  |
| 120 | 2.1.2.1.1 | IDPU System Design |  | 81d | 2001-01-02 A | 2001-04-26 A | 50 | 100% |  | 2001-01-02 | 2001-04-26 | 81d |  |  | STEREO | IMPACT | UC-B | IDPU | IDPU | IDPU |  |  |
| 121 | 2.1.2.1.2 | IDPU FPGA Design |  | 17.05d | 2002-01-02 A | 2002-05-06 A | 6 | 100% |  | 2002-01-02 | 2002-05-06 | 17.05d |  |  | STEREO | IMPACT | UC-B | IDPU | IDPU | IDPU |  |  |
| 122 | 2.1.2.1.3 | IDPU DCB Design |  | 57d | 2002-01-02 A | 2002-03-25 A | 6 | 100% |  | 2002-01-02 | 2002-03-25 | 57d |  |  | STEREO | IMPACT | UC-B | IDPU | IDPU | IDPU |  |  |
| 123 | 2.1.2.1.4 | IDPU Box Design |  | 58d | 2001-04-27 A | 2001-07-19 A | 120 | 100% |  | 2001-04-27 | 2001-07-19 | 58d |  |  | STEREO | IMPACT | UC-B | IDPU | IDPU | IDPU |  | Box Design Begins/Complete |
| 124 | 2.1.2.1.5 | MAG/DCB Printed Wiring Board Form Factor |  | 1d | 2002-03-01 A | 2002-03-01 A | 122FS-17d | 100% |  | 2002-03-01 | 2002-03-01 | 1d |  | start no earlier than 2002-05-31 | STEREO | IMPACT | UC-B | IDPU | IDPU | IDPU |  |  |
| 125 | 2.1.2.2 | **FM 1 & FM 2** |  | 19d | 2003-02-26 A | 2003-03-24 A |  | 100% |  | 2003-05-19 | 2003-06-13 | 19d |  |  | STEREO | IMPACT | UC-B | IDPU | IDPU | IDPU |  |  |
| 126 | 2.1.2.2.1 | IDPU Design Finalize |  | 19d | 2003-02-26 A | 2003-03-24 A | 161, 123, 162 | 100% |  | 2003-05-19 | 2003-06-13 | 19d |  |  | STEREO | IMPACT | UC-B | IDPU | IDPU | IDPU |  |  |
| 127 | 2.1.2.3 | **Flight Software** |  | 87d | 2001-04-27 A | 2001-08-29 A |  | 100% |  | 2001-04-27 | 2001-08-29 | 87d |  |  | STEREO | IMPACT | UC-B | IDPU | IDPU | IDPU |  |  |
| 128 | 2.1.2.3.1 | IDPU Software Design |  | 59d | 2001-06-07 A | 2001-08-29 A | 120, 110, 48 | 100% |  | 2001-06-07 | 2001-08-29 | 59d |  |  | STEREO | IMPACT | UC-B | IDPU | IDPU | IDPU |  |  |
| 129 | 2.1.2.3.2 | Command & Display Software Design |  | 20d | 2001-04-27 A | 2001-05-24 A | 120 | 100% |  | 2001-04-27 | 2001-05-24 | 20d |  |  | STEREO | IMPACT | UC-B | IDPU | IDPU | IDPU |  |  |
| 130 | 2.1.3 | **Fabrication** |  | 467d | 2002-03-26 A | 2004-02-03 |  | 38% | 291.88d | 2002-03-26 | 2003-12-26 | 442d | 45.75d |  | STEREO | IMPACT | UC-B | IDPU | IDPU | IDPU |  |  |
| 131 | 2.1.3.1 | **ETU** |  | 29d | 2002-03-26 A | 2002-05-03 A |  | 100% |  | 2002-03-26 | 2002-05-03 | 29d |  |  | STEREO | IMPACT | UC-B | IDPU | IDPU | IDPU |  |  |
| 132 | 2.1.3.1.1 | Begin IDPU ETU |  | 1d | 2002-03-26 A | 2002-03-26 A | 133SS | 100% |  | 2002-03-26 | 2002-03-26 | 1d |  |  | STEREO | IMPACT | UC-B | IDPU | IDPU | IDPU |  | ETU Begins |
| 133 | 2.1.3.1.2 | IDPU DCB ETU Layout |  | 20d | 2002-03-26 A | 2002-04-22 A | 122, 124 | 100% |  | 2002-03-26 | 2002-04-22 | 20d |  |  | STEREO | IMPACT | UC-B | IDPU | IDPU | IDPU |  |  |
| 134 | 2.1.3.1.3 | IDPU DCB ETU PWB Layout |  | 3d | 2002-05-01 A | 2002-05-03 A | 133 | 100% |  | 2002-05-01 | 2002-05-03 | 3d |  | start no earlier than 2002-04-30 | STEREO | IMPACT | UC-B | IDPU | IDPU | IDPU |  |  |

Notes:
- 120: Actual duration was approximately 84 days. Actuals from 1/2/01 to 4/26/01

| ID | WBS | Task | Duration | Start | Finish | Predecessors | Complete | Remaining | Baseline start | Baseline finish | Baseline duration | Total slack | Free slack | Constraint | Text11 | Text12 | Text13 | Text14 | Text16 | Text28 | Text23 | Text21 | Text20 |
| --- | --- | --- | --- | --- | --- | --- | --- | --- | --- | --- | --- | --- | --- | --- | --- | --- | --- | --- | --- | --- | --- | --- | --- |
| 135 | 2.1.3.2 | **FM 1 & FM 2** | 169d | 2003-06-02 | 2004-02-03 |  |  |  | 2003-06-16 | 2003-12-26 | 134d | 45.75d |  |  | STEREO | IMPACT | IDPU | IDPU | IDPU | UC-B |  |  |  |
| 136 | 2.1.3.2.1 | **FM 1** | 20d | 2003-06-02 | 2003-06-27 |  |  |  | 2003-06-16 | 2003-07-14 | 20d | 95d |  |  | STEREO | IMPACT | IDPU | IDPU | IDPU | UC-B |  |  |  |
| 137 | 2.1.3.2.1.1 | IDPU FM 1 Box Fabrication | 20d | 2003-06-02 | 2003-06-27 | 126 |  |  | 2003-06-16 | 2003-07-14 | 20d | 95d |  | start no earlier than 2003-05-31 | STEREO | IMPACT | IDPU | IDPU | IDPU | UC-B | FM 1 IDPU Box Fabricated |  |  |
| 138 | 2.1.3.2.2 | **FM 2** | 20d | 2004-01-06 | 2004-02-03 |  |  |  | 2003-11-28 | 2003-12-26 | 20d | 45.75d |  |  | STEREO | IMPACT | IDPU | IDPU | IDPU | UC-B |  |  |  |
| 139 | 2.1.3.2.2.1 | IDPU FM 2 Box Fabrication | 20d | 2004-01-06 | 2004-02-03 | 126, 169 |  |  | 2003-11-28 | 2003-12-26 | 20d | 47d | 0d |  | STEREO | IMPACT | IDPU | IDPU | IDPU | UC-B | FM 2 IDPU Box Fabricated |  |  |
| 140 | 2.1.4 | **Assembly** | 404d | 2002-05-20 A | 2003-12-29 |  | 43% | 230.86d | 2002-05-20 | 2003-11-20 | 379d | 69.75d |  |  | STEREO | IMPACT | IDPU | IDPU | IDPU | UC-B |  |  |  |
| 141 | 2.1.4.1 | **ETU** | 35d | 2002-05-20 A | 2002-07-09 A |  | 100% |  | 2002-05-20 | 2002-07-09 | 35d |  |  |  | STEREO | IMPACT | IDPU | IDPU | IDPU | UC-B |  |  |  |
| 142 | 2.1.4.1.1 | IDPU DCB ETU PWB Board Load | 5d | 2002-05-20 A | 2002-05-24 A | 134 | 100% |  | 2002-05-20 | 2002-05-24 | 5d |  |  |  | STEREO | IMPACT | IDPU | IDPU | IDPU | UC-B |  |  |  |
| 143 | 2.1.4.1.2 | Assemble Second IDPU ETU For PLASTIC | 10d | 2002-06-17 A | 2002-07-09 A | 142 | 100% |  | 2002-06-17 | 2002-07-09 | 10d |  |  |  | STEREO | PLASTIC | IDPU | IDPU | IDPU | UC-B |  | ETU For PLASTIC(Start MS) |  |
| 144 | 2.1.4.2 | **FM 1** | 10d | 2003-06-02 | 2003-06-13 |  |  |  | 2003-07-15 | 2003-07-28 | 10d | 105d |  |  | STEREO | IMPACT | IDPU | IDPU | IDPU | UC-B |  |  |  |
| 145 | 2.1.4.2.1 | IDPU FM 1 Board Load | 10d | 2003-06-02 | 2003-06-13 | 115, 117FS+15d |  |  | 2003-07-15 | 2003-07-28 | 10d | 105d |  | start no earlier than 2003-05-31 | STEREO | IMPACT | IDPU | IDPU | IDPU | UC-B | FM 1 IDPU Data Control Board Loaded |  |  |
| 146 | 2.1.4.3 | **FM 2** | 10d | 2003-12-15 | 2003-12-29 |  |  |  | 2003-11-06 | 2003-11-20 | 10d | 69.75d |  |  | STEREO | IMPACT | IDPU | IDPU | IDPU | UC-B |  |  |  |
| 147 | 2.1.4.3.1 | IDPU FM 2 Board Load | 10d | 2003-12-15 | 2003-12-29 | 115, 117FS+15d, 167 |  |  | 2003-11-06 | 2003-11-20 | 10d | 71d | 24d |  | STEREO | IMPACT | IDPU | IDPU | IDPU | UC-B | FM 2 IDPU Data Control Board Loaded |  |  |
| 148 | 2.1.5 | **Test** | 467d | 2002-03-01 A | 2004-01-08 |  | 66% | 156.65d | 2002-03-01 | 2004-01-09 | 468d | 88.75d |  |  | STEREO | IMPACT | IDPU | IDPU | IDPU | UC-B |  |  |  |
| 149 | 2.1.5.1 | **ETU** | 77d | 2002-05-28 A | 2002-09-13 A |  | 100% |  | 2002-05-28 | 2002-09-13 | 77d |  |  |  | STEREO | IMPACT | IDPU | IDPU | IDPU | UC-B |  |  |  |
| 150 | 2.1.5.1.1 | Test IDPU DCB ETU | 19.25d | 2002-05-28 A | 2002-07-09 A | 142, 121 | 100% |  | 2002-05-28 | 2002-07-09 | 19.25d |  |  |  | STEREO | IMPACT | IDPU | IDPU | IDPU | UC-B |  |  |  |
| 151 | 2.1.5.1.2 | Test Second IDPU ETU For PLASTIC | 10d | 2002-08-01 A | 2002-09-13 A | 143 | 100% |  | 2002-08-01 | 2002-09-13 | 10d |  |  | start no earlier than 2002-07-31 | STEREO | PLASTIC | IDPU | IDPU | IDPU | UC-B |  | ETU For PLASTIC (Finish MS) |  |
| 152 | 2.1.5.2 | **Flight Software** | 467d | 2002-03-01 A | 2004-01-08 |  | 64% | 167.45d | 2002-03-01 | 2004-01-09 | 468d | 88.75d |  |  | STEREO | IMPACT | IDPU | IDPU | IDPU | UC-B |  |  |  |
| 153 | 2.1.5.2.1 | IDPU S/W Build #1 | 98d | 2002-03-01 A | 2002-07-18 A | 128 | 100% |  | 2002-03-01 | 2002-07-18 | 98d |  |  |  | STEREO | IMPACT | IDPU | IDPU | IDPU | UC-B |  | S/W B1 |  |
| 154 | 2.1.5.2.2 | IDPU S/W Iterate | 97.9d | 2002-05-07 A | 2003-01-15 A | 153SS+40d, 121 | 100% |  | 2002-05-07 | 2003-01-15 | 97.9d |  |  |  | STEREO | IMPACT | IDPU | IDPU | IDPU | UC-B | Reworked S/W Build 1 |  |  |
| 155 | 2.1.5.2.3 | IDPU S/W Build #2.0 | 68d | 2003-01-16 A | 2003-04-22 A | 154 | 100% |  | 2003-01-16 | 2003-04-03 | 55d |  |  |  | STEREO | IMPACT |  | IDPU |  |  | Build 2.0 Complete |  |  |
| 156 | 2.1.5.2.4 | IDPU S/W Build #2.5 | 80d | 2003-05-05 A | 2003-09-11 | 126SS+2d, 155 | 10% | 72d | 2003-05-21 | 2003-09-12 | 80d | 43d | 0d |  | STEREO | IMPACT | IDPU | IDPU | IDPU | UC-B | Build 2.5 Complete | S/W B2 |  |
| 157 | 2.1.5.2.5 | IDPU S/W Build #3 | 80d | 2003-09-12 | 2004-01-08 | 156 |  |  | 2003-09-15 | 2004-01-09 | 80d | 88d | 0d |  | STEREO | IMPACT | IDPU | IDPU | IDPU | UC-B | Build 3.0 Complete | S/W B3 |  |
| 158 | 3 | **Integration & Test** | 300d | 2003-01-21 A | 2004-03-30 |  | 6% | 281.74d | 2003-01-21 | 2004-03-02 | 280d | 72d |  |  | STEREO | IMPACT |  |  |  | UC-B |  |  |  |
| 159 | 3.1 | **ETU** | 137d | 2003-01-21 A | 2003-08-04 |  | 26% | 101.48d | 2003-01-21 | 2003-05-16 | 83d | 235d |  |  | STEREO | IMPACT |  |  |  | UC-B |  |  |  |
| 160 | 3.1.1 | **IDPU** | 137d | 2003-01-21 A | 2003-08-04 |  | 26% | 101.48d | 2003-01-21 | 2003-05-16 | 83d | 235d |  |  | STEREO | IMPACT |  | IDPU |  | UC-B |  |  |  |
| 161 | 3.1.1.1 | IDPU ETU/LVPS ETU I & T | 2d | 2003-02-07 A | 2003-02-10 A | 27, 162 | 100% |  | 2003-02-11 | 2003-02-25 | 10d |  |  |  | STEREO | IMPACT | IDPU | IDPU | IDPU | UC-B | ETU LVPS Integrated & Tested |  |  |
| 162 | 3.1.1.2 | MAG/IDPU ETU I/F Test | 5d | 2003-01-21 A | 2003-01-27 A | 33, 150, 188 | 100% |  | 2003-01-21 | 2003-01-27 | 5d |  |  |  | STEREO | IMPACT | Boom Suite | IDPU | IDPU | UC-B | MAG ETU Integrated and Tested |  | Begin EM I & T |
| 163 | 3.1.1.3 | SWEA/STE/IDPU ETU I/F Test | 10d | 2003-06-30 | 2003-07-14 | 41, 86 |  |  | 2003-05-05 | 2003-05-16 | 10d | 250d |  |  | STEREO | IMPACT | Boom Suite | IDPU | IDPU | UC-B | ETU SWEA/STE-D Integrated & Tested |  | Complete EM I & T |
| 164 | 3.1.1.4 | (OBSOLETE) STE-U/IDPU ETU I/F Test | 10d | 2003-07-22 | 2003-08-04 | 43, 153 |  |  | 2003-03-25 | 2003-04-07 | 10d | 235d |  |  | STEREO | IMPACT | Boom Suite | IDPU | IDPU | UC-B |  |  |  |

Notes:
- 164: Same as for STE-D only need one board for ETU purposes. The flight boards will need to be built

| ID | WBS | Task | Duration | Start | Finish | Predecessors | Complete | Remaining | Baseline start | Baseline finish | Baseline duration | Total slack | Free slack | Constraint | Text11 | Text12 | Text28 | Text13 | Text14 | Text16 | Text23 | Text20 | Text21 |
| --- | --- | --- | --- | --- | --- | --- | --- | --- | --- | --- | --- | --- | --- | --- | --- | --- | --- | --- | --- | --- | --- | --- | --- |
| 165 | 3.2 | **FM 1** | 49d | 2003-11-14 | 2004-01-27 |  |  |  | 2003-10-09 | 2003-12-18 | 49d | 0d |  |  | STEREO | IMPACT | UC-B |  |  |  |  |  |  |
| 166 | 3.2.1 | **IDPU** | 49d | 2003-11-14 | 2004-01-27 |  |  |  | 2003-10-09 | 2003-12-18 | 49d | 0d |  |  | STEREO | IMPACT | UC-B | IDPU | IDPU |  |  |  |  |
| 167 | 3.2.1.1 | IDPU FM 1 I & T | 20d | 2003-11-14 | 2003-12-12 | 145, 156, 46, 35, 137, 29, 39, 58 |  |  | 2003-10-09 | 2003-11-05 | 20d | -4d | 0d |  | STEREO | IMPACT | UC-B | IDPU | IDPU | IDPU | FM 1 IDPU Integrated & Tested |  |  |
| 168 | 3.2.1.2 | IDPU FM 1 Clean/Stake/Coat | 9d | 2003-12-15 | 2003-12-26 | 167 |  |  | 2003-11-06 | 2003-11-19 | 9d | -4d | 0d |  | STEREO | IMPACT | UC-B | IDPU | IDPU | IDPU |  |  |  |
| 169 | 3.2.1.3 | IDPU FM 1 Vibration | 5d | 2003-12-29 | 2004-01-05 | 168 |  |  | 2003-11-20 | 2003-11-26 | 5d | -4d | 0d |  | STEREO | IMPACT | UC-B | IDPU | IDPU | IDPU |  | FM1 IDPU Vib | FM1 Env. Tst (Begin MS) |
| 170 | 3.2.1.4 | IDPU FM 1 Thermal Vacuum | 10d | 2004-01-06 | 2004-01-20 | 169 |  |  | 2003-11-28 | 2003-12-11 | 10d | -4d | 0d |  | STEREO | IMPACT | UC-B | IDPU | IDPU | IDPU | FM 1 IDPU Environmentally Tested |  | FM1 Env. Tst (Finish MS) / Bar 2 FM 1 IDPU (Finish MS) |
| 171 | 3.2.1.5 | IDPU FM 1 Bakeout | 5d | 2004-01-21 | 2004-01-27 | 170 |  |  | 2003-12-12 | 2003-12-18 | 5d | -4d | 0d |  | STEREO | IMPACT | UC-B | IDPU | IDPU | IDPU |  |  |  |
| 172 | 3.3 | **FM 2** | 39d | 2004-02-04 | 2004-03-30 |  |  |  | 2004-01-06 | 2004-03-02 | 39d | 45.75d |  |  | STEREO | IMPACT | UC-B |  |  |  |  |  |  |
| 173 | 3.3.1 | **IDPU** | 39d | 2004-02-04 | 2004-03-30 |  |  |  | 2004-01-06 | 2004-03-02 | 39d | 45.75d |  |  | STEREO | IMPACT | UC-B |  |  |  |  |  |  |
| 174 | 3.3.1.1 | IDPU FM 2 I & T | 9d | 2004-02-04 | 2004-02-17 | 139, 37, 147, 31, 61 |  |  | 2004-01-06 | 2004-01-19 | 9d | 47d | 0d |  | STEREO | IMPACT | UC-B | IDPU | IDPU | IDPU | FM 2 IDPU Integrated & Tested |  |  |
| 175 | 3.3.1.2 | IDPU FM 2 Clean/Stake/Coat | 10d | 2004-02-18 | 2004-03-02 | 174 |  |  | 2004-01-20 | 2004-02-02 | 10d | 47d | 0d |  | STEREO | IMPACT | UC-B | IDPU | IDPU | IDPU |  |  |  |
| 176 | 3.3.1.3 | IDPU FM 2 Vibration | 5d | 2004-03-03 | 2004-03-09 | 175 |  |  | 2004-02-03 | 2004-02-09 | 5d | 47d | 0d |  | STEREO | IMPACT | UC-B | IDPU | IDPU | IDPU |  |  | FM2 Env. Tst (Begin MS) |
| 177 | 3.3.1.4 | IDPU FM 2 Thermal Vacuum | 10d | 2004-03-10 | 2004-03-23 | 176, 157 |  |  | 2004-02-10 | 2004-02-24 | 10d | 47d | 0d |  | STEREO | IMPACT | UC-B | IDPU | IDPU | IDPU | FM 2 IDPU Environmentally Tested |  | FM2 Env. Tst (Finish MS) / Bar 2 FM 2 IDPU (Finish MS) |
| 178 | 3.3.1.5 | IDPU FM 2 Bakeout | 5d | 2004-03-24 | 2004-03-30 | 177 |  |  | 2004-02-25 | 2004-03-02 | 5d | 47d | 0d |  | STEREO | IMPACT | UC-B | IDPU | IDPU | IDPU |  |  |  |
| 179 | 4 | **Emulators/Simulators/GSE** | 805d | 2001-04-27 A | 2004-07-12 |  | 68% | 256.89d | 2001-04-27 | 2004-02-27 | 711d | 0d |  |  | STEREO | IMPACT | UC-B |  |  |  |  |  |  |
| 180 | 4.1 | **GSE** | 805d | 2001-04-27 A | 2004-07-12 |  | 68% | 256.89d | 2001-04-27 | 2004-02-27 | 711d | 0d |  |  | STEREO | IMPACT | UC-B |  |  |  |  |  |  |
| 181 | 4.1.1 | IDPU Simulator GSE Hardware | 97d | 2001-04-27 A | 2001-09-13 A | 120 | 100% |  | 2001-04-27 | 2001-09-13 | 97d |  |  |  | STEREO | IMPACT | UC-B | IDPU | IDPU |  |  |  |  |
| 182 | 4.1.2 | IDPU Simulator Software | 104d | 2001-04-27 A | 2002-05-31 A | 120 | 100% |  | 2001-04-27 | 2002-05-31 | 104d |  |  |  | STEREO | IMPACT | UC-B | IDPU | IDPU |  |  |  |  |
| 183 | 4.1.3 | IDPU Simulator Software For MAG | 22.02d | 2002-06-03 A | 2002-07-03 A | 182 | 100% |  | 2002-06-03 | 2002-07-03 | 22.02d |  |  |  | STEREO | IMPACT | UC-B | IDPU | IDPU |  |  |  |  |
| 184 | 4.1.4 | IDPU Simulator Software For SEP Central CIT | 41d | 2002-09-03 A | 2002-10-30 A | 182 | 100% |  | 2002-09-03 | 2002-10-30 | 41d |  |  | start no earlier than 2002-08-31 | STEREO | IMPACT | UC-B | IDPU | IDPU |  |  |  |  |
| 185 | 4.1.5 | IDPU Simulator Software For PLASTIC UNH | 41d | 2002-09-03 A | 2002-10-30 A | 182 | 100% |  | 2002-09-03 | 2002-10-30 | 41d |  |  | start no earlier than 2002-08-31 | STEREO | PLASTIC | UC-B | IDPU | IDPU |  |  |  |  |
| 186 | 4.1.6 | IDPU Simulator Software For SWEA/STE | 54.9d | 2002-08-01 A | 2002-11-27 A | 182 | 100% |  | 2002-08-01 | 2002-11-27 | 54.9d |  |  | start no earlier than 2002-07-31 | STEREO | IMPACT | UC-B | IDPU | IDPU |  |  |  |  |
| 187 | 4.1.7 | Command & Display GSE Software (Telemetry) | 163.5d | 2001-05-25 A | 2002-07-31 A | 129 | 100% |  | 2001-05-25 | 2002-07-31 | 163.5d |  |  |  | STEREO | IMPACT | UC-B | IDPU | IDPU |  |  |  |  |
| 188 | 4.1.8 | Test with Emulator (Interim Software) | 19d | 2002-08-01 A | 2002-08-27 A | 45FS-1d, 187, 44 | 100% |  | 2002-08-01 | 2002-08-27 | 19d |  |  |  | STEREO | IMPACT | UC-B | IDPU | IDPU |  |  |  | Emulator Interim S/W Testing |
| 189 | 4.1.9 | Command & Display GSE Software (Command) | 22d | 2002-08-01 A | 2002-08-30 A | 188 | 100% |  | 2002-08-01 | 2002-08-30 | 22d |  |  |  | STEREO | IMPACT | UC-B | IDPU | IDPU |  |  |  |  |
| 190 | 4.1.10 | Test with Emulator (Full Software) | 10d | 2002-12-03 A | 2002-12-16 A | 189, 46, 47 | 100% |  | 2002-12-03 | 2002-12-16 | 10d |  |  |  | STEREO | IMPACT | UC-B | IDPU | IDPU |  |  |  | Emulator Full S/W Testing |
| 191 | 4.1.11 | MAG Science Display | 23d | 2003-01-02 A | 2003-02-04 A | 190 | 100% |  | 2003-01-02 | 2003-01-16 | 10d |  |  |  | STEREO | IMPACT | UC-B | IDPU | IDPU |  |  |  |  |
| 192 | 4.1.12 | SWEA Science Display | 20d | 2003-06-02 | 2003-06-27 | 191, 190 |  |  | 2003-01-17 | 2003-02-13 | 20d | 0d |  | start no earlier than 2003-05-31 | STEREO | IMPACT | UC-B | IDPU | IDPU |  |  |  |  |
| 193 | 4.1.13 | STE Science Display | 10d | 2003-06-30 | 2003-07-14 | 192, 190 |  |  | 2003-02-14 | 2003-02-28 | 10d | 0d |  | start no earlier than 2003-05-31 | STEREO | IMPACT | UC-B | IDPU | IDPU |  |  |  |  |
| 194 | 4.1.14 | GSE Continued Development | 250d | 2003-07-15 | 2004-07-12 | 190, 191, 192, 193 |  |  | 2003-03-03 | 2004-02-27 | 250d | 0d |  |  | STEREO | IMPACT | UC-B | IDPU | IDPU |  |  |  |  |
