# LET - Low Energy Telescope

Schedule from MS Project, 2000-09-05 to 2005-09-29, status date 2003-04-30, A marks actual dates.
LET Instrument Development Schedule
NASA GSFC
Status Date: 04/30/2003 / Baseline Date: 01/31/2003 R1

## Calendars

- Standard w/ 10 Gov't Holidays: Mon-Fri 08:00-12:00, 13:00-17:00; Sat-Sun off. Exceptions (off unless hours are given): 2000-10-09, 2000-11-13, 2000-11-23, 2000-12-25, 2001-01-01, 2001-01-15, 2001-02-19, 2001-05-28, 2001-07-04, 2001-09-03, 2001-10-08, 2001-11-12, 2001-11-22, 2001-12-25, 2002-01-01, 2002-01-14, 2002-02-18, 2002-05-27, 2002-07-04, 2002-09-02, 2002-10-07, 2002-11-11, 2002-11-28, 2002-12-25, 2003-01-01, 2003-01-13, 2003-02-17, 2003-05-26, 2003-07-04, 2003-09-01, 2003-10-06, 2003-11-10, 2003-11-27, 2003-12-25, 2004-01-01, 2004-01-12, 2004-02-16, 2004-05-31, 2004-07-05, 2004-09-06, 2004-10-11, 2004-11-08, 2004-11-25, 2004-12-24, 2004-12-31, 2005-01-17, 2005-02-21, 2005-05-30, 2005-07-04, 2005-09-05.

## Resources

| Resource |
| --- |
| Kecman |
| Burnham |
| Nguyen |
| Wiedenbeck |
| Geier |

## Schedule

| ID | WBS | Task | Type | Duration | Start | Finish | Predecessors | Complete | Remaining | Baseline start | Baseline finish | Baseline duration | Total slack | Free slack | Constraint | Text11 | Text12 | Text13 | Text14 | Text16 | Text28 | Text22 | Text23 | Text17 | Text20 | Text21 |
| --- | --- | --- | --- | --- | --- | --- | --- | --- | --- | --- | --- | --- | --- | --- | --- | --- | --- | --- | --- | --- | --- | --- | --- | --- | --- | --- |
| 1 | 1 | **Management** |  | 629.65d | 2001-06-27 A | 2003-12-31 |  | 60% | 251.86d | 2001-06-27 | 2003-12-29 | 628d | 440.35d |  |  | STEREO | IMPACT | SEP Package | LET | LET | CIT |  |  |  |  |  |
| 2 | 1.1 | **Contingency** |  | 1d | 2003-12-30 | 2003-12-31 |  |  |  | 2003-12-29 | 2003-12-29 | 0d | 0.35d |  |  | STEREO | IMPACT | SEP Package | LET | LET | CIT |  |  |  |  |  |
| 3 | 1.1.1 | LET FM 1 Delivery to CIT For SEP I & T Contingency |  | 1d | 2003-12-30 | 2003-12-31 | 355, 10 |  |  | 2003-12-29 | 2003-12-29 | 0d | 0.35d | 0d |  | STEREO | IMPACT | SEP Package | LET | LET | CIT |  |  |  |  |  |
| 4 | 1.1.2 | LET FM 2 Delivery to CIT For SEP I & T Contingency |  | 1d | 2003-12-30 | 2003-12-31 | 363, 362, 11 |  |  | 2003-12-29 | 2003-12-29 | 0d | 0.35d | 0d |  | STEREO | IMPACT | SEP Package | LET | LET | CIT |  |  |  |  |  |
| 5 | 1.2 | **Milestones** |  | 629.65d | 2001-06-27 A | 2003-12-31 |  | 99% | 0d | 2001-06-27 | 2003-12-29 | 628d | 440.35d |  |  | STEREO | IMPACT | SEP Package | LET | LET | CIT |  |  |  |  |  |
| 6 | 1.2.1 | LET L1 Detector Decision |  | 1d | 2003-01-31 A | 2003-01-31 A |  | 100% |  | 2003-01-31 | 2003-01-31 | 1d |  |  | start no earlier than 2003-02-01 | STEREO | IMPACT | SEP Package | LET | LET | CIT | LET - L1 Detector Decision Trigger Event | L1 Detector Decision |  |  |  |
| 7 | 1.2.2 | LET Software Requirements Review | milestone | 0d | 2002-05-21 A | 2002-05-21 A |  | 100% |  | 2002-05-21 | 2002-05-21 | 0d |  |  | finish no earlier than 2002-04-30 | STEREO | IMPACT | SEP Package | LET | LET | CIT |  |  |  |  |  |
| 8 | 1.2.3 | **Receivables** |  | 492.65d | 2002-01-15 A | 2003-12-30 |  | 99% | 0d | 2002-01-15 | 2003-12-29 | 492d | 441.35d |  |  | STEREO | IMPACT | SEP Package | LET | LET | CIT |  |  |  |  |  |
| 9 | 1.2.3.1 | Receive LET Spare Housing | milestone | 0d | 2003-05-27 | 2003-05-27 | 59 |  |  | 2003-03-19 | 2003-03-19 | 0d | 24d |  |  | STEREO | IMPACT | SEP Package | LET | LET | CIT |  |  |  |  |  |
| 10 | 1.2.3.2 | Receive LET FM 1 Brackets With Integrated Housing & Detectors from GSFC | milestone | 0d | 2003-12-30 | 2003-12-30 | 16, 374 |  |  | 2003-12-29 | 2003-12-29 | 0d | 0.35d | 0d |  | STEREO | IMPACT | SEP Package | LET | LET | CIT |  |  |  |  |  |
| 11 | 1.2.3.3 | Receive LET FM 2 Brackets With Integrated Housing & Detectors from GSFC | milestone | 0d | 2003-12-30 | 2003-12-30 | 17, 376 |  |  | 2003-12-29 | 2003-12-29 | 0d | 0.35d | 0d |  | STEREO | IMPACT | SEP Package | LET | LET | CIT |  |  |  |  |  |
| 12 | 1.1.6.8 | Deliver Software Requirements Doc To LET |  | 1d | 2002-01-15 A | 2002-01-15 A |  | 100% |  | 2002-01-15 | 2002-01-15 | 1d |  |  |  | STEREO | IMPACT | SEP Package | LET | LET | CIT |  |  |  |  |  |
| 13 | 1.2.3.5 | Receive Software Requirements Doc |  | 1d | 2002-01-15 A | 2002-01-15 A | 12 | 100% |  | 2002-01-15 | 2002-01-15 | 1d |  |  |  | STEREO | IMPACT | SEP Package | LET | LET | CIT |  |  |  |  |  |
| 14 | 1.2.3.6 | Receive LET EM Mockup from GSFC | milestone | 0d | 2003-04-30 | 2003-04-30 | 34 |  |  | 2003-02-01 | 2003-02-01 | 0d | 608d |  | start no earlier than 2003-04-30 | STEREO | IMPACT | SEP Package | LET | LET | CIT |  |  |  |  |  |
| 15 | 1.2.4 | **Deliverables** |  | 629.65d | 2001-06-27 A | 2003-12-31 |  | 99% | 0d | 2001-06-27 | 2003-12-29 | 628d | 440.35d |  |  | STEREO | IMPACT | SEP Package | LET | LET | CIT |  |  | HET |  |  |
| 16 | 1.2.4.1 | Deliver LET FM 1 Brackets With Integrated Housing & Detectors to CIT | milestone | 0d | 2003-05-28 | 2003-05-28 | 54 |  |  | 2003-02-28 | 2003-02-28 | 0d | 147d |  | start no earlier than 2003-04-30 | STEREO | IMPACT | SEP Package | LET | LET | GSFC |  |  |  |  |  |
| 17 | 1.2.4.2 | Deliver LET FM 2 Brackets With Integrated Housing & Detectors to CIT | milestone | 0d | 2003-05-28 | 2003-05-28 | 57 |  |  | 2003-02-28 | 2003-02-28 | 0d | 147d |  | start no earlier than 2003-04-30 | STEREO | IMPACT | SEP Package | LET | LET | GSFC |  |  |  |  |  |
| 18 | 1.2.4.3 | Deliver LET EM to I & T | milestone | 0d | 2003-07-18 | 2003-07-18 | 323, 24, 9 |  |  | 2003-06-30 | 2003-06-30 | 0d | -12.5d | 0d | finish no later than 2003-06-30 | STEREO | IMPACT | SEP Package | LET | LET | CIT | Deliver LET EM to I & T | EM Delivery For SEP Package EM I & T |  | LET EM |  |
| 19 | 1.2.6.7.6 | Receive LET EM fo SEP EM I & T | milestone | 0d | 2003-07-25 | 2003-07-25 | 18FS+5d |  |  | 2003-07-15 | 2003-07-15 | 0d | 112.25d |  | start no earlier than 2003-07-15 | STEREO | IMPACT | SEP Package | LET | LET | CIT |  |  |  |  |  |
| 20 | 1.2.4.5 | Deliver LET FM 1 to CIT For SEP I & T | milestone | 0d | 2003-12-31 | 2003-12-31 | 3 |  |  | 2003-12-29 | 2003-12-29 | 0d | 0.35d |  | finish no later than 2003-12-31 | STEREO | IMPACT | SEP Package | LET | LET | CIT | LET - FM 1 Delivery to SEP I & T | FM1 Delivery for SEP Package I & T |  | LET FM 1 | LET FM1 & FM2 Avail |
| 21 | 1.2.6.7.8 | Receive LET FM 1 For SEP FM 1 I & T | milestone | 0d | 2004-01-08 | 2004-01-08 | 20FS+5d |  |  | 2004-01-06 | 2004-01-06 | 0d | 49.1d |  |  | STEREO | IMPACT | SEP Package | LET | LET | CIT |  |  |  |  |  |
| 22 | 1.2.4.7 | Deliver LET FM 2 to CIT For SEP I & T | milestone | 0d | 2003-12-31 | 2003-12-31 | 4 |  |  | 2003-12-29 | 2003-12-29 | 0d | 0.35d |  | finish no later than 2003-12-31 | STEREO | IMPACT | SEP Package | LET | LET | CIT | LET - FM 2 Delivery to SEP I & T | FM 2 Delivery for SEP Package I & T |  | LET FM 2 | LET FM1 & FM2 Avail |
| 23 | 1.2.6.7.10 | Receive LET FM 2 For SEP FM 2 I & T | milestone | 0d | 2004-01-08 | 2004-01-08 | 22FS+5d |  |  | 2004-01-06 | 2004-01-06 | 0d | 49.1d |  |  | STEREO | IMPACT | SEP Package | LET | LET | CIT |  |  |  |  |  |
| 24 | 1.2.4.9 | Deliver LET S/W Build 2 | milestone | 0d | 2003-07-02 | 2003-07-02 | 370 |  |  | 2003-05-28 | 2003-05-28 | 0d | -2d | 0d |  | STEREO | IMPACT | SEP Package | LET | LET | CIT |  |  |  |  |  |
| 25 | 1.2.6.7.2 | Receive LET S/W Build 2 | milestone | 0d | 2003-07-02 | 2003-07-02 | 24 |  |  | 2003-05-05 | 2003-05-05 | 0d | 127.75d |  |  | STEREO | IMPACT | SEP Package | LET | LET | CIT |  |  |  |  |  |
| 26 | 1.1.5.5.2 | Receive LET S/W Build 2 | milestone | 0d | 2003-07-02 | 2003-07-02 | 24 |  |  | 2003-05-05 | 2003-05-05 | 0d | 1000.5d |  |  | STEREO | IMPACT | SEP Package | LET | LET | CIT |  |  |  |  |  |
| 27 | 1.2.4.12 | Deliver LET S/W Build 3 | milestone | 0d | 2003-12-10 | 2003-12-10 | 371 |  |  | 2003-11-03 | 2003-11-03 | 0d | 53.3d | 0d |  | STEREO | IMPACT | SEP Package | LET | LET | CIT |  |  |  |  |  |
| 28 | 1.2.6.7.4 | Receive LET S/W Build 3 | milestone | 0d | 2003-12-10 | 2003-12-10 | 27 |  |  | 2003-10-09 | 2003-10-09 | 0d | 67.75d |  |  | STEREO | IMPACT | SEP Package | LET | LET | CIT |  |  |  |  |  |
| 29 | 1.1.5.5.4 | Receive LET S/W Build 3 | milestone | 0d | 2003-12-10 | 2003-12-10 | 27 |  |  | 2003-10-09 | 2003-10-09 | 0d | 870.5d |  |  | STEREO | IMPACT | SEP Package | LET | LET | CIT |  |  |  |  |  |
| 30 | 1.2.4.15 | Deliver Sample Flight VLSI Chip to GSFC | milestone | 0d | 2002-05-01 A | 2002-05-01 A | 132 | 100% |  | 2002-05-01 | 2002-05-01 | 0d |  |  |  | STEREO | IMPACT | SEP Package | LET | LET | CIT |  |  |  |  |  |
| 31 | 1.1.5.2 | Receive PHA Chip From CIT | milestone | 0d | 2002-05-01 A | 2002-05-01 A | 30 | 100% |  |  |  |  |  |  |  | STEREO | IMPACT | SEP Package | LET | LET | CIT |  |  |  |  |  |
| 32 | 1.1.4.13 | Deliver VLSI Chip Definition to SIT and HET |  | 1d | 2001-06-27 A | 2001-06-27 A | 95 | 100% |  | 2001-06-27 | 2001-06-27 | 1d |  |  |  | STEREO | IMPACT | SEP Package | LET | LET | CIT |  |  |  |  | VLSI Chip Def to SIT & HET |
| 33 | 1.1.5.5 | Receive VLSI Chip Definition From CIT For SIT and HET | milestone | 0d | 2001-06-27 A | 2001-06-27 A | 32 | 100% |  |  |  |  |  |  |  | STEREO | IMPACT | SEP Package | LET | LET | CIT |  |  |  |  |  |
| 34 | 1.2.4.19 | Deliver LET EM Mechanical Mockup to CIT | milestone | 0d | 2003-04-30 | 2003-04-30 |  |  |  | 2003-02-01 | 2003-02-01 | 0d | 608d | 0d | start no earlier than 2003-04-30 | STEREO | IMPACT | SEP Package | LET | LET | CIT |  |  |  |  |  |

Notes:
- 3: Removed 12 days of duration 1/9/03
- 4: Removed 12 days of duration 1/9/03
- 20: FNL of 12/31/03 removed 1/9/03
- 22: FNL of 12/31/03 removed 1/9/03

| ID | WBS | Task | Type | Duration | Start | Finish | Predecessors | Complete | Remaining | Baseline start | Baseline finish | Baseline duration | Total slack | Free slack | Constraint | Text11 | Text12 | Text13 | Text14 | Text16 | Text28 | Text19 |
| --- | --- | --- | --- | --- | --- | --- | --- | --- | --- | --- | --- | --- | --- | --- | --- | --- | --- | --- | --- | --- | --- | --- |
| 35 | 2 | **Systems Engineering** |  | 680d | 2000-09-05 A | 2003-05-21 |  | 95% | 32.9d | 2000-09-05 | 2003-02-24 | 618d | 593d |  |  | STEREO | IMPACT | SEP Package | LET | LET | CIT |  |
| 36 | 2.1 | **Documentation** |  | 60d | 2001-08-13 A | 2001-11-06 A |  | 100% |  | 2001-08-13 | 2001-11-06 | 60d |  |  |  | STEREO | IMPACT | SEP Package | LET | LET | CIT |  |
| 37 | 2.1.1 | LET ICD Drawings |  | 60d | 2001-08-13 A | 2001-11-06 A | 39 | 100% |  | 2001-08-13 | 2001-11-06 | 60d |  |  |  | STEREO | IMPACT | SEP Package | LET | LET | CIT |  |
| 38 | 2.2 | **Studies** |  | 680d | 2000-09-05 A | 2003-05-21 |  | 94% | 40.8d | 2000-09-05 | 2003-02-24 | 618d | 593d |  |  | STEREO | IMPACT | SEP Package | LET | LET | CIT |  |
| 39 | 2.2.1 | Analyze Fields of View |  | 235d | 2000-09-05 A | 2001-08-10 A |  | 100% |  | 2000-09-05 | 2001-08-10 | 235d |  |  | start no earlier than 2000-09-05 | STEREO | IMPACT | SEP Package | LET | LET | GSFC |  |
| 40 | 2.2.2 | LET Vibration Analysis |  | 15d | 2003-05-01 | 2003-05-21 |  |  |  | 2003-02-03 | 2003-02-24 | 15d | 593d | 0d | start no earlier than 2003-04-30 | STEREO | IMPACT | SEP Package | LET | LET | GSFC |  |
| 41 | 3 | **Structure** |  | 270d | 2002-05-01 A | 2003-05-28 |  | 37% | 171.29d | 2002-05-01 | 2003-03-19 | 221d | 589d |  |  | STEREO | IMPACT | SEP Package | LET | LET | GSFC |  |
| 42 | 3.1 | **Design, Manufacture, Assembly and Test** |  | 270d | 2002-05-01 A | 2003-05-28 |  | 37% | 171.29d | 2002-05-01 | 2003-03-19 | 221d | 589d |  |  | STEREO | IMPACT | SEP Package | LET | LET | GSFC |  |
| 43 | 3.1.1 | **Procurements** |  | 2d | 2003-05-01 | 2003-05-02 |  |  |  | 2003-02-24 | 2003-02-25 | 2d | 24d |  |  | STEREO | IMPACT | SEP Package | LET | LET | GSFC |  |
| 44 | 3.1.1.1 | **FM 1 & FM 2** |  | 2d | 2003-05-01 | 2003-05-02 |  |  |  | 2003-02-24 | 2003-02-25 | 2d | 24d |  |  | STEREO | IMPACT | SEP Package | LET | LET | GSFC |  |
| 45 | 3.1.1.1.1 | Place Order for LET FM 1, LET FM 2, LET Spare Housing |  | 2d | 2003-05-01 | 2003-05-02 | 47, 52 |  |  | 2003-02-24 | 2003-02-25 | 2d | 24d | 0d | start no earlier than 2003-04-30 | STEREO | IMPACT | SEP Package | LET | LET | GSFC | Sandy Shuman |
| 46 | 3.1.2 | **Design** |  | 203d | 2002-05-01 A | 2003-02-21 |  | 85% | 30.45d | 2002-05-01 | 2003-02-21 | 203d | 72d |  |  | STEREO | IMPACT | SEP Package | LET | LET | GSFC |  |
| 47 | 3.1.2.1 | Design LET Housing |  | 40d | 2002-05-01 A | 2003-02-21 | 156, 155 | 85% | 6d | 2002-05-01 | 2003-02-21 | 40d | 72d | 48d | finish no earlier than 2003-02-21 | STEREO | IMPACT | SEP Package | LET | LET | GSFC | Sandy Shuman |
| 48 | 3.1.3 | **Fabrication** |  | 19d | 2003-05-01 | 2003-05-28 |  |  |  | 2003-02-03 | 2003-03-19 | 32d | 38d |  |  | STEREO | IMPACT | SEP Package | LET | LET | GSFC |  |
| 49 | 3.1.3.1 | ETU |  | 1d | 2003-05-01 | 2003-05-01 |  |  |  | 2003-02-03 | 2003-02-03 | 1d | 607d |  | start no earlier than 2003-04-30 | STEREO | IMPACT | SEP Package | LET | LET | CIT |  |
| 50 | 3.1.3.2 | **FM 1 & FM 2** |  | 19d | 2003-05-01 | 2003-05-28 |  |  |  | 2003-02-03 | 2003-03-19 | 32d | 38d |  |  | STEREO | IMPACT | SEP Package | LET | LET | GSFC |  |
| 51 | 3.1.3.2.1 | **FM 1** |  | 19d | 2003-05-01 | 2003-05-28 |  |  |  | 2003-02-03 | 2003-03-19 | 32d | 126d |  |  | STEREO | IMPACT | SEP Package | LET | LET | GSFC |  |
| 52 | 1.1.13 | Instrument CDR | milestone | 3d | 2002-11-20 A | 2002-11-22 A | 40FS-10d | 100% |  |  |  |  |  |  | finish no earlier than 2002-11-22 | STEREO | IMPACT | SEP Package | LET | LET | CIT |  |
| 53 | 3.1.3.2.1.2 | Receive & Inspect LET FM 1 Housing |  | 4d | 2003-05-21 | 2003-05-27 | 45FS+12d, 52 |  |  | 2003-03-14 | 2003-03-19 | 4d | 111d |  | start no earlier than 2003-04-30 | STEREO | IMPACT | SEP Package | LET | LET | GSFC | Sandy Shuman |
| 54 | 3.1.3.2.1.3 | Fabricate LET FM 1 Internal Parts |  | 19d | 2003-05-01 | 2003-05-28 | 52 |  |  | 2003-02-03 | 2003-02-28 | 19d | 147d | 0d | start no earlier than 2003-04-30 | STEREO | IMPACT | SEP Package | LET | LET | GSFC | Sandy Shuman |
| 55 | 3.1.3.2.2 | **FM 2** |  | 19d | 2003-05-01 | 2003-05-28 |  |  |  | 2003-02-03 | 2003-03-19 | 32d | 126d |  |  | STEREO | IMPACT | SEP Package | LET | LET | GSFC |  |
| 56 | 3.1.3.2.2.1 | Receive and Inspect LET FM 2 Housing |  | 4d | 2003-05-21 | 2003-05-27 | 45FS+12d, 52 |  |  | 2003-03-14 | 2003-03-19 | 4d | 111d |  | start no earlier than 2003-04-30 | STEREO | IMPACT | SEP Package | LET | LET | GSFC | Sandy Shuman |
| 57 | 3.1.3.2.2.2 | Fabricate LET FM 2 Internal Parts |  | 19d | 2003-05-01 | 2003-05-28 | 52 |  |  | 2003-02-03 | 2003-02-28 | 19d | 147d | 0d | start no earlier than 2003-04-30 | STEREO | IMPACT | SEP Package | LET | LET | GSFC | Sandy Shuman |
| 58 | 3.1.3.2.3 | **Spare** |  | 4d | 2003-05-21 | 2003-05-27 |  |  |  | 2003-03-14 | 2003-03-19 | 4d | 24d |  |  | STEREO | IMPACT | SEP Package | LET | LET | GSFC |  |
| 59 | 3.1.3.2.3.1 | Receive and Inspect LET Spare Housing |  | 4d | 2003-05-21 | 2003-05-27 | 45FS+12d, 52 |  |  | 2003-03-14 | 2003-03-19 | 4d | 24d | 0d | start no earlier than 2003-04-30 | STEREO | IMPACT | SEP Package | LET | LET | GSFC | Sandy Shuman |

Notes:
- 40: Modified CDR Successor fs-10d

| ID | WBS | Task | Duration | Start | Finish | Predecessors | Complete | Remaining | Baseline start | Baseline finish | Baseline duration | Total slack | Free slack | Constraint | Text11 | Text12 | Text13 | Text14 | Text16 | Text28 | Text29 | Text20 | Text21 |
| --- | --- | --- | --- | --- | --- | --- | --- | --- | --- | --- | --- | --- | --- | --- | --- | --- | --- | --- | --- | --- | --- | --- | --- |
| 60 | 4 | **Detector** | 1153d | 2001-03-01 A | 2005-09-29 |  | 37% | 729.93d | 2001-03-01 | 2005-07-01 | 1091d | 0d |  |  | STEREO | IMPACT | SEP Package | LET | LET | CIT |  |  |  |
| 61 | 4.1 | Detector oversight | 385d | 2001-06-01 A | 2004-02-06 |  | 50% | 192.5d | 2001-06-01 | 2003-11-05 | 385d | 415.5d |  | start no earlier than 2001-06-01 | STEREO | IMPACT | SEP Package | LET | LET | CIT | L1 Plan B |  |  |
| 62 | 4.2 | **Design, Manufacture, Assembly and Test** | 1153d | 2001-03-01 A | 2005-09-29 |  | 26% | 853.63d | 2001-03-01 | 2005-07-01 | 1091d | 0d |  |  | STEREO | IMPACT | SEP Package | LET | LET | CIT |  |  |  |
| 63 | 4.2.1 | Design detector | 108.2d | 2001-03-01 A | 2002-07-17 A |  | 100% |  | 2001-03-01 | 2002-07-17 | 108.2d |  |  | start no earlier than 2001-03-01 | STEREO | IMPACT | SEP Package | LET | LET | CIT |  |  |  |
| 64 | 4.2.2 | **Procure Detectors** | 1030d | 2001-08-23 A | 2005-09-29 |  | 13% | 892.63d | 2001-08-23 | 2005-07-01 | 968d | 0d |  |  | STEREO | IMPACT | SEP Package | LET | LET | CIT |  |  |  |
| 65 | 4.2.2.1 | Order prototypes | 1d | 2001-08-23 A | 2001-08-23 A | 63FS+15d | 100% |  | 2001-08-23 | 2001-08-23 | 1d |  |  |  | STEREO | IMPACT | SEP Package | LET | LET | CIT |  |  |  |
| 66 | 4.2.2.2 | L1 thinning at JPL | 144d | 2001-12-14 A | 2003-10-09 | 65FS+76d, 79 | 40% | 86.4d | 2001-12-14 | 2003-08-05 | 144d | 496.75d |  |  | STEREO | IMPACT | SEP Package | LET | LET | CIT |  |  |  |
| 67 | 4.2.2.3 | Evaluate prototypes | 55d | 2003-05-01 | 2003-07-18 | 65FS+142d |  |  | 2003-02-03 | 2003-04-21 | 55d | 0d |  | start no earlier than 2003-04-30 | STEREO | IMPACT | SEP Package | LET | LET | CIT |  |  |  |
| 68 | 4.2.2.4 | Order prototypes L1 plan B | 1d | 2001-12-17 A | 2001-12-17 A |  | 100% |  | 2001-12-17 | 2001-12-17 | 1d |  |  | start no earlier than 2001-12-17 | STEREO | IMPACT | SEP Package | LET | LET | CIT |  |  |  |
| 69 | 4.2.2.5 | Evaluate prototypes L1 plan B | 19d | 2002-12-02 A | 2002-12-27 A | 68FS+100d | 100% |  | 2002-12-02 | 2002-12-27 | 19d |  |  | start no earlier than 2002-11-30 | STEREO | IMPACT | SEP Package | LET | LET | CIT |  |  |  |
| 70 | 4.2.2.6 | Order flight Detectors | 2d | 2003-02-17 A | 2003-02-19 A | 69 | 100% |  | 2003-02-28 | 2003-03-10 | 7d |  |  | start no earlier than 2003-02-28 | STEREO | IMPACT | SEP Package | LET | LET | CIT |  | All Flt Detectors Ordered | All Flt Detectors Ordered |
| 71 | 4.2.2.7 | Software support | 42d | 2001-12-03 A | 2003-05-09 |  | 85% | 6.3d | 2001-12-03 | 2003-02-26 | 42d | 34.7d |  | start no earlier than 2001-12-03 | STEREO | IMPACT | SEP Package | LET | LET | CIT |  |  |  |
| 72 | 4.2.2.8 | Routine handling | 608d | 2003-05-01 | 2005-09-29 | 67SS |  |  | 2003-02-03 | 2005-07-01 | 608d | 0d |  | start no earlier than 2003-04-30 | STEREO | IMPACT | SEP Package | LET | LET | CIT |  |  |  |
| 73 | 4.2.3 | **Detector fixturing** | 375.3d | 2001-12-03 A | 2003-06-02 |  | 76% | 88.46d | 2001-12-03 | 2003-03-18 | 323d | 20.7d |  |  | STEREO | IMPACT | SEP Package | LET | LET | CIT |  |  |  |
| 74 | 4.2.3.1 | Design Detector Fixturing | 10d | 2001-12-03 A | 2003-05-01 |  | 95% | 0.5d | 2001-12-03 | 2003-02-13 | 10d | 20.7d | 0d | start no earlier than 2001-12-03 | STEREO | IMPACT | SEP Package | LET | LET | CIT |  |  |  |
| 75 | 4.2.3.2 | Clean & Assemble Detector Fixturing | 4d | 2003-05-08 A | 2003-06-02 | 74FS+18d | 30% | 2.8d | 2003-03-13 | 2003-03-18 | 4d | 20.7d | 20.35d | start no earlier than 2003-02-01 | STEREO | IMPACT | SEP Package | LET | LET | CIT |  |  |  |
| 76 | 4.2.4 | **Test equip** | 652.65d | 2001-04-02 A | 2003-11-04 |  | 30% | 455.46d | 2001-04-02 | 2003-10-31 | 651d | 478.35d |  |  | STEREO | IMPACT | SEP Package | LET | LET | CIT |  |  |  |
| 77 | 4.2.4.1 | **Mechanical** | 564.65d | 2001-04-02 A | 2003-06-30 |  | 87% | 73.93d | 2001-04-02 | 2003-04-28 | 520.1d | 0.35d |  |  | STEREO | IMPACT | SEP Package | LET | LET | CIT |  |  |  |
| 78 | 4.2.4.1.1 | Design Mechanical Test Equipment | 59d | 2001-04-02 A | 2003-05-05 |  | 95% | 2.95d | 2001-04-02 | 2003-02-10 | 59d | 0.35d | 0d | start no earlier than 2001-04-02 | STEREO | IMPACT | SEP Package | LET | LET | CIT |  |  |  |
| 79 | 4.2.4.1.2 | Clean & Assemble Mechanical Test Equipment | 58d | 2001-07-23 A | 2003-06-05 | 78FS+19d | 95% | 2.9d | 2001-07-23 | 2003-04-03 | 58d | 0.35d | 0d |  | STEREO | IMPACT | SEP Package | LET | LET | CIT |  |  |  |
| 80 | 4.2.4.1.3 | Test & Debug Mechanical Test Equipment | 56d | 2001-10-15 A | 2003-06-30 | 79 | 70% | 16.8d | 2001-10-15 | 2003-04-28 | 56d | 0.35d | 0d |  | STEREO | IMPACT | SEP Package | LET | LET | CIT |  |  |  |
| 81 | 4.2.4.2 | **Electronics** | 400.2d | 2002-01-07 A | 2003-08-08 |  | 24% | 303.55d | 2002-01-07 | 2003-05-28 | 349.8d | 538.8d |  |  | STEREO | IMPACT | SEP Package | LET | LET | CIT |  |  |  |
| 82 | 4.2.4.2.1 | Electronic Test Equipment Design | 6d | 2002-07-02 A | 2003-05-02 | 67SS-61d | 80% | 1.2d | 2002-07-02 | 2003-02-10 | 6d | 40.8d | 0d | start no earlier than 2002-07-01 | STEREO | IMPACT | SEP Package | LET | LET | CIT |  |  |  |
| 83 | 4.2.4.2.2 | Electronic Test Equipment Layout | 4d | 2003-04-08 A | 2003-05-02 | 82 | 80% | 0.8d | 2003-02-10 | 2003-02-14 | 4d | 538.8d | 0d | start no earlier than 2003-03-31 | STEREO | IMPACT | SEP Package | LET | LET | CIT |  |  |  |
| 84 | 4.2.4.2.3 | Procure Electronic Test Equipment Labor | 6d | 2002-01-07 A | 2003-05-06 | 83 | 80% | 1.2d | 2002-01-07 | 2003-02-24 | 6d | 538.8d | 0d |  | STEREO | IMPACT | SEP Package | LET | LET | CIT |  |  |  |
| 85 | 4.2.4.2.4 | Fabricate Electronics Test Box and Cabling | 15d | 2003-06-17 | 2003-07-09 | 84FS+29d |  |  | 2003-04-04 | 2003-04-25 | 15d | 538.8d | 0d | start no earlier than 2002-04-30 | STEREO | IMPACT | SEP Package | LET | LET | CIT |  |  |  |
| 86 | 4.2.4.2.5 | Assemble Electronics Test Box | 15d | 2003-07-09 | 2003-07-30 | 85 |  |  | 2003-04-25 | 2003-05-16 | 15d | 538.8d | 0d | start no earlier than 2002-04-30 | STEREO | IMPACT | SEP Package | LET | LET | CIT |  |  |  |
| 87 | 4.2.4.2.6 | Test & Debug Electronics Test Box | 7d | 2003-07-30 | 2003-08-08 | 86 |  |  | 2003-05-16 | 2003-05-28 | 7d | 538.8d |  | start no earlier than 2002-04-30 | STEREO | IMPACT | SEP Package | LET | LET | CIT |  |  |  |

| ID | WBS | Task | Type | Duration | Start | Finish | Predecessors | Complete | Remaining | Baseline start | Baseline finish | Baseline duration | Total slack | Free slack | Constraint | Text11 | Text12 | Text13 | Text14 | Text16 | Text28 |
| --- | --- | --- | --- | --- | --- | --- | --- | --- | --- | --- | --- | --- | --- | --- | --- | --- | --- | --- | --- | --- | --- |
| 88 | 4.2.4.3 | **Test detectors** |  | 88d | 2003-06-30 | 2003-11-04 |  |  |  | 2003-06-30 | 2003-11-03 | 88d | 0.35d |  |  | STEREO | IMPACT | SEP Package | LET | LET | CIT |
| 89 | 4.2.4.3.1 | Perform Detector Noise & breakdown Testing |  | 78d | 2003-06-30 | 2003-10-21 | 82, 70FS+91d, 71, 75, 80, 176, 180 |  |  | 2003-06-30 | 2003-10-20 | 78d | 0.35d | 0d |  | STEREO | IMPACT | SEP Package | LET | LET | CIT |
| 90 | 4.2.4.3.2 | Perform Detector Thermal Vac Testing |  | 79d | 2003-07-14 | 2003-11-04 | 89SS+9d |  |  | 2003-07-14 | 2003-11-03 | 79d | 0.35d | 0d |  | STEREO | IMPACT | SEP Package | LET | LET | CIT |
| 91 | 4.2.4.3.3 | Perform Detector Alphas Testing |  | 78d | 2003-06-30 | 2003-10-21 | 89SS |  |  | 2003-06-30 | 2003-10-20 | 78d | 8.35d |  |  | STEREO | IMPACT | SEP Package | LET | LET | CIT |
| 92 | 4.2.4.3.4 | Analyze Detector Testing Data |  | 79d | 2003-07-14 | 2003-11-04 | 91SS, 90SS |  |  | 2003-07-14 | 2003-11-03 | 79d | 0.35d | 0d |  | STEREO | IMPACT | SEP Package | LET | LET | CIT |
| 93 | 4.3 | **VLSI, protoflight** |  | 630d | 2001-06-25 A | 2003-12-29 |  | 45% | 344.55d | 2001-06-25 | 2003-11-14 | 601d | 442d |  |  | STEREO | IMPACT | SEP Package | LET | LET | CIT |
| 94 | 4.3.1 | Design |  | 39d | 2001-06-25 A | 2001-08-17 A |  | 100% |  | 2001-06-25 | 2001-08-17 | 39d |  |  | start no earlier than 2001-06-25 | STEREO | IMPACT | SEP Package | LET | LET | CIT |
| 95 | 4.3.2 | Prepare VLSI design doc (initial) |  | 3d | 2001-06-25 A | 2001-06-27 A | 94SS | 100% |  | 2001-06-25 | 2001-06-27 | 3d |  |  |  | STEREO | IMPACT | SEP Package | LET | LET | CIT |
| 96 | 4.3.3 | Layout |  | 79d | 2001-08-30 A | 2001-12-24 A | 94FS+8d | 100% |  | 2001-08-30 | 2001-12-24 | 79d |  |  |  | STEREO | IMPACT | SEP Package | LET | LET | CIT |
| 97 | 4.3.4 | Submit RFQ to UTMC |  | 1d | 2001-12-26 A | 2001-12-26 A | 96 | 100% |  | 2001-12-26 | 2001-12-26 | 1d |  |  |  | STEREO | IMPACT | SEP Package | LET | LET | CIT |
| 98 | 4.3.5 | DRC and layout check |  | 9d | 2001-12-26 A | 2002-01-08 A | 96 | 100% |  | 2001-12-26 | 2002-01-08 | 9d |  |  |  | STEREO | IMPACT | SEP Package | LET | LET | CIT |
| 99 | 4.3.6 | Independent DRC |  | 3d | 2002-01-09 A | 2002-01-11 A | 98 | 100% |  | 2002-01-09 | 2002-01-11 | 3d |  |  |  | STEREO | IMPACT | SEP Package | LET | LET | CIT |
| 100 | 4.3.7 | Layout Modifications post-DRC |  | 5d | 2002-02-15 A | 2002-02-22 A | 99FS+23d | 100% |  | 2002-02-15 | 2002-02-22 | 5d |  |  |  | STEREO | IMPACT | SEP Package | LET | LET | CIT |
| 101 | 4.3.8 | Layout approval |  | 2d | 2002-02-22 A | 2002-02-25 A | 100 | 100% |  | 2002-02-22 | 2002-02-25 | 2d |  |  |  | STEREO | IMPACT | SEP Package | LET | LET | CIT |
| 102 | 4.3.9 | PO and follow-up on wafer Fabricate |  | 1d | 2002-02-25 A | 2002-02-25 A | 97, 100 | 100% |  | 2002-02-25 | 2002-02-25 | 1d |  |  |  | STEREO | IMPACT | SEP Package | LET | LET | CIT |
| 103 | 4.3.10 | Submit layout for production |  | 2d | 2002-02-26 A | 2002-02-27 A | 101, 102 | 100% |  | 2002-02-26 | 2002-02-27 | 2d |  |  |  | STEREO | IMPACT | SEP Package | LET | LET | CIT |
| 104 | 4.3.11 | VLSI protoflight Fabricate |  | 24d | 2002-02-26 A | 2002-03-29 A | 103 | 100% |  | 2002-02-26 | 2002-03-29 | 24d |  |  |  | STEREO | IMPACT | SEP Package | LET | LET | CIT |
| 105 | 4.3.12 | VLSI packages |  | 1d | 2002-01-02 A | 2002-01-02 A |  | 100% |  | 2002-01-02 | 2002-01-02 | 1d |  |  | start no earlier than 2002-01-02 | STEREO | IMPACT | SEP Package | LET | LET | CIT |
| 106 | 4.3.13 | Final VLSI design doc |  | 20d | 2002-02-28 A | 2003-05-01 | 103 | 95% | 1d | 2002-02-28 | 2003-02-06 | 20d | 607d |  |  | STEREO | IMPACT | SEP Package | LET | LET | CIT |
| 107 | 4.3.14 | Assess hybrid Package/parts req's & Packages |  | 19.1d | 2002-03-06 A | 2002-07-03 A | 96FS+28d | 100% |  | 2002-03-06 | 2002-07-03 | 19.1d |  |  |  | STEREO | IMPACT | SEP Package | LET | LET | CIT |
| 108 | 4.3.15 | Procure hybrid Packages/parts |  | 16d | 2002-03-20 A | 2002-07-22 A | 107FS+10d | 100% |  | 2002-03-20 | 2002-07-22 | 16d |  |  | finish no earlier than 2002-07-22 | STEREO | IMPACT | SEP Package | LET | LET | CIT |
| 109 | 4.3.16 | Design hybrid substrate layout |  | 10d | 2002-03-06 A | 2002-07-16 A | 101, 107 | 100% |  | 2002-03-06 | 2002-07-16 | 10d |  |  |  | STEREO | IMPACT | SEP Package | LET | LET | CIT |
| 110 | 4.3.17 | Review & approve substate layout |  | 3d | 2002-07-17 A | 2002-07-19 A | 109 | 100% |  | 2002-07-17 | 2002-07-19 | 3d |  |  | start no earlier than 2002-06-30 | STEREO | IMPACT | SEP Package | LET | LET | CIT |
| 111 | 4.3.18 | Procure hybrid substrate |  | 5d | 2002-07-22 A | 2002-08-06 A | 110 | 100% |  | 2002-07-22 | 2002-08-06 | 5d |  |  | start no earlier than 2002-06-30 | STEREO | IMPACT | SEP Package | LET | LET | CIT |
| 112 | 4.3.19 | Receive, inspect, database wafer, parts, & Packages |  | 2.75d | 2002-04-08 A | 2003-01-31 A | 105FS+40d, 103FS+60d, 108FS+29d, 111FS+40d | 100% |  | 2002-04-08 | 2003-02-05 | 5d |  |  |  | STEREO | IMPACT | SEP Package | LET | LET | CIT |
| 113 | 4.3.20 | Assign pinout & draw hybrid Package |  | 0.3d | 2002-04-17 A | 2002-04-17 A | 108FS-1d | 100% |  | 2002-04-17 | 2002-04-17 | 0.3d |  |  |  | STEREO | IMPACT | SEP Package | LET | LET | CIT |
| 114 | 4.3.21 | Generate Footprints for Schematics & Printed Circuit Board libraries |  | 0.6d | 2002-04-17 A | 2002-04-17 A | 113 | 100% |  | 2002-04-17 | 2002-04-17 | 0.6d |  |  |  | STEREO | IMPACT | SEP Package | LET | LET | CIT |
| 115 | 4.3.22 | Test hybrid packages |  | 19d | 2003-02-03 A | 2003-02-28 A | 112 | 100% |  | 2003-02-05 | 2003-02-20 | 10d |  |  |  | STEREO | IMPACT | SEP Package | LET | LET | CIT |
| 116 | 4.3.23 | Follow-up on test hybrid packaging |  | 10d | 2003-02-03 A | 2003-02-14 A | 115SS | 100% |  | 2003-02-05 | 2003-02-20 | 10d |  |  |  | STEREO | IMPACT | SEP Package | LET | LET | CIT |
| 117 | 4.3.24 | Generate flight hybrid screen flow |  | 17d | 2002-04-17 A | 2003-03-14 A | 108 | 100% |  | 2002-04-17 | 2003-02-07 | 10d |  |  | finish no earlier than 2003-02-07 | STEREO | IMPACT | SEP Package | LET | LET | CIT |
| 118 | 4.3.25 | Design test board schematics |  | 10d | 2002-08-12 A | 2002-08-23 A | 114 | 100% |  | 2002-08-12 | 2002-08-23 | 10d |  |  | start no earlier than 2002-06-30 | STEREO | IMPACT | SEP Package | LET | LET | CIT |
| 119 | 4.3.26 | Design FPGA schematics for test board |  | 5d | 2002-08-26 A | 2002-08-30 A | 118 | 100% |  | 2002-08-26 | 2002-08-30 | 5d |  |  |  | STEREO | IMPACT | SEP Package | LET | LET | CIT |
| 120 | 4.3.27 | Burn-in FPGA |  | 1d | 2003-04-01 A | 2003-04-01 A | 119 | 100% |  | 2003-02-03 | 2003-02-03 | 1d |  |  | start no earlier than 2003-03-31 | STEREO | IMPACT | SEP Package | LET | LET | CIT |
| 121 | 4.3.28 | Obtain samples & footprints for Printed Circuit Board designer |  | 5d | 2002-08-26 A | 2002-08-30 A | 118 | 100% |  | 2002-08-26 | 2002-08-30 | 5d |  |  |  | STEREO | IMPACT | SEP Package | LET | LET | CIT |
| 122 | 4.3.29 | Design test Printed Circuit Board layout |  | 5d | 2002-08-27 A | 2002-09-03 A | 118, 119, 121 | 100% |  | 2002-08-27 | 2002-09-03 | 5d |  |  |  | STEREO | IMPACT | SEP Package | LET | LET | CIT |
| 123 | 4.3.30 | Review and approve Printed Circuit Board layout |  | 1d | 2002-08-30 A | 2002-09-04 A | 122FF+1d | 100% |  | 2002-08-30 | 2002-09-04 | 1d |  |  |  | STEREO | IMPACT | SEP Package | LET | LET | CIT |
| 124 | 4.3.31 | Procure test board and parts |  | 6d | 2002-09-05 A | 2002-09-12 A | 123 | 100% |  | 2002-09-05 | 2002-09-12 | 6d |  |  |  | STEREO | IMPACT | SEP Package | LET | LET | CIT |
| 125 | 4.3.32 | Fabricate test fixture |  | 15d | 2002-09-13 A | 2003-04-03 A | 120, 124 | 100% |  | 2002-09-13 | 2003-02-24 | 15d |  |  | finish no earlier than 2003-04-02 | STEREO | IMPACT | SEP Package | LET | LET | CIT |
| 126 | 4.3.33 | Rework/haywire/trim test board |  | 3d | 2003-04-04 A | 2003-04-08 A | 125 | 100% |  | 2003-02-24 | 2003-02-27 | 3d |  |  | start no earlier than 2003-02-01 | STEREO | IMPACT | SEP Package | LET | LET | CIT |
| 127 | 4.3.34 | Doc test board rework |  | 4d | 2003-04-09 A | 2003-04-14 A | 126 | 100% |  | 2003-02-27 | 2003-03-05 | 4d |  |  | start no earlier than 2003-02-01 | STEREO | IMPACT | SEP Package | LET | LET | CIT |
| 128 | 4.3.35 | Package flight hybrids |  | 40d | 2003-03-03 A | 2003-06-16 | 115 | 30% | 28d | 2003-03-03 | 2003-03-27 | 19d | 576d | 21d | start no earlier than 2003-03-03 | STEREO | IMPACT | SEP Package | LET | LET | CIT |
| 129 | 4.3.36 | VLSI packaging | milestone | 0d | 2003-04-25 A | 2003-04-25 A | 128 | 100% |  | 2003-03-27 | 2003-03-27 | 0d |  |  |  | STEREO | IMPACT | SEP Package | LET | LET | CIT |
| 130 | 4.3.37 | Follow-up on flight hybrid packaging |  | 20d | 2003-04-01 A | 2003-05-22 | 128SS | 30% | 14d | 2003-03-03 | 2003-03-27 | 19d | 64d | 0d | start no earlier than 2003-03-31 | STEREO | IMPACT | SEP Package | LET | LET | CIT |
| 131 | 4.3.38 | Test hybrids |  | 20d | 2003-04-29 A | 2003-06-16 | 112, 130, 136 | 20% | 16d | 2003-03-28 | 2003-04-24 | 20d | 65d | 0d | start no earlier than 2003-03-31 | STEREO | IMPACT | SEP Package | LET | LET | CIT |
| 132 | 4.3.39 | Deliver hybrid samples to GSFC | milestone | 0d | 2003-05-12 A | 2003-05-12 | 131SS+10d | 50% | 0d | 2003-04-09 | 2003-04-09 | 0d | 445d | 0d |  | STEREO | IMPACT | SEP Package | LET | LET | CIT |
| 133 | 4.3.40 | Support offsite chip application (HET) |  | 155d | 2003-05-13 | 2003-12-23 | 132 |  |  | 2003-04-10 | 2003-11-14 | 152d | 445d |  |  | STEREO | IMPACT | SEP Package | LET | LET | CIT |
| 134 | 4.3.41 | Doc test results/write report |  | 5d | 2003-06-17 | 2003-06-23 | 131 |  |  | 2003-04-25 | 2003-05-01 | 5d | 571d |  |  | STEREO | IMPACT | SEP Package | LET | LET | CIT |
| 135 | 4.3.42 | QA inspection during flight hybrid packaging |  | 2d | 2003-04-01 A | 2003-05-02 | 128SS | 5% | 1.9d | 2003-03-03 | 2003-03-04 | 2d | 95.1d | 30.1d | start no earlier than 2003-03-31 | STEREO | IMPACT | SEP Package | LET | LET | CIT |
| 136 | 4.3.43 | Develop screening test fixture & software |  | 39d | 2003-02-03 A | 2003-03-28 A | 122 | 100% |  | 2003-02-10 | 2003-04-03 | 38d |  |  | start no earlier than 2003-02-03 | STEREO | IMPACT | SEP Package | LET | LET | CIT |
| 137 | 4.3.44 | Burn in flight parts |  | 20d | 2003-06-17 | 2003-07-15 | 131, 135, 136 |  |  | 2003-04-25 | 2003-05-21 | 19d | 64d | 0d |  | STEREO | IMPACT | SEP Package | LET | LET | CIT |
| 138 | 4.3.45 | Select parts for flight |  | 1d | 2003-07-16 | 2003-07-16 | 137 |  |  | 2003-05-22 | 2003-05-23 | 2d | 64d | 0d |  | STEREO | IMPACT | SEP Package | LET | LET | CIT |
| 139 | 4.3.46 | Document screening/selection |  | 3d | 2003-07-17 | 2003-07-21 | 138 |  |  | 2003-05-27 | 2003-05-29 | 3d | 552d |  |  | STEREO | IMPACT | SEP Package | LET | LET | CIT |
| 140 | 4.3.47 | Maintain hard copy docs (sch, parts, Material list) |  | 266d | 2002-02-25 A | 2003-12-29 | 101 | 38% | 166d | 2002-02-25 | 2003-05-07 | 166d | 442d |  |  | STEREO | IMPACT | SEP Package | LET | LET | CIT |

Notes:
- 124: Alan started not taking some credit due to project.

| ID | WBS | Task | Duration | Start | Finish | Predecessors | Complete | Remaining | Baseline start | Baseline finish | Baseline duration | Total slack | Free slack | Constraint | Text11 | Text12 | Text13 | Text14 | Text16 | Text28 | Text20 | Text22 | Text23 |
| --- | --- | --- | --- | --- | --- | --- | --- | --- | --- | --- | --- | --- | --- | --- | --- | --- | --- | --- | --- | --- | --- | --- | --- |
| 141 | 4.3.48 | **Procurements** | 159d | 2002-07-01 A | 2003-02-19 A |  | 100% |  | 2002-07-01 | 2003-03-03 | 167d |  |  |  | STEREO | IMPACT | SEP Package | LET | LET | CIT |  |  |  |
| 142 | 4.3.48.1 | **ETU** | 21d | 2002-07-01 A | 2002-07-30 A |  | 100% |  | 2002-07-01 | 2002-07-30 | 21d |  |  |  | STEREO | IMPACT | SEP Package | LET | LET | GSFC |  |  |  |
| 143 | 4.3.48.1.1 | Place Order For LET ETU Mounts | 2d | 2002-07-01 A | 2002-07-02 A | 152, 153, 154 | 100% |  | 2002-07-01 | 2002-07-02 | 2d |  |  | start no earlier than 2002-07-31 | STEREO | IMPACT | SEP Package | LET | LET | GSFC |  |  |  |
| 144 | 4.3.48.1.2 | Place Order For LET L1 Prototype Detectors | 2d | 2002-07-29 A | 2002-07-30 A | 165 | 100% |  | 2002-07-29 | 2002-07-30 | 2d |  |  | start no earlier than 2002-08-30 | STEREO | IMPACT | SEP Package | LET | LET | GSFC |  |  |  |
| 145 | 4.3.48.1.3 | Place Order For LET L2-L3 Prototype Detectors | 2d | 2002-07-29 A | 2002-07-30 A | 166, 167 | 100% |  | 2002-07-29 | 2002-07-30 | 2d |  |  | start no earlier than 2002-08-30 | STEREO | IMPACT | SEP Package | LET | LET | GSFC |  |  |  |
| 146 | 4.3.48.2 | **FM 1 & FM 2** | 130d | 2002-08-12 A | 2003-02-19 A |  | 100% |  | 2002-08-12 | 2003-03-03 | 138d |  |  |  | STEREO | IMPACT | SEP Package | LET | LET | GSFC |  |  |  |
| 147 | 4.3.48.2.1 | Place Order For LET Flight Mounts | 2d | 2002-08-12 A | 2002-08-13 A | 152, 153, 154 | 100% |  | 2002-08-12 | 2002-08-13 | 2d |  |  | start no earlier than 2002-07-31 | STEREO | IMPACT | SEP Package | LET | LET | GSFC |  |  |  |
| 148 | 4.3.48.2.2 | Order LET Flight Detectors | 1d | 2003-02-19 A | 2003-02-19 A | 149, 150 | 100% |  | 2003-03-03 | 2003-03-03 | 1d |  |  |  | STEREO | IMPACT | SEP Package | LET | LET | CIT | Order LET Flight Detectors | LET - Place Flight Detector Order | Order Flight Detectors |
| 149 | 4.3.48.2.3 | Place Order For LET L1 Flight Detectors | 2d | 2003-02-17 A | 2003-02-19 A | 172 | 100% |  | 2003-02-28 | 2003-03-03 | 2d |  |  | start no earlier than 2003-02-28 | STEREO | IMPACT | SEP Package | LET | LET | GSFC |  |  |  |
| 150 | 4.3.48.2.4 | Place Order For LET L2-L3 Flight Detectors | 2d | 2003-02-17 A | 2003-02-19 A | 173, 174 | 100% |  | 2003-02-28 | 2003-03-03 | 2d |  |  | start no earlier than 2003-02-28 | STEREO | IMPACT | SEP Package | LET | LET | GSFC |  |  |  |
| 151 | 4.3.49 | **Design** | 242.2d | 2002-05-15 A | 2003-05-02 |  | 98% | 4.7d | 2002-05-15 | 2003-02-10 | 185d | 606.8d |  |  | STEREO | IMPACT | SEP Package | LET | LET | GSFC |  |  |  |
| 152 | 4.3.49.1 | Design LET L1 Mount | 11.84d | 2002-05-15 A | 2002-05-31 A | 37 | 100% |  | 2002-05-15 | 2002-05-31 | 11.84d |  |  | start no earlier than 2002-04-30 | STEREO | IMPACT | SEP Package | LET | LET | GSFC |  |  |  |
| 153 | 4.3.49.2 | Design LET L2 Mount | 16d | 2002-05-29 A | 2002-06-19 A | 37 | 100% |  | 2002-05-29 | 2002-06-19 | 16d |  |  | start no earlier than 2002-04-30 | STEREO | IMPACT | SEP Package | LET | LET | GSFC |  |  |  |
| 154 | 4.3.49.3 | Design LET L3 Mount | 16d | 2002-06-03 A | 2002-06-24 A | 37 | 100% |  | 2002-06-03 | 2002-06-24 | 16d |  |  | start no earlier than 2002-06-30 | STEREO | IMPACT | SEP Package | LET | LET | GSFC |  |  |  |
| 155 | 4.1.2.5 | Design H3-H6 Mounts | 7d | 2002-05-22 A | 2002-06-26 A | 154, 153 | 100% |  |  |  |  |  |  | start no earlier than 2002-04-30 | STEREO | IMPACT | SEP Package | LET | LET | CIT |  |  |  |
| 156 | 4.1.2.3 | Design H1-H2 Mounts | 19d | 2002-05-01 A | 2002-05-28 A | 154, 153 | 100% |  |  |  |  |  |  | start no earlier than 2002-04-30 | STEREO | IMPACT | SEP Package | LET | LET | CIT |  |  |  |
| 157 | 4.3.49.6 | Design LET L1 Detector Test Holder | 6d | 2003-04-01 A | 2003-04-08 A | 152, 154FS+9d | 100% |  | 2003-02-03 | 2003-02-10 | 6d |  |  | start no earlier than 2003-03-31 | STEREO | IMPACT | SEP Package | LET | LET | GSFC |  |  |  |
| 158 | 4.3.49.7 | Design LET L2 Detector Test Holder | 6d | 2003-04-01 A | 2003-04-08 A | 153FS+9d | 100% |  | 2003-02-03 | 2003-02-10 | 6d |  |  | start no earlier than 2003-03-31 | STEREO | IMPACT | SEP Package | LET | LET | GSFC |  |  |  |
| 159 | 4.3.49.8 | Design LET L3 Detector Test Holder | 6d | 2003-04-01 A | 2003-05-02 | 154FS+9d | 80% | 1.2d | 2003-02-03 | 2003-02-10 | 6d | 606.8d |  | start no earlier than 2003-03-31 | STEREO | IMPACT | SEP Package | LET | LET | GSFC |  |  |  |
| 160 | 4.3.50 | **Fabrication** | 290d | 2002-07-25 A | 2003-09-18 |  | 46% | 156.94d | 2002-07-25 | 2003-09-18 | 290d | 510d |  |  | STEREO | IMPACT | SEP Package | LET | LET | GSFC |  |  |  |
| 161 | 4.3.50.1 | Receive & Inspect LET L1 Detector Test Holder | 2d | 2003-04-01 A | 2003-04-02 A |  | 100% |  | 2003-02-03 | 2003-02-04 | 2d |  |  | start no earlier than 2003-03-31 | STEREO | IMPACT | SEP Package | LET | LET | GSFC |  |  |  |
| 162 | 4.3.50.2 | Receive & Inspect LET L2 Detector Test Holder | 2d | 2003-04-01 A | 2003-05-01 |  | 90% | 0.2d | 2003-02-03 | 2003-02-04 | 2d | 538.8d | 1.8d | start no earlier than 2003-03-31 | STEREO | IMPACT | SEP Package | LET | LET | GSFC |  |  |  |
| 163 | 4.3.50.3 | Receive & Inspect LET L3 Detector Test Holder | 2d | 2003-05-01 | 2003-05-02 |  |  |  | 2003-02-03 | 2003-02-04 | 2d | 537d | 0d | start no earlier than 2003-04-30 | STEREO | IMPACT | SEP Package | LET | LET | GSFC |  |  |  |
| 164 | 4.3.50.4 | **ETU** | 192.2d | 2002-07-25 A | 2003-05-01 |  | 98% | 3.84d | 2002-07-25 | 2003-02-04 | 132d | 607.8d |  |  | STEREO | IMPACT | SEP Package | LET | LET | GSFC |  |  |  |
| 165 | 4.3.50.4.1 | Receive & Inspect LET L1 ETU Mounts | 2d | 2002-07-25 A | 2002-07-26 A | 143FS+10d | 100% |  | 2002-07-25 | 2002-07-26 | 2d |  |  | start no earlier than 2002-07-31 | STEREO | IMPACT | SEP Package | LET | LET | GSFC |  |  |  |
| 166 | 4.3.50.4.2 | Receive & Inspect LET L2 ETU Mounts | 2d | 2002-07-25 A | 2002-07-26 A | 143FS+10d | 100% |  | 2002-07-25 | 2002-07-26 | 2d |  |  | start no earlier than 2002-07-31 | STEREO | IMPACT | SEP Package | LET | LET | GSFC |  |  |  |
| 167 | 4.3.50.4.3 | Receive & Inspect LET L3 ETU Mounts | 2d | 2002-07-25 A | 2002-07-26 A | 143FS+10d | 100% |  | 2002-07-25 | 2002-07-26 | 2d |  |  | start no earlier than 2002-07-31 | STEREO | IMPACT | SEP Package | LET | LET | GSFC |  |  |  |
| 168 | 4.3.50.4.4 | Receive & Inspect LET L1 Prototype Detector | 2d | 2002-11-20 A | 2002-11-21 A | 144FS+77d | 100% |  | 2002-11-20 | 2002-11-21 | 2d |  |  |  | STEREO | IMPACT | SEP Package | LET | LET | GSFC |  |  |  |
| 169 | 4.3.50.4.5 | Receive & Inspect LET L2 & L3 Prototype Detectors | 2d | 2003-04-01 A | 2003-05-01 | 145FS+31d | 90% | 0.2d | 2003-02-03 | 2003-02-04 | 2d | 607.8d | 0d | start no earlier than 2003-03-31 | STEREO | IMPACT | SEP Package | LET | LET | GSFC |  |  |  |

| ID | WBS | Task | Type | Duration | Start | Finish | Predecessors | Complete | Remaining | Baseline start | Baseline finish | Baseline duration | Total slack | Free slack | Constraint | Text11 | Text12 | Text13 | Text14 | Text16 | Text28 | Text20 | Text22 | Text23 | Text21 |
| --- | --- | --- | --- | --- | --- | --- | --- | --- | --- | --- | --- | --- | --- | --- | --- | --- | --- | --- | --- | --- | --- | --- | --- | --- | --- |
| 170 | 4.3.50.5 | **FM 1 & FM 2** |  | 98d | 2003-05-01 A | 2003-09-18 |  | 11% | 87.11d | 2003-02-03 | 2003-09-18 | 160d | 510d |  |  | STEREO | IMPACT | SEP Package | LET | LET | GSFC |  |  |  |  |
| 171 | 4.3.50.5.1 | LET Flight Detectors Received | milestone | 0d | 2003-09-18 | 2003-09-18 | 148FS+148d |  |  | 2003-09-30 | 2003-09-30 | 0d | 30d | 0d |  | STEREO | IMPACT | SEP Package | LET | LET | CIT | All LET Flight Detectors Received | LET - All Flight Detectors Received | All Flight Detectors Received |  |
| 172 | 4.3.50.5.2 | Receive & Inspect LET L1 FM 1 & FM 2 Mounts |  | 2d | 2003-05-01 | 2003-05-02 | 147FS+10d |  |  | 2003-02-03 | 2003-02-04 | 2d | 606d |  | start no earlier than 2003-04-30 | STEREO | IMPACT | SEP Package | LET | LET | GSFC |  |  |  |  |
| 173 | 4.3.50.5.3 | Receive & Inspect LET L2 FM 1 & FM 2 Mounts |  | 2d | 2003-05-01 | 2003-05-02 | 147FS+10d |  |  | 2003-02-03 | 2003-02-04 | 2d | 606d |  | start no earlier than 2003-04-30 | STEREO | IMPACT | SEP Package | LET | LET | GSFC |  |  |  |  |
| 174 | 4.3.50.5.4 | Receive & Inspect LET L3 FM 1 & FM 2 Mounts |  | 2d | 2003-05-01 A | 2003-05-02 A | 147FS+10d | 100% |  | 2003-02-03 | 2003-02-04 | 2d |  |  | start no earlier than 2003-04-30 | STEREO | IMPACT | SEP Package | LET | LET | GSFC |  |  |  |  |
| 175 | 4.3.50.5.5 | **FM 1** |  | 2d | 2003-06-18 | 2003-06-19 |  |  |  | 2003-06-18 | 2003-06-19 | 2d | 3d |  |  | STEREO | IMPACT | SEP Package | LET | LET | CIT |  |  |  |  |
| 176 | 4.3.50.5.5.1 | Receive & Inspect LET FM 1 L1 Flight Detector |  | 2d | 2003-06-18 | 2003-06-19 | 149FS+83d |  |  | 2003-06-18 | 2003-06-19 | 2d | 6d |  |  | STEREO | IMPACT | SEP Package | LET | LET | CIT |  |  |  |  |
| 177 | 4.3.50.5.5.2 | Receive & Inspect LET FM 1 L2 Flight Detector |  | 2d | 2003-06-18 | 2003-06-19 | 150FS+83d |  |  | 2003-06-18 | 2003-06-19 | 2d | 2d | 0d |  | STEREO | IMPACT | SEP Package | LET | LET | CIT |  |  |  |  |
| 178 | 4.3.50.5.5.3 | Receive & Inspect LET FM 1 L3 Flight Detector |  | 2d | 2003-06-18 | 2003-06-19 | 150FS+83d |  |  | 2003-06-18 | 2003-06-19 | 2d | 2d | 0d |  | STEREO | IMPACT | SEP Package | LET | LET | CIT |  |  |  |  |
| 179 | 4.3.50.5.6 | **FM 2** |  | 2d | 2003-06-18 | 2003-06-19 |  |  |  | 2003-06-18 | 2003-06-19 | 2d | 3d |  |  | STEREO | IMPACT | SEP Package | LET | LET | CIT |  |  |  |  |
| 180 | 4.3.50.5.6.1 | Receive & Inspect LET FM 2 L1 Flight Detector |  | 2d | 2003-06-18 | 2003-06-19 | 149FS+83d |  |  | 2003-06-18 | 2003-06-19 | 2d | 6d |  |  | STEREO | IMPACT | SEP Package | LET | LET | CIT |  |  |  |  |
| 181 | 4.3.50.5.6.2 | Receive & Inspect LET FM 2 L2 Flight Detector |  | 2d | 2003-06-18 | 2003-06-19 | 150FS+83d |  |  | 2003-06-18 | 2003-06-19 | 2d | 2d | 0d |  | STEREO | IMPACT | SEP Package | LET | LET | CIT |  |  |  |  |
| 182 | 4.3.50.5.6.3 | Receive & Inspect LET FM 2 L3 Flight Detector |  | 2d | 2003-06-18 | 2003-06-19 | 150FS+83d |  |  | 2003-06-18 | 2003-06-19 | 2d | 2d | 0d |  | STEREO | IMPACT | SEP Package | LET | LET | CIT |  |  |  |  |
| 183 | 4.3.51 | **Test** |  | 127d | 2003-05-01 | 2003-10-30 |  |  |  | 2003-02-05 | 2003-10-30 | 187d | 44d |  |  | STEREO | IMPACT | SEP Package | LET | LET | CIT |  |  |  |  |
| 184 | 4.3.51.1 | **ETU** |  | 71d | 2003-05-01 | 2003-08-11 |  |  |  | 2003-02-05 | 2003-05-13 | 69d | 537d |  |  | STEREO | IMPACT | SEP Package | LET | LET | CIT |  |  |  |  |
| 185 | 4.3.51.1.1 | Evaluate LET L1 Prototype Detector |  | 69d | 2003-05-01 | 2003-08-07 | 168FS-50d, 161 |  |  | 2003-02-05 | 2003-05-13 | 69d | 539d |  | start no earlier than 2003-04-30 | STEREO | IMPACT | SEP Package | LET | LET | GSFC |  |  |  | LET Detect. Tested |
| 186 | 4.3.51.1.2 | Evaluate LET L2 & L3 Prototype Detectors |  | 69d | 2003-05-05 | 2003-08-11 | 169FS-80d, 163, 162 |  |  | 2003-02-05 | 2003-05-13 | 69d | 537d |  | start no earlier than 2003-04-30 | STEREO | IMPACT | SEP Package | LET | LET | GSFC |  |  |  |  |
| 187 | 4.3.51.2 | **FM 1 & FM 2** |  | 86d | 2003-06-30 | 2003-10-30 |  |  |  | 2003-06-30 | 2003-10-30 | 86d | 3d |  |  | STEREO | IMPACT | SEP Package | LET | LET | GSFC |  |  |  |  |
| 188 | 4.3.51.2.1 | Capacitance, Current, Depletion, Alpha Resolution |  | 75d | 2003-06-30 | 2003-10-15 | 181FS+6d, 182FS+6d, 177FS+6d, 178FS+6d, 171FF-10d |  |  | 2003-06-30 | 2003-10-15 | 75d | 2d | 0d |  | STEREO | IMPACT | SEP Package | LET | LET | GSFC |  |  |  |  |
| 189 | 4.3.51.2.2 | Life Test LET Flight Detectors |  | 76d | 2003-07-15 | 2003-10-30 | 188SS+10d |  |  | 2003-07-15 | 2003-10-30 | 76d | 2d |  |  | STEREO | IMPACT | SEP Package | LET | LET | GSFC |  |  | Flight Detectors Life Tested |  |
| 190 | 5 | **(OBSOLETE)MISC Board** |  | 562.7d | 2001-12-03 A | 2004-03-02 |  | 31% | 389.57d | 2001-12-03 | 2003-12-01 | 500.7d | 399.3d |  |  | STEREO | IMPACT | SEP Package | LET | LET | CIT |  |  |  |  |
| 191 | 5.1 | **Design, Manufacture, Assembly and Test** |  | 562.7d | 2001-12-03 A | 2004-03-02 |  | 31% | 389.57d | 2001-12-03 | 2003-12-01 | 500.7d | 399.3d |  |  | STEREO | IMPACT | SEP Package | LET | LET | CIT |  |  |  |  |
| 192 | 5.1.1 | **Procurements** |  | 435d | 2001-12-03 A | 2003-08-25 |  | 62% | 166.01d | 2001-12-03 | 2003-07-28 | 415d | 451d |  |  | STEREO | IMPACT | SEP Package | LET | LET | CIT |  |  |  |  |
| 193 | 5.1.1.1 | **ETU** |  | 367d | 2001-12-03 A | 2003-05-19 |  | 74% | 94.1d | 2001-12-03 | 2003-03-04 | 313d | 447d |  |  | STEREO | IMPACT | SEP Package | LET | LET | CIT |  |  |  |  |
| 194 | 5.1.1.1.1 | Procure LET MISC Board Actel 54SX72A FPGA - EM | milestone | 0d | 2001-12-03 A | 2003-04-30 |  | 25% | 0d | 2001-12-03 | 2003-02-01 | 0d | 459d | 8d | finish no earlier than 2002-08-01 | STEREO | IMPACT | SEP Package | LET | LET | CIT |  |  |  |  |
| 195 | 5.1.1.1.2 | Procure LET MISC Board SRAM 128K x 8, 3.3V - EM |  | 29d | 2002-07-01 A | 2003-01-14 A |  | 100% |  | 2002-07-01 | 2003-01-14 | 29d |  |  | finish no earlier than 2002-08-01 | STEREO | IMPACT | SEP Package | LET | LET | CIT |  |  |  |  |
| 196 | 5.1.1.1.3 | Procure LET MISC Board EM Parts |  | 8d | 2003-05-01 | 2003-05-12 | 210, 211 |  |  | 2003-02-03 | 2003-02-12 | 8d | 451d | 0d | start no earlier than 2003-04-30 | STEREO | IMPACT | SEP Package | LET | LET | CIT |  |  |  |  |
| 197 | 5.1.1.1.4 | Procure LET MISC Board EM Printed Circuit Board |  | 2d | 2003-05-16 | 2003-05-19 | 214 |  |  | 2003-03-03 | 2003-03-04 | 2d | 447d | 0d | start no earlier than 2003-04-30 | STEREO | IMPACT | SEP Package | LET | LET | CIT |  |  |  |  |

Notes:
- 186: This is a CIT Function GSFC is evaluating L1 only for CIT
- 190: March 03 Status - This board is obsolete. It was combined with the Detector Board.
- 196: Alan started but project again.MS Project problem @ ?%

| ID | WBS | Task | Type | Duration | Start | Finish | Predecessors | Complete | Remaining | Baseline start | Baseline finish | Baseline duration | Total slack | Free slack | Constraint | Text11 | Text12 | Text13 | Text14 | Text16 | Text28 |
| --- | --- | --- | --- | --- | --- | --- | --- | --- | --- | --- | --- | --- | --- | --- | --- | --- | --- | --- | --- | --- | --- |
| 198 | 5.1.1.2 | **FM 1 & FM 2** |  | 290d | 2002-07-01 A | 2003-08-25 |  | 13% | 252.3d | 2002-07-01 | 2003-07-28 | 270d | 451d |  |  | STEREO | IMPACT | SEP Package | LET | LET | CIT |
| 199 | 5.1.1.2.1 | Procure LET MISC Board Actel RTSX72S FPGA - flight |  | 1d | 2002-07-01 A | 2002-07-01 A |  | 100% |  | 2002-07-01 | 2002-07-01 | 1d |  |  | start no earlier than 2002-07-01 | STEREO | IMPACT | SEP Package | LET | LET | CIT |
| 200 | 5.1.1.2.2 | Procure LET MISC Board SRAM 128K x 8, 3.3V - flight | milestone | 0d | 2002-07-01 A | 2003-04-30 |  | 30% | 0d | 2002-07-01 | 2003-02-01 | 0d | 420d | 20.7d |  | STEREO | IMPACT | SEP Package | LET | LET | CIT |
| 201 | 5.1.1.2.3 | Procure LET MISC Board Clock Oscillator, 32 MHz |  | 1d | 2002-07-02 A | 2003-05-01 |  | 30% | 0.7d | 2002-07-02 | 2003-02-03 | 1d | 399.3d | 0d | start no earlier than 2002-07-01 | STEREO | IMPACT | SEP Package | LET | LET | CIT |
| 202 | 5.1.1.2.4 | Procure LET MISC Board MISC Board Flight Parts |  | 5d | 2003-07-25 | 2003-07-31 | 260 |  |  | 2003-06-26 | 2003-07-02 | 5d | 447d | 0d |  | STEREO | IMPACT | SEP Package | LET | LET | CIT |
| 203 | 5.1.1.2.5 | Procure LET MISC Board flight Printed Circuit Board |  | 3d | 2003-08-21 | 2003-08-25 | 221 |  |  | 2003-07-24 | 2003-07-28 | 3d | 451d | 0d |  | STEREO | IMPACT | SEP Package | LET | LET | CIT |
| 204 | 5.1.2 | **Design** |  | 389.7d | 2002-07-02 A | 2004-01-22 |  | 62% | 148.46d | 2002-07-02 | 2003-10-21 | 327.7d | 426.3d |  |  | STEREO | IMPACT | SEP Package | LET | LET | CIT |
| 205 | 5.1.2.1 | **ETU** |  | 270d | 2002-07-02 A | 2003-07-29 |  | 87% | 36d | 2002-07-02 | 2003-06-30 | 250d | 546d |  |  | STEREO | IMPACT | SEP Package | LET | LET | CIT |
| 206 | 5.1.2.1.1 | Design and sketch LET MISC Printed Circuit Board schematics for EM |  | 40d | 2002-07-02 A | 2002-11-06 A | 297SS | 100% |  | 2002-07-02 | 2002-11-06 | 40d |  |  | start no earlier than 2002-07-01 | STEREO | IMPACT | SEP Package | LET | LET | CIT |
| 207 | 4.1.2.1.3 | Design and sketch Printed Circuit Board schematics for SEP Central Logic EM |  | 56.7d | 2002-07-02 A | 2002-11-12 A | 206SS | 100% |  | 2002-07-02 | 2002-11-12 | 56.7d |  |  |  | STEREO | IMPACT | SEP Package | LET | LET | CIT |
| 208 | 5.1.2.1.3 | Design LET MISC Printed Circuit Board schematics for EM version |  | 5d | 2002-11-07 A | 2002-11-14 A | 206 | 100% |  | 2002-11-07 | 2002-11-14 | 5d |  |  | start no earlier than 2002-10-31 | STEREO | IMPACT | SEP Package | LET | LET | CIT |
| 209 | 5.1.2.1.4 | Design FPGA Schematics/EEPROM for LET MISC Board EM version |  | 10d | 2002-11-15 A | 2002-12-02 A | 208 | 100% |  | 2002-11-15 | 2002-12-02 | 10d |  |  | start no earlier than 2002-10-31 | STEREO | IMPACT | SEP Package | LET | LET | CIT |
| 210 | 5.1.2.1.5 | FMA/design review/risk assessment for LET MISC Board |  | 4d | 2002-12-03 A | 2002-12-06 A | 208, 209 | 100% |  | 2002-12-03 | 2002-12-06 | 4d |  |  | start no earlier than 2002-10-31 | STEREO | IMPACT | SEP Package | LET | LET | CIT |
| 211 | 5.1.2.1.6 | Assess MISC Board EM and Flight Parts |  | 8d | 2002-11-15 A | 2002-11-26 A | 208 | 100% |  | 2002-11-15 | 2002-11-26 | 8d |  |  | start no earlier than 2002-10-31 | STEREO | IMPACT | SEP Package | LET | LET | CIT |
| 212 | 5.1.2.1.7 | Obtain samples & Footprints, provide to LET MISC Printed Circuit Board designer |  | 1d | 2002-11-27 A | 2002-11-27 A | 211 | 100% |  | 2002-11-27 | 2002-11-27 | 1d |  |  | start no earlier than 2002-10-31 | STEREO | IMPACT | SEP Package | LET | LET | CIT |
| 213 | 5.1.2.1.8 | Design EM LET MISC Printed Circuit Board layout |  | 20d | 2003-01-20 A | 2003-05-14 | 208FS+20d, 210FS+20d, 212FS+20d | 50% | 10d | 2003-01-20 | 2003-02-14 | 20d | 447d | 0d | start no earlier than 2003-01-20 | STEREO | IMPACT | SEP Package | LET | LET | CIT |
| 214 | 5.1.2.1.9 | Review & approve EM LET MISC Printed Circuit Board layout |  | 1d | 2003-05-15 | 2003-05-15 | 213 |  |  | 2003-02-18 | 2003-02-18 | 1d | 447d | 0d | start no earlier than 2003-04-30 | STEREO | IMPACT | SEP Package | LET | LET | CIT |
| 215 | 5.1.2.1.10 | Doc EM LET MISC Board rework (traveler, ECR) |  | 1d | 2003-07-29 | 2003-07-29 | 233 |  |  | 2003-06-30 | 2003-06-30 | 1d | 546d |  |  | STEREO | IMPACT | SEP Package | LET | LET | CIT |
| 216 | 5.1.2.2 | **FM 1 & FM 2** |  | 120.7d | 2003-07-29 | 2004-01-22 |  |  |  | 2003-06-30 | 2003-10-21 | 78.7d | 426.3d |  |  | STEREO | IMPACT | SEP Package | LET | LET | CIT |
| 217 | 5.1.2.2.1 | Revise/update LET MISC Printed Circuit Board schematics for flight version |  | 10d | 2003-07-29 | 2003-08-11 | 261 |  |  | 2003-06-30 | 2003-07-14 | 10d | 451d | 0d |  | STEREO | IMPACT | SEP Package | LET | LET | CIT |
| 218 | 5.1.2.2.2 | Revise/update FPGA Schematics/EEPROM for LET MISC Board Flight Version |  | 10d | 2003-07-29 | 2003-08-11 | 261 |  |  | 2003-06-30 | 2003-07-14 | 10d | 451d | 0d |  | STEREO | IMPACT | SEP Package | LET | LET | CIT |
| 219 | 5.1.2.2.3 | Obtain samples & Footprints, provide to LET MISC Printed Circuit Board designer |  | 7d | 2003-08-01 | 2003-08-11 | 202 |  |  | 2003-07-03 | 2003-07-14 | 7d | 451d | 0d |  | STEREO | IMPACT | SEP Package | LET | LET | CIT |
| 220 | 5.1.2.2.4 | Revise/update LET MISC Printed Circuit Board layout for flight version |  | 5d | 2003-08-12 | 2003-08-18 | 217, 218, 219 |  |  | 2003-07-15 | 2003-07-21 | 5d | 451d | 0d |  | STEREO | IMPACT | SEP Package | LET | LET | CIT |
| 221 | 5.1.2.2.5 | Review & approve flight LET MISC Printed Circuit Board layout |  | 2d | 2003-08-19 | 2003-08-20 | 220 |  |  | 2003-07-22 | 2003-07-23 | 2d | 451d | 0d |  | STEREO | IMPACT | SEP Package | LET | LET | CIT |
| 222 | 5.1.2.2.6 | Doc flight LET MISC Board rework (traveler, ECR) |  | 1d | 2004-01-20 | 2004-01-21 | 248, 245 |  |  | 2003-10-17 | 2003-10-20 | 1d | 399.3d | 0d |  | STEREO | IMPACT | SEP Package | LET | LET | CIT |
| 223 | 5.1.2.2.7 | Final update of LET MISC Printed Circuit Board schematics & layout |  | 1d | 2004-01-21 | 2004-01-22 | 222 |  |  | 2003-10-20 | 2003-10-21 | 1d | 426.3d |  |  | STEREO | IMPACT | SEP Package | LET | LET | CIT |

Notes:
- 202: At 25% but MS Project problem
- 211: Alan started but project generates incorrect data for out of sequence activities.
- 212: Alan says at 10 % project problem.

| ID | WBS | Task | Duration | Start | Finish | Predecessors | Baseline start | Baseline finish | Baseline duration | Total slack | Free slack | Constraint | Text11 | Text12 | Text13 | Text14 | Text16 | Text28 |
| --- | --- | --- | --- | --- | --- | --- | --- | --- | --- | --- | --- | --- | --- | --- | --- | --- | --- | --- |
| 224 | 5.1.3 | **Fabrication** | 179.7d | 2003-05-01 | 2004-01-20 |  | 2003-02-03 | 2003-10-17 | 179.7d | 427.3d |  |  | STEREO | IMPACT | SEP Package | LET | LET | CIT |
| 225 | 5.1.3.1 | **ETU** | 48d | 2003-05-20 | 2003-07-28 |  | 2003-03-11 | 2003-06-27 | 78d | 451d |  |  | STEREO | IMPACT | SEP Package | LET | LET | CIT |
| 226 | 5.1.3.1.1 | Receive/inspect/database EM parts for LET MISC Board | 3d | 2003-05-20 | 2003-05-22 | 194FS+5d, 195FS+38d, 196FS+5d | 2003-03-11 | 2003-03-13 | 3d | 451d | 0d | start no earlier than 2003-04-30 | STEREO | IMPACT | SEP Package | LET | LET | CIT |
| 227 | 5.1.3.1.2 | Generate EM kit list in database for LET MISC Board | 2d | 2003-05-23 | 2003-05-27 | 226 | 2003-03-14 | 2003-03-17 | 2d | 451d | 0d | start no earlier than 2003-04-30 | STEREO | IMPACT | SEP Package | LET | LET | CIT |
| 228 | 5.1.3.1.3 | Burn in EM FPGA/EEPROM for LET MISC Board | 2d | 2003-05-23 | 2003-05-27 | 226, 209 | 2003-03-14 | 2003-03-17 | 2d | 456d | 9d | start no earlier than 2003-04-30 | STEREO | IMPACT | SEP Package | LET | LET | CIT |
| 229 | 5.1.3.1.4 | Bend leads on EM Ics for LET MISC Board | 1d | 2003-05-23 | 2003-05-23 | 226 | 2003-03-14 | 2003-03-14 | 1d | 457d | 10d | start no earlier than 2003-04-30 | STEREO | IMPACT | SEP Package | LET | LET | CIT |
| 230 | 5.1.3.1.5 | Inspect EM LET MISC Printed Circuit Board | 1d | 2003-06-09 | 2003-06-09 | 197FS+13d | 2003-03-24 | 2003-03-24 | 1d | 447d | 0d |  | STEREO | IMPACT | SEP Package | LET | LET | CIT |
| 231 | 5.1.3.1.6 | Generate EM kit book for LET MISC Board | 2d | 2003-05-28 | 2003-05-29 | 227 | 2003-03-18 | 2003-03-19 | 2d | 451d | 0d | start no earlier than 2003-04-30 | STEREO | IMPACT | SEP Package | LET | LET | CIT |
| 232 | 5.1.3.1.7 | Kit EM parts for LET MISC Board | 3d | 2003-05-30 | 2003-06-03 | 231 | 2003-05-07 | 2003-05-09 | 3d | 451d | 4d | start no earlier than 2003-04-30 | STEREO | IMPACT | SEP Package | LET | LET | CIT |
| 233 | 5.1.3.1.8 | Rework/haywire/trim EM for LET MISC Printed Circuit Board | 2d | 2003-07-25 | 2003-07-28 | 260 | 2003-06-26 | 2003-06-27 | 2d | 546d | 0d |  | STEREO | IMPACT | SEP Package | LET | LET | CIT |
| 234 | 5.1.3.2 | **FM 1 & FM 2** | 149.7d | 2003-05-01 | 2003-12-04 |  | 2003-02-03 | 2003-09-04 | 149.7d | 399.3d |  |  | STEREO | IMPACT | SEP Package | LET | LET | CIT |
| 235 | 5.1.3.2.1 | Receive/inspect/database flight parts for LET MISC Board | 3d | 2003-11-20 | 2003-11-25 | 199FS+90d, 200FS+120d, 201FS+140d, 202FS+29d | 2003-08-21 | 2003-08-26 | 3d | 399.3d | 0d |  | STEREO | IMPACT | SEP Package | LET | LET | CIT |
| 236 | 5.1.3.2.2 | Generate flight kit list in database for LET MISC Board | 1d | 2003-11-25 | 2003-11-26 | 235 | 2003-08-26 | 2003-08-27 | 1d | 399.3d | 0d |  | STEREO | IMPACT | SEP Package | LET | LET | CIT |
| 237 | 5.1.3.2.3 | Rescreen heritage flight parts for LET MISC Board | 2d | 2003-05-01 | 2003-05-02 | 211 | 2003-02-03 | 2003-02-04 | 2d | 547d | 147.7d | start no earlier than 2003-04-30 | STEREO | IMPACT | SEP Package | LET | LET | CIT |
| 238 | 5.1.3.2.4 | Burn-in flight FPGA/EEPROM for LET MISC Board | 1d | 2003-11-25 | 2003-11-26 | 235, 217 | 2003-08-26 | 2003-08-27 | 1d | 404.3d | 5d |  | STEREO | IMPACT | SEP Package | LET | LET | CIT |
| 239 | 5.1.3.2.5 | Bend leads on flight Ics for LET MISC Board | 2d | 2003-11-25 | 2003-11-28 | 235, 221 | 2003-08-26 | 2003-08-28 | 2d | 403.3d | 4d |  | STEREO | IMPACT | SEP Package | LET | LET | CIT |
| 240 | 5.1.3.2.6 | Inspect flight for LET MISC Printed Circuit Boards (coupons & elec continuity) | 3d | 2003-09-16 | 2003-09-18 | 203FS+14d | 2003-08-18 | 2003-08-20 | 3d | 451d | 51.7d |  | STEREO | IMPACT | SEP Package | LET | LET | CIT |
| 241 | 5.1.3.2.7 | Generate flight kit book for LET MISC Board | 2d | 2003-11-26 | 2003-12-01 | 236 | 2003-08-27 | 2003-08-29 | 2d | 399.3d | 0d |  | STEREO | IMPACT | SEP Package | LET | LET | CIT |
| 242 | 5.1.3.2.8 | Kit flight parts for LET MISC Board | 3d | 2003-12-01 | 2003-12-04 | 241 | 2003-08-29 | 2003-09-04 | 3d | 399.3d | 0d |  | STEREO | IMPACT | SEP Package | LET | LET | CIT |
| 243 | 5.1.3.3 | **FM 1** | 3d | 2004-01-15 | 2004-01-20 |  | 2003-10-14 | 2003-10-17 | 3d | 399.3d |  |  | STEREO | IMPACT | SEP Package | LET | LET | CIT |
| 244 | 5.1.3.3.1 | Rework/haywire/trim LET FM 1 MISC Board | 2d | 2004-01-15 | 2004-01-19 | 263 | 2003-10-14 | 2003-10-16 | 2d | 399.3d | 0d |  | STEREO | IMPACT | SEP Package | LET | LET | CIT |
| 245 | 5.1.3.3.2 | Post-rework QA inspection for LET FM 1 MISC Board | 1d | 2004-01-19 | 2004-01-20 | 244 | 2003-10-16 | 2003-10-17 | 1d | 399.3d | 0d |  | STEREO | IMPACT | SEP Package | LET | LET | CIT |
| 246 | 5.1.3.4 | **FM 2** | 2d | 2004-01-15 | 2004-01-19 |  | 2003-10-14 | 2003-10-16 | 2d | 400.3d |  |  | STEREO | IMPACT | SEP Package | LET | LET | CIT |
| 247 | 5.1.3.4.1 | Rework/haywire/trim LET FM 2 MISC Board | 2d | 2004-01-15 | 2004-01-19 | 271 | 2003-10-14 | 2003-10-16 | 2d | 400.3d | 0d |  | STEREO | IMPACT | SEP Package | LET | LET | CIT |
| 248 | 5.1.3.4.2 | Post-rework QA inspection for LET FM 2 MISC Board | 1d | 2004-01-16 | 2004-01-19 | 247FS-1d | 2003-10-15 | 2003-10-16 | 1d | 400.3d | 1d |  | STEREO | IMPACT | SEP Package | LET | LET | CIT |

Notes:
- 232: Dropped SS pred with 322

| ID | WBS | Task | Duration | Start | Finish | Predecessors | Baseline start | Baseline finish | Baseline duration | Total slack | Free slack | Text11 | Text12 | Text13 | Text14 | Text16 | Text28 | Text23 |
| --- | --- | --- | --- | --- | --- | --- | --- | --- | --- | --- | --- | --- | --- | --- | --- | --- | --- | --- |
| 249 | 5.1.4 | **Assembly** | 130.7d | 2003-06-10 | 2003-12-16 |  | 2003-05-12 | 2003-09-16 | 88.7d | 400.3d |  | STEREO | IMPACT | SEP Package | LET | LET | CIT |  |
| 250 | 5.1.4.1 | **ETU** | 2d | 2003-06-10 | 2003-06-11 |  | 2003-05-12 | 2003-05-13 | 2d | 447d |  | STEREO | IMPACT | SEP Package | LET | LET | CIT |  |
| 251 | 5.1.4.1.1 | Assemble EM LET MISC Board | 2d | 2003-06-10 | 2003-06-11 | 230, 229, 228, 232 | 2003-05-12 | 2003-05-13 | 2d | 447d | 0d | STEREO | IMPACT | SEP Package | LET | LET | CIT | (obsolete)EM MISC Board Assembled |
| 252 | 5.1.4.2 | **FM 1** | 8d | 2003-12-04 | 2003-12-16 |  | 2003-09-04 | 2003-09-16 | 8d | 399.3d |  | STEREO | IMPACT | SEP Package | LET | LET | CIT |  |
| 253 | 5.1.4.2.1 | Assemble FM 1 Let MISC Board | 7d | 2003-12-04 | 2003-12-15 | 237, 238, 239, 240, 242 | 2003-09-04 | 2003-09-15 | 7d | 399.3d | 0d | STEREO | IMPACT | SEP Package | LET | LET | CIT |  |
| 254 | 5.1.4.2.2 | Post-assembly QA inpection for LET FM 1 MISC Board | 1d | 2003-12-15 | 2003-12-16 | 253 | 2003-09-15 | 2003-09-16 | 1d | 399.3d | 0d | STEREO | IMPACT | SEP Package | LET | LET | CIT | (obsolete)FM 1 MISC Board Assembled |
| 255 | 5.1.4.3 | **FM 2** | 8d | 2003-12-04 | 2003-12-16 |  | 2003-09-04 | 2003-09-16 | 8d | 400.3d |  | STEREO | IMPACT | SEP Package | LET | LET | CIT |  |
| 256 | 5.1.4.3.1 | Assemble FM 2 LET MISC Board | 7d | 2003-12-04 | 2003-12-15 | 240, 237, 238, 239, 242 | 2003-09-04 | 2003-09-15 | 7d | 400.3d | 0d | STEREO | IMPACT | SEP Package | LET | LET | CIT |  |
| 257 | 5.1.4.3.2 | Post-assembly QA inspection for LET FM 2 MISC Board | 1d | 2003-12-15 | 2003-12-16 | 256 | 2003-09-15 | 2003-09-16 | 1d | 400.3d | 0d | STEREO | IMPACT | SEP Package | LET | LET | CIT | (obsolete)FM 2 MISC Board Assembled |
| 258 | 5.1.5 | **Test** | 179.7d | 2003-06-12 | 2004-03-02 |  | 2003-05-14 | 2003-12-01 | 137.7d | 399.3d |  | STEREO | IMPACT | SEP Package | LET | LET | CIT |  |
| 259 | 5.1.5.1 | **ETU** | 32d | 2003-06-12 | 2003-07-28 |  | 2003-05-14 | 2003-06-27 | 32d | 447d |  | STEREO | IMPACT | SEP Package | LET | LET | CIT |  |
| 260 | 5.1.5.1.1 | Test EM LET MISC Board | 30d | 2003-06-12 | 2003-07-24 | 251, 369 | 2003-05-14 | 2003-06-25 | 30d | 447d | 0d | STEREO | IMPACT | SEP Package | LET | LET | CIT | (obsolete)EM MISC Board Tested |
| 261 | 5.1.5.1.2 | Doc EM LET MISC Board test results | 2d | 2003-07-25 | 2003-07-28 | 260 | 2003-06-26 | 2003-06-27 | 2d | 451d | 0d | STEREO | IMPACT | SEP Package | LET | LET | CIT |  |
| 262 | 5.1.5.2 | **FM 1** | 39d | 2003-12-16 | 2004-02-12 |  | 2003-09-16 | 2003-11-12 | 39d | 399.3d |  | STEREO | IMPACT | SEP Package | LET | LET | CIT |  |
| 263 | 5.1.5.2.1 | Test FM 1 LET MISC Board (initial) | 19d | 2003-12-16 | 2004-01-15 | 254, 370 | 2003-09-16 | 2003-10-14 | 19d | 399.3d | 0d | STEREO | IMPACT | SEP Package | LET | LET | CIT |  |
| 264 | 5.1.5.2.2 | Doc FM 1 LET MISC Boards test results | 3d | 2004-01-15 | 2004-01-20 | 263 | 2003-10-14 | 2003-10-17 | 3d | 428.3d |  | STEREO | IMPACT | SEP Package | LET | LET | CIT |  |
| 265 | 5.1.5.2.3 | Stake/conformal coat FM 1 LET MISC Boards | 3d | 2004-01-21 | 2004-01-26 | 222 | 2003-10-20 | 2003-10-23 | 3d | 399.3d | 0d | STEREO | IMPACT | SEP Package | LET | LET | CIT |  |
| 266 | 5.1.5.2.4 | Bakeout FM 1 LET MISC Boards | 1d | 2004-01-26 | 2004-01-27 | 265 | 2003-10-23 | 2003-10-24 | 1d | 399.3d | 0d | STEREO | IMPACT | SEP Package | LET | LET | CIT |  |
| 267 | 5.1.5.2.5 | Post-conf. Coat QA inspection for FM 1 LET MISC Board | 1d | 2004-01-27 | 2004-01-28 | 266 | 2003-10-24 | 2003-10-27 | 1d | 399.3d | 0d | STEREO | IMPACT | SEP Package | LET | LET | CIT |  |
| 268 | 5.1.5.2.6 | Test LET FM 1 MISC Board (final) | 10d | 2004-01-28 | 2004-02-11 | 267 | 2003-10-27 | 2003-11-11 | 10d | 399.3d | 0d | STEREO | IMPACT | SEP Package | LET | LET | CIT | (obsolete)FM 1 MISC Board Tested |
| 269 | 5.1.5.2.7 | Mass properties/photo for LET FM 1 MISC Board | 1d | 2004-02-11 | 2004-02-12 | 268 | 2003-11-11 | 2003-11-12 | 1d | 399.3d | 0d | STEREO | IMPACT | SEP Package | LET | LET | CIT |  |
| 270 | 5.1.5.3 | **FM 1 & FM 2** | 38d | 2003-12-16 | 2004-02-11 |  | 2003-09-16 | 2003-11-11 | 38d | 400.3d |  | STEREO | IMPACT | SEP Package | LET | LET | CIT |  |
| 271 | 5.1.5.3.1 | Test FM 2 LET MISC Board (initial) | 19d | 2003-12-16 | 2004-01-15 | 257, 370 | 2003-09-16 | 2003-10-14 | 19d | 400.3d | 0d | STEREO | IMPACT | SEP Package | LET | LET | CIT |  |
| 272 | 5.1.5.3.2 | Doc FM 2 LET MISC Boards test results | 3d | 2004-01-15 | 2004-01-20 | 271 | 2003-10-14 | 2003-10-17 | 3d | 428.3d |  | STEREO | IMPACT | SEP Package | LET | LET | CIT |  |
| 273 | 5.1.5.3.3 | Stake/conformal coat FM 2 LET MISC Board | 3d | 2004-01-21 | 2004-01-26 | 222 | 2003-10-20 | 2003-10-23 | 3d | 400.3d | 0d | STEREO | IMPACT | SEP Package | LET | LET | CIT |  |
| 274 | 5.1.5.3.4 | Bakeout FM 2 LET MISC Boards | 1d | 2004-01-26 | 2004-01-27 | 273 | 2003-10-23 | 2003-10-24 | 1d | 400.3d | 0d | STEREO | IMPACT | SEP Package | LET | LET | CIT |  |
| 275 | 5.1.5.3.5 | Post-conf. Coat QA inspection for FM 2 LET MISC Board | 1d | 2004-01-27 | 2004-01-28 | 274 | 2003-10-24 | 2003-10-27 | 1d | 400.3d | 0d | STEREO | IMPACT | SEP Package | LET | LET | CIT |  |
| 276 | 5.1.5.3.6 | Test LET FM 2 MISC Board (final) | 10d | 2004-01-28 | 2004-02-11 | 275 | 2003-10-27 | 2003-11-11 | 10d | 400.3d | 0d | STEREO | IMPACT | SEP Package | LET | LET | CIT | (obsolete)FM 2 MISC Board Tested |
| 277 | 5.1.5.3.7 | Mass properties/photo for LET FM 2 MISC Boards | 1d | 2004-02-10 | 2004-02-11 | 276FS-1d | 2003-11-07 | 2003-11-11 | 1d | 400.3d | 1d | STEREO | IMPACT | SEP Package | LET | LET | CIT |  |

| ID | WBS | Task | Type | Duration | Start | Finish | Predecessors | Complete | Remaining | Baseline start | Baseline finish | Baseline duration | Total slack | Free slack | Constraint | Text11 | Text12 | Text13 | Text14 | Text16 | Text28 | Text21 | Text23 |
| --- | --- | --- | --- | --- | --- | --- | --- | --- | --- | --- | --- | --- | --- | --- | --- | --- | --- | --- | --- | --- | --- | --- | --- |
| 278 | 5.1.5.4 | **FM 1 & FM 2** |  | 12d | 2004-02-12 | 2004-03-02 |  |  |  | 2003-11-12 | 2003-12-01 | 12d | 399.3d |  |  | STEREO | IMPACT | SEP Package | LET | LET | CIT |  |  |
| 279 | 5.1.5.4.1 | Maintain hard copy docs for LET MISC Board |  | 12d | 2004-02-12 | 2004-03-02 | 277, 269 |  |  | 2003-11-12 | 2003-12-01 | 12d | 399.3d |  |  | STEREO | IMPACT | SEP Package | LET | LET | CIT |  |  |
| 280 | 6 | **Detector/MISC Board** |  | 516.5d | 2001-12-03 A | 2003-12-23 |  | 46% | 276.53d | 2001-12-03 | 2003-12-04 | 504d | 445.5d |  |  | STEREO | IMPACT | SEP Package | LET | LET | CIT |  |  |
| 281 | 6.1 | **Design, Manufacture, Assembly and Test** |  | 516.5d | 2001-12-03 A | 2003-12-23 |  | 46% | 276.53d | 2001-12-03 | 2003-12-04 | 504d | 445.5d |  |  | STEREO | IMPACT | SEP Package | LET | LET | CIT |  |  |
| 282 | 6.1.1 | **Procurements** |  | 427.5d | 2001-12-03 A | 2003-08-14 |  | 86% | 59.85d | 2001-12-03 | 2003-07-28 | 415d | 29.5d |  |  | STEREO | IMPACT | SEP Package | LET | LET | CIT |  |  |
| 283 | 6.1.1.1 | **ETU** |  | 356.5d | 2001-12-03 A | 2003-05-05 A |  | 100% |  | 2001-12-03 | 2003-03-17 | 322d |  |  |  | STEREO | IMPACT | SEP Package | LET | LET | CIT |  |  |
| 284 | 6.1.1.1.1 | Procure LET Detector Board Actel 54SX72A FPGA - EM | milestone | 0d | 2001-12-03 A | 2003-01-22 A |  | 100% |  | 2001-12-03 | 2003-01-22 | 0d |  |  | finish no earlier than 2002-08-01 | STEREO | IMPACT | SEP Package | LET | LET | CIT | SRAM EM Proc. |  |
| 285 | 6.1.1.1.2 | Procure LET Detector Board SRAM 128K x 8, 3.3V - EM |  | 28d | 2002-07-01 A | 2003-01-10 A |  | 100% |  | 2002-07-01 | 2003-01-10 | 28d |  |  | finish no earlier than 2002-08-01 | STEREO | IMPACT | SEP Package | LET | LET | CIT |  |  |
| 286 | 6.1.1.1.3 | Procure LET Detector Board EEPROM 128K x 8, 3.3V - EM |  | 1d | 2002-07-01 A | 2002-08-01 A |  | 100% |  | 2002-07-01 | 2002-08-01 | 1d |  |  | finish no earlier than 2002-08-01 | STEREO | IMPACT | SEP Package | LET | LET | CIT |  |  |
| 287 | 6.1.1.1.4 | Procure LET Detector Board Detector Board EM Parts |  | 10d | 2003-03-03 A | 2003-03-14 A | 299, 300 | 100% |  | 2003-03-03 | 2003-03-14 | 10d |  |  | start no earlier than 2003-03-03 | STEREO | IMPACT | SEP Package | LET | LET | CIT |  |  |
| 288 | 6.1.1.1.5 | Procure LET Detector Board EM PCB |  | 2d | 2003-05-01 A | 2003-05-05 A | 304 | 100% |  | 2003-03-14 | 2003-03-17 | 2d |  |  | start no earlier than 2003-04-30 | STEREO | IMPACT | SEP Package | LET | LET | CIT |  |  |
| 289 | 6.1.1.2 | **FM 1 & FM 2** |  | 282.5d | 2002-07-01 A | 2003-08-14 |  | 22% | 219.72d | 2002-07-01 | 2003-07-28 | 270d | 29.5d |  |  | STEREO | IMPACT | SEP Package | LET | LET | CIT |  |  |
| 290 | 6.1.1.2.1 | Procure LET Detector Board Actel RTSX72S FPGA - flight |  | 1d | 2002-07-01 A | 2002-07-01 A |  | 100% |  | 2002-07-01 | 2002-07-01 | 1d |  |  | start no earlier than 2002-07-01 | STEREO | IMPACT | SEP Package | LET | LET | CIT |  |  |
| 291 | 6.1.1.2.2 | Procure LET Detector Board SRAM 128K x 8, 3.3V - flight | milestone | 0d | 2002-07-01 A | 2003-03-31 A |  | 100% |  | 2002-07-01 | 2003-02-01 | 0d |  |  | finish no earlier than 2002-08-01 | STEREO | IMPACT | SEP Package | LET | LET | CIT |  |  |
| 292 | 6.1.1.2.3 | Procure LET Detector Board EEPROM 128K x 8, 3.3V - flight |  | 1d | 2002-07-01 A | 2002-08-01 A |  | 100% |  | 2002-07-01 | 2002-08-01 | 1d |  |  | finish no earlier than 2002-08-01 | STEREO | IMPACT | SEP Package | LET | LET | CIT |  |  |
| 293 | 6.1.1.2.4 | Procure LET Detector Board Flight Parts |  | 5d | 2003-07-16 | 2003-07-23 | 346 |  |  | 2003-06-27 | 2003-07-03 | 5d | 12.5d | 0d |  | STEREO | IMPACT | SEP Package | LET | LET | CIT |  |  |
| 294 | 6.1.1.2.5 | Procure flight LET Detector Printed Circuit Board |  | 2d | 2003-08-12 | 2003-08-14 | 311 |  |  | 2003-07-25 | 2003-07-28 | 2d | 28.5d | 0d |  | STEREO | IMPACT | SEP Package | LET | LET | CIT |  |  |
| 295 | 6.1.2 | **Design** |  | 349.5d | 2002-07-02 A | 2003-11-21 |  | 78% | 77.86d | 2002-07-02 | 2003-11-03 | 337d | 466.5d |  |  | STEREO | IMPACT | SEP Package | LET | LET | CIT |  |  |
| 296 | 6.1.2.1 | **ETU** |  | 263.5d | 2002-07-02 A | 2003-07-21 |  | 99% | 2.14d | 2002-07-02 | 2003-07-01 | 251d | 29.5d |  |  | STEREO | IMPACT | SEP Package | LET | LET | CIT |  |  |
| 297 | 6.1.2.1.1 | Design & sketch LET Detector Printed Circuit Board schematics for EM |  | 59.1d | 2002-07-02 A | 2002-12-09 A | 96FS+126d | 100% |  | 2002-07-02 | 2002-12-09 | 59.1d |  |  | start no earlier than 2002-07-01 | STEREO | IMPACT | SEP Package | LET | LET | CIT |  |  |
| 298 | 6.1.2.1.2 | Design LET Detector Printed Circuit Board schematics for EM version |  | 5d | 2002-12-10 A | 2002-12-16 A | 297 | 100% |  | 2002-12-10 | 2002-12-16 | 5d |  |  | start no earlier than 2002-11-30 | STEREO | IMPACT | SEP Package | LET | LET | CIT |  |  |
| 299 | 6.1.2.1.3 | Design FPGA Schematics/EEPROM for LET Detector Board EM |  | 18d | 2002-12-17 A | 2003-01-14 A | 298 | 100% |  | 2002-12-17 | 2003-01-14 | 18d |  |  | start no earlier than 2002-11-30 | STEREO | IMPACT | SEP Package | LET | LET | CIT |  |  |
| 300 | 6.1.2.1.4 | FMA/design review/risk assessment for LET Detector Board |  | 5d | 2003-01-15 A | 2003-01-21 A | 298, 299 | 100% |  | 2003-01-15 | 2003-01-21 | 5d |  |  |  | STEREO | IMPACT | SEP Package | LET | LET | CIT |  |  |
| 301 | 6.1.2.1.5 | Assess LET Detector Board EM and Flight Parts |  | 14d | 2002-12-17 A | 2003-01-07 A | 298 | 100% |  | 2002-12-17 | 2003-01-07 | 14d |  |  | start no earlier than 2002-11-30 | STEREO | IMPACT | SEP Package | LET | LET | CIT |  |  |
| 302 | 6.1.2.1.6 | Obtain samples & Footprints, provide to LET Detector Printed Circuit Board designer |  | 5d | 2003-01-08 A | 2003-01-15 A | 301 | 100% |  | 2003-01-08 | 2003-01-15 | 5d |  |  |  | STEREO | IMPACT | SEP Package | LET | LET | CIT |  |  |
| 303 | 6.1.2.1.7 | Design EM LET Detector Printed Circuit Board layout |  | 15d | 2003-02-20 A | 2003-04-01 A | 300, 298FS+20d, 302 | 100% |  | 2003-02-20 | 2003-03-12 | 15d |  |  |  | STEREO | IMPACT | SEP Package | LET | LET | CIT |  |  |
| 304 | 6.1.2.1.8 | Review & approve EM LET Detector Printed Circuit Board layout |  | 1d | 2003-04-02 A | 2003-05-01 A | 303 | 100% |  | 2003-03-13 | 2003-03-13 | 1d |  |  | start no earlier than 2003-03-31 | STEREO | IMPACT | SEP Package | LET | LET | CIT |  | EM Detector Board Designed |
| 305 | 6.1.2.1.9 | Doc EM LET Detector Board rework (traveler, ECR) |  | 1d | 2003-07-18 | 2003-07-21 | 323 |  |  | 2003-07-01 | 2003-07-01 | 1d | 28.5d | 0d |  | STEREO | IMPACT | SEP Package | LET | LET | CIT |  |  |

Notes:
- 287: 20% MS Project Problem
- 288: Dropped succ SS with 197
- 290: Need Activities from Antonio related to decision to have GSFC procure.
- 293: 25% MS project problem
- 301: at 50% MS project problem
- 302: 10% MS Project Problem.

| ID | WBS | Task | Duration | Start | Finish | Predecessors | Complete | Remaining | Baseline start | Baseline finish | Baseline duration | Total slack | Free slack | Constraint | Text11 | Text12 | Text13 | Text14 | Text16 | Text28 | Text23 |
| --- | --- | --- | --- | --- | --- | --- | --- | --- | --- | --- | --- | --- | --- | --- | --- | --- | --- | --- | --- | --- | --- |
| 306 | 6.1.2.2 | **FM 1 & FM 2** | 86d | 2003-07-21 | 2003-11-21 |  |  |  | 2003-07-02 | 2003-11-03 | 86d | 29.5d |  |  | STEREO | IMPACT | SEP Package | LET | LET | CIT |  |
| 307 | 6.1.2.2.1 | Revise/update LET Detector Printed Circuit Board schematics for flight version | 10d | 2003-07-21 | 2003-08-04 | 305 |  |  | 2003-07-02 | 2003-07-16 | 10d | 28.5d | 0d |  | STEREO | IMPACT | SEP Package | LET | LET | CIT |  |
| 308 | 6.1.2.2.2 | Revise/update FPGA Schematics/EEPROM for LET Detector Board Flight Version | 10d | 2003-07-21 | 2003-08-04 | 305 |  |  | 2003-07-02 | 2003-07-16 | 10d | 28.5d | 0d |  | STEREO | IMPACT | SEP Package | LET | LET | CIT |  |
| 309 | 6.1.2.2.3 | Obtain samples & Footprints, provide to LET Detector Printed Circuit Board designer | 6d | 2003-07-23 | 2003-07-31 | 293 |  |  | 2003-07-07 | 2003-07-14 | 6d | 30.5d | 2d |  | STEREO | IMPACT | SEP Package | LET | LET | CIT |  |
| 310 | 6.1.2.2.4 | Revise/update LET Detector Printed Circuit Board layout for flight version | 4d | 2003-08-04 | 2003-08-08 | 307, 308, 309 |  |  | 2003-07-17 | 2003-07-22 | 4d | 28.5d | 0d |  | STEREO | IMPACT | SEP Package | LET | LET | CIT |  |
| 311 | 6.1.2.2.5 | Review & approve flight LET Detector Printed Circuit Board layout | 2d | 2003-08-08 | 2003-08-12 | 310 |  |  | 2003-07-23 | 2003-07-24 | 2d | 28.5d | 0d |  | STEREO | IMPACT | SEP Package | LET | LET | CIT | Flight Detector Board Design Rework |
| 312 | 6.1.2.2.6 | Doc flight LET Detector Board rework (traveler, ECR) | 1d | 2003-11-19 | 2003-11-20 | 334 |  |  | 2003-10-31 | 2003-10-31 | 1d | 12.5d | 0d |  | STEREO | IMPACT | SEP Package | LET | LET | CIT |  |
| 313 | 6.1.2.2.7 | Final update of LET Detector Printed Circuit Board schematics & layout | 1d | 2003-11-20 | 2003-11-21 | 312 |  |  | 2003-11-03 | 2003-11-03 | 1d | 466.5d |  |  | STEREO | IMPACT | SEP Package | LET | LET | CIT |  |
| 314 | 6.1.3 | **Fabrication** | 161.5d | 2003-04-01 A | 2003-11-19 |  | 37% | 102.17d | 2003-04-14 | 2003-10-30 | 140d | 13.5d |  |  | STEREO | IMPACT | SEP Package | LET | LET | CIT |  |
| 315 | 6.1.3.1 | **ETU** | 76.5d | 2003-04-01 A | 2003-07-18 |  | 80% | 15.48d | 2003-04-14 | 2003-06-30 | 55d | -12.5d | 0d |  | STEREO | IMPACT | SEP Package | LET | LET | CIT |  |
| 316 | 6.1.3.1.1 | Receive/inspect/database EM parts for LET Detector Board | 7d | 2003-04-01 A | 2003-05-01 | 287FS+10d | 95% | 0.35d | 2003-04-14 | 2003-04-22 | 7d | 0.05d | 0d | start no earlier than 2003-03-31 | STEREO | IMPACT | SEP Package | LET | LET | CIT |  |
| 317 | 6.1.3.1.2 | Inspect EM PCB LET Detector Printed Circuit Board | 1d | 2003-05-19 | 2003-05-20 | 288FS+10d |  |  | 2003-04-15 | 2003-04-15 | 1d | -12.5d | 0d | start no earlier than 2003-04-30 | STEREO | IMPACT | SEP Package | LET | LET | CIT | EM Detector Board Fabricated |
| 318 | 6.1.3.1.3 | Generate EM kit list in database for LET Detector Board | 2d | 2003-04-10 A | 2003-04-11 A | 316 | 100% |  | 2003-04-23 | 2003-04-24 | 2d |  |  |  | STEREO | IMPACT | SEP Package | LET | LET | CIT |  |
| 319 | 6.1.3.1.4 | Burn in EM FPGA/EEPROM for LET Detector Board | 2d | 2003-04-10 A | 2003-05-01 | 299, 316 | 70% | 0.6d | 2003-04-23 | 2003-04-24 | 2d | 0.05d |  |  | STEREO | IMPACT | SEP Package | LET | LET | CIT |  |
| 320 | 6.1.3.1.5 | Bend leads on EM ICs for LET Detector Board | 1d | 2003-04-10 A | 2003-05-01 | 316 | 90% | 0.1d | 2003-04-23 | 2003-04-23 | 1d | 0.55d |  |  | STEREO | IMPACT | SEP Package | LET | LET | CIT |  |
| 321 | 6.1.3.1.6 | Generate EM kit book for LET Detector Board | 2d | 2003-04-14 A | 2003-04-15 A | 318 | 100% |  | 2003-04-25 | 2003-04-28 | 2d |  |  |  | STEREO | IMPACT | SEP Package | LET | LET | CIT |  |
| 322 | 6.1.3.1.7 | Kit EM parts for LET Detector Board | 4d | 2003-04-29 A | 2003-05-02 | 321FS-1d, 284FS+30d, 285FS+30d, 286FS+30d, 104, 105, 129, 131SS | 95% | 0.2d | 2003-04-28 | 2003-05-01 | 4d | -1d | 0d |  | STEREO | IMPACT | SEP Package | LET | LET | CIT |  |
| 323 | 6.1.3.1.8 | Rework/haywire/trim EM LET Detector Board | 2d | 2003-07-16 | 2003-07-18 | 346 |  |  | 2003-06-27 | 2003-06-30 | 2d | -12.5d | 0d |  | STEREO | IMPACT | SEP Package | LET | LET | CIT |  |
| 324 | 6.1.3.2 | **FM 1 & FM 2** | 120.5d | 2003-05-29 A | 2003-11-19 |  | 4% | 115.12d | 2003-06-03 | 2003-10-30 | 105d | 13.5d |  |  | STEREO | IMPACT | SEP Package | LET | LET | CIT |  |
| 325 | 6.1.3.2.1 | Receive/inspect/database flight parts for LET Detector Board | 6d | 2003-09-16 | 2003-09-24 | 293FS+38d |  |  | 2003-08-28 | 2003-09-05 | 6d | 12.5d | 0d |  | STEREO | IMPACT | SEP Package | LET | LET | CIT |  |
| 326 | 6.1.3.2.2 | Inspect flight LET Detector Printed Circuit Boards (coupons & elec continuity) | 3d | 2003-09-05 | 2003-09-10 | 294FS+15d |  |  | 2003-08-19 | 2003-08-21 | 3d | 28.5d | 16d |  | STEREO | IMPACT | SEP Package | LET | LET | CIT | Flight Detector Boards Fabricated & Inspected |
| 327 | 6.1.3.2.3 | Generate flight kit list in database for LET Detector Board | 1d | 2003-09-24 | 2003-09-25 | 325, 308 |  |  | 2003-09-08 | 2003-09-08 | 1d | 12.5d | 0d |  | STEREO | IMPACT | SEP Package | LET | LET | CIT |  |
| 328 | 6.1.3.2.4 | Rescreen heritage flight parts for LET Detector Board | 5d | 2003-05-29 A | 2003-06-04 | 301 | 25% | 3.75d | 2003-06-03 | 2003-06-09 | 5d | 96d | 83.5d |  | STEREO | IMPACT | SEP Package | LET | LET | CIT |  |
| 329 | 6.1.3.2.5 | Burn-in flight FPGA/EEPROM for LET Detector Board | 2d | 2003-09-24 | 2003-09-26 | 325, 307 |  |  | 2003-09-08 | 2003-09-09 | 2d | 16.5d | 4d |  | STEREO | IMPACT | SEP Package | LET | LET | CIT |  |
| 330 | 6.1.3.2.6 | Bend leads on flight ICs for LET Detector Board | 2d | 2003-09-24 | 2003-09-26 | 325, 311 |  |  | 2003-09-08 | 2003-09-09 | 2d | 16.5d | 4d |  | STEREO | IMPACT | SEP Package | LET | LET | CIT |  |
| 331 | 6.1.3.2.7 | Generate flight kit book for LET Detector Board | 2d | 2003-09-25 | 2003-09-29 | 327 |  |  | 2003-09-09 | 2003-09-10 | 2d | 12.5d | 0d |  | STEREO | IMPACT | SEP Package | LET | LET | CIT |  |
| 332 | 6.1.3.2.8 | Kit flight parts for LET Detector Board | 3d | 2003-09-29 | 2003-10-02 | 331, 290FS+60d, 291FS+60d, 292FS+60d, 138 |  |  | 2003-09-11 | 2003-09-15 | 3d | 12.5d | 0d |  | STEREO | IMPACT | SEP Package | LET | LET | CIT |  |
| 333 | 6.1.3.2.9 | Rework/haywire/trim flight LET Detector Boards | 3d | 2003-11-13 | 2003-11-18 | 357, 349 |  |  | 2003-10-27 | 2003-10-29 | 3d | 12.5d | 0d |  | STEREO | IMPACT | SEP Package | LET | LET | CIT |  |
| 334 | 6.1.3.2.10 | Post-rework QA inspection for LET Detector Boards | 1d | 2003-11-18 | 2003-11-19 | 333 |  |  | 2003-10-30 | 2003-10-30 | 1d | 12.5d | 0d |  | STEREO | IMPACT | SEP Package | LET | LET | CIT |  |

| ID | WBS | Task | Duration | Start | Finish | Predecessors | Baseline start | Baseline finish | Baseline duration | Total slack | Free slack | Text11 | Text12 | Text13 | Text14 | Text16 | Text28 | Text23 |
| --- | --- | --- | --- | --- | --- | --- | --- | --- | --- | --- | --- | --- | --- | --- | --- | --- | --- | --- |
| 335 | 6.1.4 | **Assembly** | 103d | 2003-05-20 | 2003-10-16 |  | 2003-05-02 | 2003-09-26 | 103d | -12.5d | 0d | STEREO | IMPACT | SEP Package | LET | LET | CIT |  |
| 336 | 6.1.4.1 | **ETU** | 10d | 2003-05-20 | 2003-06-04 |  | 2003-05-02 | 2003-05-15 | 10d | -12.5d | 0d | STEREO | IMPACT | SEP Package | LET | LET | CIT |  |
| 337 | 6.1.4.1.1 | Assemble EM LET Detector Board | 10d | 2003-05-20 | 2003-06-04 | 317, 319, 320, 322 | 2003-05-02 | 2003-05-15 | 10d | -12.5d | 0d | STEREO | IMPACT | SEP Package | LET | LET | CIT | EM Detector Board Assembled |
| 338 | 6.1.4.2 | **FM 1** | 9d | 2003-10-02 | 2003-10-16 |  | 2003-09-16 | 2003-09-26 | 9d | 13.5d |  | STEREO | IMPACT | SEP Package | LET | LET | CIT |  |
| 339 | 6.1.4.2.1 | Assemble LET FM 1 Detector Board | 8d | 2003-10-02 | 2003-10-15 | 326, 328, 329, 330, 332 | 2003-09-16 | 2003-09-25 | 8d | 12.5d | 0d | STEREO | IMPACT | SEP Package | LET | LET | CIT |  |
| 340 | 6.1.4.2.2 | Post-assembly QA inspection for flight LET Detector Boards | 1d | 2003-10-15 | 2003-10-16 | 339 | 2003-09-26 | 2003-09-26 | 1d | 12.5d | 0d | STEREO | IMPACT | SEP Package | LET | LET | CIT | FM 1 Detector Board Assembled |
| 341 | 6.1.4.3 | **FM 2** | 9d | 2003-10-02 | 2003-10-16 |  | 2003-09-16 | 2003-09-26 | 9d | 13.5d |  | STEREO | IMPACT | SEP Package | LET | LET | CIT |  |
| 342 | 6.1.4.3.1 | Assemble LET FM 2 Detector Board | 8d | 2003-10-02 | 2003-10-15 | 326, 328, 329, 330, 332 | 2003-09-16 | 2003-09-25 | 8d | 12.5d | 0d | STEREO | IMPACT | SEP Package | LET | LET | CIT |  |
| 343 | 6.1.4.3.2 | Post-assembly QA inspection for flight LET Detector Boards | 1d | 2003-10-15 | 2003-10-16 | 342 | 2003-09-26 | 2003-09-26 | 1d | 12.5d | 0d | STEREO | IMPACT | SEP Package | LET | LET | CIT | FM 2 Detector Board Assembled |
| 344 | 6.1.5 | **Test** | 139d | 2003-06-04 | 2003-12-23 |  | 2003-05-16 | 2003-12-04 | 139d | -12.5d | 0d | STEREO | IMPACT | SEP Package | LET | LET | CIT |  |
| 345 | 6.1.5.1 | **ETU** | 31d | 2003-06-04 | 2003-07-18 |  | 2003-05-16 | 2003-06-30 | 31d | -12.5d | 0d | STEREO | IMPACT | SEP Package | LET | LET | CIT |  |
| 346 | 6.1.5.1.1 | Test EM LET Detector Board | 29d | 2003-06-04 | 2003-07-16 | 337 | 2003-05-16 | 2003-06-26 | 29d | -12.5d | 0d | STEREO | IMPACT | SEP Package | LET | LET | CIT | EM Detector Board Tested |
| 347 | 6.1.5.1.2 | Doc EM LET Detector Boardtest results | 2d | 2003-07-16 | 2003-07-18 | 346 | 2003-06-27 | 2003-06-30 | 2d | 553.5d |  | STEREO | IMPACT | SEP Package | LET | LET | CIT |  |
| 348 | 6.1.5.2 | **FM 1** | 37d | 2003-10-16 | 2003-12-10 |  | 2003-09-29 | 2003-11-20 | 37d | 13.5d |  | STEREO | IMPACT | SEP Package | LET | LET | CIT |  |
| 349 | 6.1.5.2.1 | Test LET FM 1 Detector Boards (initial) | 19d | 2003-10-16 | 2003-11-13 | 340 | 2003-09-29 | 2003-10-24 | 19d | 12.5d | 0d | STEREO | IMPACT | SEP Package | LET | LET | CIT |  |
| 350 | 6.1.5.2.2 | Doc LET FM 1 Detector Board test results | 3d | 2003-11-13 | 2003-11-18 | 349 | 2003-10-27 | 2003-10-29 | 3d | 469.5d |  | STEREO | IMPACT | SEP Package | LET | LET | CIT |  |
| 351 | 6.1.5.2.3 | Stake/conformal coat LET FM 1 Detector Boards | 2d | 2003-11-20 | 2003-11-24 | 312 | 2003-11-03 | 2003-11-04 | 2d | 12.5d | 0d | STEREO | IMPACT | SEP Package | LET | LET | CIT |  |
| 352 | 6.1.5.2.4 | Bakeout LET FM 1 Detector Boards | 1d | 2003-11-24 | 2003-11-25 | 351 | 2003-11-05 | 2003-11-05 | 1d | 12.5d | 0d | STEREO | IMPACT | SEP Package | LET | LET | CIT |  |
| 353 | 6.1.5.2.5 | Post-conf. Coat QA inspection of LET FM 1 Detector Boards | 1d | 2003-11-25 | 2003-11-26 | 352 | 2003-11-06 | 2003-11-06 | 1d | 12.5d | 0d | STEREO | IMPACT | SEP Package | LET | LET | CIT |  |
| 354 | 6.1.5.2.6 | Test LET FM 1 Detector Boards (final) | 8d | 2003-11-26 | 2003-12-09 | 353 | 2003-11-07 | 2003-11-19 | 8d | 12.5d | 0d | STEREO | IMPACT | SEP Package | LET | LET | CIT | FM1 Detector Board Tested |
| 355 | 6.1.5.2.7 | LET FM 1 Detector Board Mass properties/photo | 1d | 2003-12-09 | 2003-12-10 | 354 | 2003-11-20 | 2003-11-20 | 1d | 12.5d | 0d | STEREO | IMPACT | SEP Package | LET | LET | CIT |  |
| 356 | 6.1.5.3 | **FM 2** | 37d | 2003-10-16 | 2003-12-10 |  | 2003-09-29 | 2003-11-20 | 37d | 13.5d |  | STEREO | IMPACT | SEP Package | LET | LET | CIT |  |
| 357 | 6.1.5.3.1 | Test LET FM 2 Detector Boards (initial) | 19d | 2003-10-16 | 2003-11-13 | 343 | 2003-09-29 | 2003-10-24 | 19d | 12.5d | 0d | STEREO | IMPACT | SEP Package | LET | LET | CIT |  |
| 358 | 6.1.5.3.2 | Doc LET FM 2 Detector Board test results | 3d | 2003-11-13 | 2003-11-18 | 357 | 2003-10-27 | 2003-10-29 | 3d | 469.5d |  | STEREO | IMPACT | SEP Package | LET | LET | CIT |  |
| 359 | 6.1.5.3.3 | Stake/conformal coat LET FM 2 Detector Boards | 2d | 2003-11-20 | 2003-11-24 | 312 | 2003-11-03 | 2003-11-04 | 2d | 12.5d | 0d | STEREO | IMPACT | SEP Package | LET | LET | CIT |  |
| 360 | 6.1.5.3.4 | Bakeout LET FM 2 Detector Boards | 1d | 2003-11-24 | 2003-11-25 | 359 | 2003-11-05 | 2003-11-05 | 1d | 12.5d | 0d | STEREO | IMPACT | SEP Package | LET | LET | CIT |  |
| 361 | 6.1.5.3.5 | Post-conf. Coat QA inspection of LET FM 2 Detector Boards | 1d | 2003-11-25 | 2003-11-26 | 360 | 2003-11-06 | 2003-11-06 | 1d | 12.5d | 0d | STEREO | IMPACT | SEP Package | LET | LET | CIT |  |
| 362 | 6.1.5.3.6 | Test LET FM 2 Detector Boards (final) | 8d | 2003-11-26 | 2003-12-09 | 361 | 2003-11-07 | 2003-11-19 | 8d | 12.5d | 0d | STEREO | IMPACT | SEP Package | LET | LET | CIT | FM 2 Detector Board Tested |
| 363 | 6.1.5.3.7 | LET FM 2 Detector Board Mass properties/photo | 1d | 2003-12-09 | 2003-12-10 | 362 | 2003-11-20 | 2003-11-20 | 1d | 12.5d | 0d | STEREO | IMPACT | SEP Package | LET | LET | CIT |  |

| ID | WBS | Task | Duration | Start | Finish | Predecessors | Complete | Remaining | Baseline start | Baseline finish | Baseline duration | Total slack | Free slack | Constraint | Text11 | Text12 | Text13 | Text14 | Text16 | Text28 | Text23 |
| --- | --- | --- | --- | --- | --- | --- | --- | --- | --- | --- | --- | --- | --- | --- | --- | --- | --- | --- | --- | --- | --- |
| 364 | 6.1.5.4 | **FM 1 & FM 2** | 9d | 2003-12-10 | 2003-12-23 |  |  |  | 2003-11-21 | 2003-12-04 | 9d | 445.5d |  |  | STEREO | IMPACT | SEP Package | LET | LET | CIT |  |
| 365 | 6.1.5.4.1 | Maintain hard copy docs for LET Detector Board | 9d | 2003-12-10 | 2003-12-23 | 363, 355 |  |  | 2003-11-21 | 2003-12-04 | 9d | 445.5d |  |  | STEREO | IMPACT | SEP Package | LET | LET | CIT |  |
| 366 | 7 | **Flight Software** | 362d | 2002-07-02 A | 2003-12-10 |  | 49% | 185.75d | 2002-07-02 | 2003-11-03 | 337d | 34d |  |  | STEREO | IMPACT | SEP Package | LET | LET | CIT |  |
| 367 | 7.1 | **Design, Manufacture, Assembly and Test** | 362d | 2002-07-02 A | 2003-12-10 |  | 49% | 185.75d | 2002-07-02 | 2003-11-03 | 337d | 34d |  |  | STEREO | IMPACT | SEP Package | LET | LET | CIT |  |
| 368 | 7.1.1 | **Fabrication** | 362d | 2002-07-02 A | 2003-12-10 |  | 49% | 185.75d | 2002-07-02 | 2003-11-03 | 337d | 34d |  |  | STEREO | IMPACT | SEP Package | LET | LET | CIT |  |
| 369 | 7.1.1.1 | LET Flight Software Build 1 | 149d | 2002-07-02 A | 2003-03-05 A | 13 | 100% |  | 2002-07-02 | 2003-02-05 | 149d |  |  | start no earlier than 2002-07-01 | STEREO | IMPACT | SEP Package | LET | LET | CIT | B1 Flight S/W |
| 370 | 7.1.1.2 | Let Flight Software Build 2 | 84d | 2003-03-06 A | 2003-07-02 | 369 | 21% | 66d | 2003-03-03 | 2003-05-28 | 62d | -2d | 0d | start no earlier than 2003-03-03 | STEREO | IMPACT | SEP Package | LET | LET | CIT | B2 Flight S/W |
| 371 | 7.1.1.3 | Let Flight Software Build 3 | 110d | 2003-07-03 | 2003-12-10 | 370 |  |  | 2003-05-29 | 2003-11-03 | 110d | 53.3d | 0d |  | STEREO | IMPACT | SEP Package | LET | LET | CIT | B3 Flight S/W |
| 372 | 8 | **Integration & Test** | 37d | 2003-11-04 | 2003-12-30 |  |  |  | 2003-11-03 | 2003-12-29 | 38d | 0.35d |  |  | STEREO | IMPACT | SEP Package | LET | LET | CIT |  |
| 373 | 8.1 | **FM 1** | 37d | 2003-11-04 | 2003-12-30 |  |  |  | 2003-11-03 | 2003-12-29 | 38d | 0.35d |  |  | STEREO | IMPACT | SEP Package | LET | LET | CIT |  |
| 374 | 8.1.1 | Integrate LET FM 1 Housing With Detectors | 37d | 2003-11-04 | 2003-12-30 | 189, 53, 89, 90, 91, 92 |  |  | 2003-11-03 | 2003-12-29 | 38d | 0.35d | 0d |  | STEREO | IMPACT | SEP Package | LET | LET | CIT | FM 1 Integrated & Tested |
| 375 | 8.2 | **FM 2** | 37d | 2003-11-04 | 2003-12-30 |  |  |  | 2003-11-03 | 2003-12-29 | 38d | 0.35d |  |  | STEREO | IMPACT | SEP Package | LET | LET | CIT |  |
| 376 | 8.2.1 | Integrate LET FM 2 Housing With Detectors | 37d | 2003-11-04 | 2003-12-30 | 189, 56, 89, 90, 91, 92 |  |  | 2003-11-03 | 2003-12-29 | 38d | 0.35d | 0d |  | STEREO | IMPACT | SEP Package | LET | LET | CIT | FM 2 Integrated and Tested |
