# SWEA - Solar Wind Electron Analyzer (CESR)

Schedule from MS Project, 2000-08-05 to 2004-02-16, status date 2003-04-30, A marks actual dates.
SWEA(CESR) Instrument Development Schedule
NASA GSFC
Status Date: 05/31/2003 / Baseline Date: 01/31/2003 R1

## Calendars

- Standard w/ 10 Gov't Holidays: Mon-Fri 08:00-12:00, 13:00-17:00; Sat-Sun off. Exceptions (off unless hours are given): 2000-09-04, 2000-10-09, 2000-11-13, 2000-11-23, 2000-12-25, 2001-01-01, 2001-01-15, 2001-02-19, 2001-05-28, 2001-07-04, 2001-09-03, 2001-10-08, 2001-11-12, 2001-11-22, 2001-12-25, 2002-01-01, 2002-01-14, 2002-02-18, 2002-05-27, 2002-07-04, 2002-09-02, 2002-10-07, 2002-11-11, 2002-11-28, 2002-12-25, 2003-01-01, 2003-01-13, 2003-02-17, 2003-05-26, 2003-07-04, 2003-09-01, 2003-10-06, 2003-11-10, 2003-11-27, 2003-12-25, 2004-01-01, 2004-01-12, 2004-02-16.
- Standard w/ French Holidays: Mon-Fri 08:00-12:00, 13:00-17:00; Sat-Sun off. Exceptions (off unless hours are given): 2002-11-01, 2002-11-11, 2002-12-24 to 2002-12-27, 2002-12-30 to 2003-01-03, 2003-04-21, 2003-05-01 to 2003-05-02, 2003-05-08 to 2003-05-09, 2003-05-29 to 2003-05-30, 2003-07-14, 2003-08-01 to 2003-08-29, 2003-11-10 to 2003-11-11, 2003-12-24 to 2004-01-02.

## Schedule

| ID | WBS | Task | Type | Duration | Start | Finish | Predecessors | Complete | Remaining | Baseline start | Baseline finish | Baseline duration | Total slack | Free slack | Constraint | Calendar | Text11 | Text12 | Text13 | Text14 | Text16 | Text17 | Text28 | Text8 | Text20 | Text21 | Text23 |
| --- | --- | --- | --- | --- | --- | --- | --- | --- | --- | --- | --- | --- | --- | --- | --- | --- | --- | --- | --- | --- | --- | --- | --- | --- | --- | --- | --- |
| 1 | 1 | **Management** |  | 720d | 2001-03-06 A | 2004-02-16 |  | 99% | 0d | 2001-03-06 | 2004-02-16 | 720d | 0d |  |  | Standard w/ French Holidays | STEREO | IMPACT | Boom Suite | SWEA | SWEA/STE-D and STE-U | SWEA | CESR |  |  |  |  |
| 2 | 1.1 | **Milestones** |  | 720d | 2001-03-06 A | 2004-02-16 |  | 99% | 0d | 2001-03-06 | 2004-02-16 | 720d | 0d |  |  | Standard w/ French Holidays | STEREO | IMPACT | Boom Suite | SWEA | SWEA/STE-D and STE-U | SWEA | CESR |  |  |  |  |
| 3 | 1.1.1 | **Contingency Blocks** |  | 314d | 2002-09-25 A | 2004-02-16 |  |  | 314d | 2002-09-25 | 2004-02-16 | 314d | 0d |  |  | Standard w/ French Holidays | STEREO | IMPACT | Boom Suite | SWEA | SWEA/STE-D and STE-U | SWEA | CESR |  |  |  |  |
| 4 | 1.1.1.1 | SWEA(CESR) ETU Contingency | milestone | 0d | 2002-09-25 A | 2002-09-25 A | 65, 66, 80 | 100% |  | 2002-09-25 | 2002-09-25 | 0d |  |  |  | Standard w/ French Holidays | STEREO | IMPACT | Boom Suite | SWEA | SWEA/STE-D and STE-U | SWEA | CESR | Complete |  |  |  |
| 5 | 1.1.1.2 | SWEA(CESR) FM 1 Contingency | milestone | 0d | 2003-11-13 | 2003-11-13 | 71 |  |  | 2003-10-13 | 2003-11-17 | 24d | 2d | 0d |  | Standard w/ French Holidays | STEREO | IMPACT | Boom Suite | SWEA | SWEA/STE-D and STE-U | SWEA | CESR | Complete |  |  |  |
| 6 | 1.1.1.3 | SWEA(CESR) FM 2 Contingency | milestone | 0d | 2004-02-16 | 2004-02-16 | 76 |  |  | 2004-01-16 | 2004-02-16 | 22d | 0d |  |  | Standard w/ French Holidays | STEREO | IMPACT | Boom Suite | SWEA | SWEA/STE-D and STE-U | SWEA | CESR | Complete |  |  |  |
| 7 | 1.1.2 | **Receivables** |  | 603d | 2001-03-06 A | 2003-07-28 |  | 99% | 0d | 2001-03-06 | 2003-06-02 | 564d | 137d |  |  |  | STEREO | IMPACT | Boom Suite | SWEA | SWEA/STE-D and STE-U | SWEA | CESR |  |  |  |  |
| 8 | 1.1.3.1 | Deliver SWEA ICD Draft to CESR |  | 1d | 2001-03-06 A | 2001-03-06 A |  | 100% |  | 2001-03-06 | 2001-03-06 | 1d |  |  |  |  | STEREO | IMPACT | Boom Suite | SWEA | SWEA/STE-D and STE-U | SWEA |  |  |  |  |  |
| 9 | 1.1.2.2 | Receive SWEA ICD Draft |  | 1d | 2001-03-06 A | 2001-03-06 A | 8 | 100% |  | 2001-03-06 | 2001-03-06 | 1d |  |  |  | Standard w/ French Holidays | STEREO | IMPACT | Boom Suite | SWEA | SWEA/STE-D and STE-U | SWEA | UC-B | Rec SWEA ICD Draft |  |  |  |
| 10 | 1.1.3.13 | Deliver SWEA / STE-D ETU Testing Results | milestone | 0d | 2003-07-28 | 2003-07-28 |  |  |  | 2003-06-02 | 2003-06-02 | 0d | 173d | 0d |  |  | STEREO | IMPACT | Boom Suite | SWEA | SWEA/STE-D and STE-U | SWEA |  |  |  |  |  |
| 11 | 1.1.2.4 | Receive SWEA/STE Interface Test Results | milestone | 0d | 2003-07-28 | 2003-07-28 | 10 |  |  | 2003-06-02 | 2003-06-02 | 0d | 173d |  |  |  | STEREO | IMPACT | Boom Suite | SWEA | SWEA/STE-D and STE-U | SWEA | CESR |  |  |  |  |
| 12 | 1.1.3 | **Deliverables** |  | 347d | 2002-09-25 A | 2004-02-16 |  |  | 347d | 2002-09-25 | 2004-02-16 | 347d | 0d |  |  |  | STEREO | IMPACT | Boom Suite | SWEA | SWEA/STE-D and STE-U | SWEA | CESR |  |  |  |  |
| 13 | 1.1.3.1 | Deliver SWEA ETU Detectors/Front-End With Calibration Setup to UC-B | milestone | 0d | 2002-09-25 A | 2002-09-25 A | 4 | 100% |  | 2002-09-25 | 2002-09-25 | 0d |  |  | finish no later than 2002-09-18 | Standard w/ French Holidays | STEREO | IMPACT | Boom Suite | SWEA | SWEA/STE-D and STE-U | SWEA | CESR | ETU to UCB | ETU SWEA (FE) | ETU to UCB | Deliver ETU Front End W/Calibration Setup to UC-B |
| 14 | 1.1.2.2 | Receive ETU SWEA(CESR) With Calibration Setup From CESR | milestone | 0d | 2002-09-25 A | 2002-09-25 A | 13 | 100% |  | 2002-09-25 | 2002-09-25 | 0d |  |  |  |  | STEREO | IMPACT | Boom Suite | SWEA | SWEA/STE-D and STE-U | SWEA |  |  |  |  |  |
| 15 | 1.1.3.3 | Deliver SWEA FM 1 Detectors/Front-End to UC-B | milestone | 0d | 2003-11-13 | 2003-11-13 | 5 |  |  | 2003-11-17 | 2003-11-17 | 0d | 2d |  | finish no later than 2003-11-17 | Standard w/ French Holidays | STEREO | IMPACT | Boom Suite | SWEA | SWEA/STE-D and STE-U | SWEA | CESR | FM 1 to UCB | FM1 SWEA (FE) | FM1 to UCB | Deliver FM 1 Front End to UC-B |
| 16 | 1.1.2.4 | Receive FM 1 SWEA(CESR) With Calibration Setup From CESR | milestone | 0d | 2003-11-13 | 2003-11-13 | 15 |  |  | 2003-11-17 | 2003-11-17 | 0d | 38d |  |  |  | STEREO | IMPACT | Boom Suite | SWEA | SWEA/STE-D and STE-U | SWEA |  |  |  |  |  |
| 17 | 1.1.3.5 | Deliver SWEA FM 2 Detectors/Front-End to UC-B | milestone | 0d | 2004-02-16 | 2004-02-16 | 6 |  |  | 2004-02-16 | 2004-02-16 | 0d | 0d |  | finish no later than 2004-02-16 | Standard w/ French Holidays | STEREO | IMPACT | Boom Suite | SWEA | SWEA/STE-D and STE-U | SWEA | CESR | FM 2 to UCB | FM2 SWEA(FE) | FM2 to UCB | Deliver FM 2 Front End to UC-B |
| 18 | 1.1.2.6 | Receive FM 2 SWEA(CESR) With Calibration Setup From CESR | milestone | 0d | 2004-02-16 | 2004-02-16 | 17 |  |  | 2004-02-16 | 2004-02-16 | 0d | 0d |  |  |  | STEREO | IMPACT | Boom Suite | SWEA | SWEA/STE-D and STE-U | SWEA |  |  |  |  |  |
| 19 | 2 | **Design, Manufacture, Assembly and Test** |  | 871d | 2000-08-05 A | 2004-02-16 |  | 87% | 111.25d | 2000-08-05 | 2004-01-15 | 849d | 0d |  |  | Standard w/ French Holidays | STEREO | IMPACT | Boom Suite | SWEA | SWEA/STE-D and STE-U | SWEA | CESR |  |  |  |  |
| 20 | 2.1 | **Procurements** |  | 652d | 2000-11-07 A | 2003-06-02 |  | 99% | 1.41d | 2000-11-07 | 2003-04-30 | 635d | 18d |  |  | Standard w/ French Holidays | STEREO | IMPACT | Boom Suite | SWEA | SWEA/STE-D and STE-U | SWEA | CESR |  |  |  |  |
| 21 | 2.1.1 | **ETU** |  | 206d | 2000-11-07 A | 2001-08-31 A |  | 100% |  | 2000-11-07 | 2001-08-31 | 206d |  |  |  |  | STEREO | IMPACT | Boom Suite | SWEA | SWEA/STE-D and STE-U | SWEA | CESR |  |  |  |  |
| 22 | 2.1.1.1 | SWEA ETU Parts Procurement |  | 214d | 2000-11-07 A | 2001-08-31 A | 26 | 100% |  | 2000-11-07 | 2001-08-31 | 214d |  |  |  | Standard w/ French Holidays | STEREO | IMPACT | Boom Suite | SWEA | SWEA/STE-D and STE-U | SWEA | CESR | ETU Parts |  |  |  |
| 23 | 2.1.2 | **FM 1 & FM 2** |  | 652d | 2000-11-07 A | 2003-06-02 |  | 99% | 2.63d | 2000-11-07 | 2003-04-30 | 635d | 18d |  |  | Standard w/ French Holidays | STEREO | IMPACT | Boom Suite | SWEA | SWEA/STE-D and STE-U | SWEA | CESR |  |  |  |  |
| 24 | 2.1.2.1 | SWEA Long Lead Procurements |  | 248d | 2000-11-07 A | 2003-06-02 | 26 | 99% | 1d | 2000-11-07 | 2003-04-30 | 248d | 18d |  |  | Standard w/ French Holidays | STEREO | IMPACT | Boom Suite | SWEA | SWEA/STE-D and STE-U | SWEA | CESR | Flight |  |  | Long Lead Flight Procurements Complete |

Notes:
- 4: 2002 Vacation time taken into account via miminal progress for July reporting cycle.
- 13: Text22: SWEA - ETU Detectors/Front-End With Calibration Setup to UC-B
- 15: FNL of 11/3/03 removed 1/9/03 / Text22: SWEA - FM 1 Detectors/Front-End to UC-B
- 17: FNL of 1/1/04 removed 1/9/03 / Text22: SWEA - FM 2 Detectors/Front-End to UC-B

| ID | WBS | Task | Type | Duration | Start | Finish | Predecessors | Complete | Remaining | Baseline start | Baseline finish | Baseline duration | Total slack | Constraint | Calendar | Text11 | Text12 | Text13 | Text14 | Text16 | Text17 | Text28 | Text8 | Text20 | Text21 |
| --- | --- | --- | --- | --- | --- | --- | --- | --- | --- | --- | --- | --- | --- | --- | --- | --- | --- | --- | --- | --- | --- | --- | --- | --- | --- |
| 25 | 2.2 | **Design** |  | 342d | 2000-08-05 A | 2001-12-17 A |  | 100% |  | 2000-08-05 | 2001-12-17 | 342d |  |  |  | STEREO | IMPACT | Boom Suite | SWEA | SWEA/STE-D and STE-U | SWEA | CESR |  |  |  |
| 26 | 2.2.1 | Preliminary SWEA Design |  | 66d | 2000-08-05 A | 2000-11-06 A |  | 100% |  | 2000-08-05 | 2000-11-06 | 66d |  | start no earlier than 2000-08-15 | Standard w/ French Holidays | STEREO | IMPACT | Boom Suite | SWEA | SWEA/STE-D and STE-U | SWEA | CESR | Prelim Dsn |  |  |
| 27 | 2.2.2 | Detailed SWEA Design |  | 105d | 2000-11-07 A | 2001-04-02 A | 26 | 100% |  | 2000-11-07 | 2001-04-02 | 105d |  |  | Standard w/ French Holidays | STEREO | IMPACT | Boom Suite | SWEA | SWEA/STE-D and STE-U | SWEA | CESR | Detail Dsn |  |  |
| 28 | 2.2.3 | Final SWEA Design |  | 205d | 2001-03-06 A | 2001-12-17 A | 9, 26 | 100% |  | 2001-03-06 | 2001-12-17 | 205d |  |  | Standard w/ French Holidays | STEREO | IMPACT | Boom Suite | SWEA | SWEA/STE-D and STE-U | SWEA | CESR | Final Dsn |  |  |
| 29 | 2.3 | **Fabrication** |  | 585d | 2001-04-03 A | 2003-07-25 |  | 94% | 32.39d | 2001-04-03 | 2003-04-25 | 527d | 33d |  | Standard w/ French Holidays | STEREO | IMPACT | Boom Suite | SWEA | SWEA/STE-D and STE-U | SWEA | CESR |  |  |  |
| 30 | 2.3.1 | **ETU** |  | 329d | 2001-04-03 A | 2002-07-05 A |  | 100% |  | 2001-04-03 | 2002-07-05 | 329d |  |  | Standard w/ French Holidays | STEREO | IMPACT | Boom Suite | SWEA | SWEA/STE-D and STE-U | SWEA | CESR |  |  |  |
| 31 | 2.3.1.1 | Begin SWEA ETU |  | 1d | 2001-04-03 A | 2001-04-03 A | 32SS | 100% |  | 2001-04-03 | 2001-04-03 | 1d |  |  | Standard w/ French Holidays | STEREO | IMPACT | Boom Suite | SWEA | SWEA/STE-D and STE-U | SWEA | CESR | Begin ETU | SWEA ETU |  |
| 32 | 2.3.1.2 | Analyzer ETU Fabrication |  | 286.26d | 2001-04-03 A | 2002-07-05 A | 27 | 100% |  | 2001-04-03 | 2002-07-05 | 286.26d |  |  | Standard w/ French Holidays | STEREO | IMPACT | Boom Suite | SWEA | SWEA/STE-D and STE-U | SWEA | CESR | Analyzer Fab |  |  |
| 33 | 2.3.1.3 | Electronics ETU Fabrication |  | 284d | 2001-04-03 A | 2002-05-03 A | 27 | 100% |  | 2001-04-03 | 2002-05-03 | 284d |  |  | Standard w/ French Holidays | STEREO | IMPACT | Boom Suite | SWEA | SWEA/STE-D and STE-U | SWEA | CESR | Electronics Fab |  |  |
| 34 | 2.3.2 | **FM 1 & FM 2** |  | 153d | 2002-12-02 A | 2003-07-25 |  | 87% | 20.45d | 2002-12-02 | 2003-04-25 | 95d | 33d |  | Standard w/ French Holidays | STEREO | IMPACT | Boom Suite | SWEA | SWEA/STE-D and STE-U | SWEA | CESR |  |  |  |
| 35 | 2.3.2.1 | **FM 1** |  | 133d | 2002-12-02 A | 2003-06-26 |  | 93% | 9.88d | 2002-12-02 | 2003-04-25 | 95d | 0d |  | Standard w/ French Holidays | STEREO | IMPACT | Boom Suite | SWEA | SWEA/STE-D and STE-U | SWEA | CESR |  |  |  |
| 36 | 1.1.13 | Instrument CDR | milestone | 3d | 2002-11-20 A | 2002-11-22 A |  | 100% |  | 2002-11-20 | 2002-11-22 | 3d |  | finish no earlier than 2002-11-22 |  | STEREO | IMPACT | Boom Suite | SWEA | SWEA/STE-D and STE-U | SWEA | CESR |  |  |  |
| 37 | 2.3.2.1.2 | SWEA FM 1 Mechanical Fabrication |  | 36d | 2002-12-02 A | 2003-01-31 A | 36FS+4d | 100% |  | 2002-12-02 | 2003-01-31 | 36d |  |  | Standard w/ French Holidays | STEREO | IMPACT | Boom Suite | SWEA | SWEA/STE-D and STE-U | SWEA | CESR | Fab |  | FM 1 Fab. Begins |
| 38 | 2.3.2.1.3 | SWEA FM 1 Surface Treatment |  | 20d | 2003-02-03 A | 2003-03-14 A | 37, 39 | 100% |  | 2003-02-03 | 2003-02-28 | 20d |  |  | Standard w/ French Holidays | STEREO | IMPACT | Boom Suite | SWEA | SWEA/STE-D and STE-U | SWEA |  |  |  |  |
| 39 | 2.3.2.1.4 | SWEA FM 1 Sphere Treatment |  | 20d | 2003-01-06 A | 2003-01-31 A |  | 100% |  | 2003-01-06 | 2003-01-31 | 20d |  | start no earlier than 2003-01-06 | Standard w/ French Holidays | STEREO | IMPACT | Boom Suite | SWEA | SWEA/STE-D and STE-U | SWEA |  |  |  |  |
| 40 | 2.3.2.1.5 | SWEA FM 1 Grids |  | 39d | 2003-04-25 A | 2003-06-26 | 38 | 62% | 15d | 2003-03-03 | 2003-04-25 | 39d | 0d |  | Standard w/ French Holidays | STEREO | IMPACT | Boom Suite | SWEA | SWEA/STE-D and STE-U | SWEA |  |  |  |  |
| 41 | 2.3.2.1.6 | SWEA FM 1 HV Coupling & Amplis Board Manufacturing |  | 56d | 2002-12-02 A | 2003-02-28 A |  | 100% |  | 2002-12-02 | 2003-02-28 | 56d |  | start no earlier than 2002-12-02 | Standard w/ French Holidays | STEREO | IMPACT | Boom Suite | SWEA | SWEA/STE-D and STE-U | SWEA |  |  |  |  |
| 42 | 2.3.2.1.7 | SWEA FM 1 HV Board Manufacturing |  | 31d | 2003-02-17 A | 2003-03-31 A |  | 100% |  | 2003-02-17 | 2003-04-14 | 41d |  | start no earlier than 2003-02-17 | Standard w/ French Holidays | STEREO | IMPACT | Boom Suite | SWEA | SWEA/STE-D and STE-U | SWEA |  |  |  |  |
| 43 | 2.3.2.2 | **FM 2** |  | 153d | 2002-12-02 A | 2003-07-25 |  | 81% | 29.54d | 2002-12-02 | 2003-04-25 | 95d | 33d |  | Standard w/ French Holidays | STEREO | IMPACT | Boom Suite | SWEA | SWEA/STE-D and STE-U | SWEA | CESR |  |  |  |
| 44 | 2.3.2.2.1 | SWEA FM 2 Mechanical Fabrication |  | 36d | 2002-12-02 A | 2003-01-31 A | 36FS+4d | 100% |  | 2002-12-02 | 2003-01-31 | 36d |  |  | Standard w/ French Holidays | STEREO | IMPACT | Boom Suite | SWEA | SWEA/STE-D and STE-U | SWEA | CESR | Fab |  |  |
| 45 | 2.3.2.2.2 | SWEA FM 2 Surface Treatment |  | 20d | 2003-02-03 A | 2003-03-14 A | 44, 46 | 100% |  | 2003-02-03 | 2003-02-28 | 20d |  |  | Standard w/ French Holidays | STEREO | IMPACT | Boom Suite | SWEA | SWEA/STE-D and STE-U | SWEA |  |  |  |  |
| 46 | 2.3.2.2.3 | SWEA FM 2 Sphere Treatment |  | 20d | 2003-01-06 A | 2003-01-31 A |  | 100% |  | 2003-01-06 | 2003-01-31 | 20d |  | start no earlier than 2003-01-06 | Standard w/ French Holidays | STEREO | IMPACT | Boom Suite | SWEA | SWEA/STE-D and STE-U | SWEA |  |  |  |  |
| 47 | 2.3.2.2.4 | SWEA FM 2 Grids |  | 39d | 2003-06-02 | 2003-07-25 | 45 |  |  | 2003-03-03 | 2003-04-25 | 39d | 18d | start no earlier than 2003-05-31 | Standard w/ French Holidays | STEREO | IMPACT | Boom Suite | SWEA | SWEA/STE-D and STE-U | SWEA |  |  |  |  |
| 48 | 2.3.2.2.5 | SWEA FM 2 HV Coupling & Amplis Board Manufacturing |  | 56d | 2002-12-02 A | 2003-02-28 A |  | 100% |  | 2002-12-02 | 2003-02-28 | 56d |  | start no earlier than 2002-12-02 | Standard w/ French Holidays | STEREO | IMPACT | Boom Suite | SWEA | SWEA/STE-D and STE-U | SWEA |  |  |  |  |
| 49 | 2.3.2.2.6 | SWEA FM 2 HV Board Manufacturing |  | 31d | 2003-02-17 A | 2003-03-31 A |  | 100% |  | 2003-02-17 | 2003-04-14 | 41d |  | start no earlier than 2003-02-17 | Standard w/ French Holidays | STEREO | IMPACT | Boom Suite | SWEA | SWEA/STE-D and STE-U | SWEA |  |  |  |  |

| ID | WBS | Task | Duration | Start | Finish | Predecessors | Complete | Remaining | Baseline start | Baseline finish | Baseline duration | Total slack | Free slack | Constraint | Calendar | Text11 | Text12 | Text13 | Text14 | Text16 | Text17 | Text28 | Text8 | Text23 | Text21 |
| --- | --- | --- | --- | --- | --- | --- | --- | --- | --- | --- | --- | --- | --- | --- | --- | --- | --- | --- | --- | --- | --- | --- | --- | --- | --- |
| 50 | 2.4 | **Assembly** | 288d | 2002-06-17 A | 2003-09-17 |  | 56% | 126.76d | 2002-06-17 | 2003-07-18 | 266d | 29d |  |  | Standard w/ French Holidays | STEREO | IMPACT | Boom Suite | SWEA | SWEA/STE-D and STE-U | SWEA | CESR |  |  |  |
| 51 | 2.4.1 | **ETU** | 36d | 2002-06-17 A | 2002-08-05 A |  | 100% |  | 2002-06-17 | 2002-08-05 | 36d |  |  |  | Standard w/ French Holidays | STEREO | IMPACT | Boom Suite | SWEA | SWEA/STE-D and STE-U | SWEA | CESR |  |  |  |
| 52 | 2.4.1.1 | SWEA ETU Assembly | 11.5d | 2002-06-17 A | 2002-08-05 A | 32, 33 | 100% |  | 2002-06-17 | 2002-08-05 | 11.5d |  |  |  | Standard w/ French Holidays | STEREO | IMPACT | Boom Suite | SWEA | SWEA/STE-D and STE-U | SWEA | CESR | Assembly |  |  |
| 53 | 2.4.2 | **FM 1** | 58d | 2003-04-16 A | 2003-07-16 |  | 61% | 22.61d | 2003-03-03 | 2003-06-13 | 68d | 0d |  |  | Standard w/ French Holidays | STEREO | IMPACT | Boom Suite | SWEA | SWEA/STE-D and STE-U | SWEA | CESR |  |  |  |
| 54 | 2.4.2.1 | SWEA FM 1 Mechanical Assembly | 21d | 2003-05-05 A | 2003-06-06 | 37, 38 | 52% | 10d | 2003-03-03 | 2003-03-31 | 21d | 14d |  | start no earlier than 2003-05-01 | Standard w/ French Holidays | STEREO | IMPACT | Boom Suite | SWEA | SWEA/STE-D and STE-U | SWEA |  |  |  |  |
| 55 | 2.4.2.2 | SWEA FM 1 HV Coupling & Amplis Board Wiring | 10d | 2003-04-16 A | 2003-04-30 A | 41 | 100% |  | 2003-03-03 | 2003-03-14 | 10d |  |  | start no earlier than 2003-04-30 | Standard w/ French Holidays | STEREO | IMPACT | Boom Suite | SWEA | SWEA/STE-D and STE-U | SWEA |  |  |  |  |
| 56 | 2.4.2.3 | SWEA FM 1 HV Board Wiring | 15d | 2003-04-16 A | 2003-05-13 A | 42 | 100% |  | 2003-04-15 | 2003-05-12 | 15d |  |  | start no earlier than 2003-04-30 | Standard w/ French Holidays | STEREO | IMPACT | Boom Suite | SWEA | SWEA/STE-D and STE-U | SWEA |  |  | FM 1 HV Board Assembly Complete |  |
| 57 | 2.4.2.4 | SWEA FM 1 Final Assembly | 13d | 2003-06-27 | 2003-07-16 | 24, 69, 40, 54, 68 |  |  | 2003-05-26 | 2003-06-13 | 13d | 0d |  |  | Standard w/ French Holidays | STEREO | IMPACT | Boom Suite | SWEA | SWEA/STE-D and STE-U | SWEA | CESR | Begin Assm. | FM 1 Final Assembly Complete |  |
| 58 | 2.4.3 | **FM 2** | 72d | 2003-05-05 A | 2003-09-17 |  | 42% | 41.49d | 2003-03-03 | 2003-07-18 | 92d | 29d |  |  | Standard w/ French Holidays | STEREO | IMPACT | Boom Suite | SWEA | SWEA/STE-D and STE-U | SWEA | CESR |  |  |  |
| 59 | 2.4.3.1 | SWEA FM 2 Mechanical Assembly | 21d | 2003-05-05 | 2003-06-06 | 44, 45 |  |  | 2003-03-03 | 2003-03-31 | 21d | 67d | 59d | start no earlier than 2003-04-30 | Standard w/ French Holidays | STEREO | IMPACT | Boom Suite | SWEA | SWEA/STE-D and STE-U | SWEA |  |  |  |  |
| 60 | 2.4.3.2 | SWEA FM 2 HV Coupling & Amplis Board Wiring | 10d | 2003-05-05 A | 2003-05-20 A | 48 | 100% |  | 2003-03-03 | 2003-03-14 | 10d |  |  | start no earlier than 2003-04-30 | Standard w/ French Holidays | STEREO | IMPACT | Boom Suite | SWEA | SWEA/STE-D and STE-U | SWEA |  |  |  |  |
| 61 | 2.4.3.3 | SWEA FM 2 HV Board Wiring | 15d | 2003-05-05 A | 2003-05-27 A | 49 | 100% |  | 2003-04-15 | 2003-05-12 | 15d |  |  | start no earlier than 2003-04-30 | Standard w/ French Holidays | STEREO | IMPACT | Boom Suite | SWEA | SWEA/STE-D and STE-U | SWEA |  |  | FM 2 HV Board Assembly Complete |  |
| 62 | 2.4.3.4 | SWEA FM 2 Final Assembly | 13d | 2003-09-01 | 2003-09-17 | 24, 70FS+1d, 47, 59, 74 |  |  | 2003-07-01 | 2003-07-18 | 13d | 29d | 0d |  | Standard w/ French Holidays | STEREO | IMPACT | Boom Suite | SWEA | SWEA/STE-D and STE-U | SWEA | CESR | Assembly | FM 2 Final Assembly Complete |  |
| 63 | 2.5 | **Test** | 347d | 2002-08-09 A | 2004-02-16 |  | 27% | 253.34d | 2002-08-09 | 2004-01-15 | 325d | 0d |  |  | Standard w/ French Holidays | STEREO | IMPACT | Boom Suite | SWEA | SWEA/STE-D and STE-U | SWEA | CESR |  |  |  |
| 64 | 2.5.1 | **ETU** | 34d | 2002-08-09 A | 2002-09-25 A |  | 100% |  | 2002-08-09 | 2002-09-25 | 34d |  |  |  | Standard w/ French Holidays | STEREO | IMPACT | Boom Suite | SWEA | SWEA/STE-D and STE-U | SWEA | CESR |  |  |  |
| 65 | 2.5.1.1 | SWEA ETU Testing | 8d | 2002-08-09 A | 2002-08-20 A | 79, 52 | 100% |  | 2002-08-09 | 2002-08-20 | 8d |  |  | start no earlier than 2002-07-31 | Standard w/ French Holidays | STEREO | IMPACT | Boom Suite | SWEA | SWEA/STE-D and STE-U | SWEA | CESR | Testing |  |  |
| 66 | 2.5.1.2 | SWEA ETU Calibration | 26d | 2002-08-20 A | 2002-09-25 A | 65 | 100% |  | 2002-08-20 | 2002-09-25 | 26d |  |  |  | Standard w/ French Holidays | STEREO | IMPACT | Boom Suite | SWEA | SWEA/STE-D and STE-U | SWEA | CESR | Cal |  |  |
| 67 | 2.5.2 | **FM 1** | 111d | 2003-05-05 A | 2003-11-13 |  | 23% | 85.94d | 2003-03-17 | 2003-10-10 | 121d | 0d |  |  | Standard w/ French Holidays | STEREO | IMPACT | Boom Suite | SWEA | SWEA/STE-D and STE-U | SWEA | CESR |  |  |  |
| 68 | 2.5.2.1 | SWEA FM 1 HV Coupling & Amplis Board Testing | 20d | 2003-05-05 A | 2003-06-05 | 55 | 90% | 2d | 2003-03-17 | 2003-04-11 | 20d | 8d | 0d | start no earlier than 2003-04-30 | Standard w/ French Holidays | STEREO | IMPACT | Boom Suite | SWEA | SWEA/STE-D and STE-U | SWEA |  |  |  |  |
| 69 | 2.5.2.2 | SWEA FM 1 HV Board Integration & Test | 10d | 2003-05-26 A | 2003-06-16 | 56FS-1d, 68 | 30% | 7d | 2003-05-12 | 2003-05-23 | 10d | 8d |  | start no earlier than 2003-04-30 | Standard w/ French Holidays | STEREO | IMPACT | Boom Suite | SWEA | SWEA/STE-D and STE-U | SWEA |  |  | FM 1 Front End HV Board I & T Complete |  |
| 70 | 2.5.2.3 | SWEA FM 1 Electrical/Thermal Testing | 10d | 2003-07-17 | 2003-07-30 | 57 |  |  | 2003-06-16 | 2003-06-27 | 10d | 0d |  |  | Standard w/ French Holidays | STEREO | IMPACT | Boom Suite | SWEA | SWEA/STE-D and STE-U | SWEA | CESR | Assm. Cpt./Tst Begin | FM 1 Electrical/Environemntal Testing Complete |  |
| 71 | 2.5.2.4 | SWEA FM 1 Calibration | 53d | 2003-07-31 | 2003-11-13 | 70 |  |  | 2003-06-30 | 2003-10-10 | 53d | 0d |  |  | Standard w/ French Holidays | STEREO | IMPACT | Boom Suite | SWEA | SWEA/STE-D and STE-U | SWEA | CESR | Cal | FM 1 Front End Calibration Complete | FM 1 Cal |
| 72 | 2.5.3 | **FM 2** | 160d | 2003-05-21 A | 2004-02-16 |  | 6% | 150.3d | 2003-04-14 | 2004-01-15 | 160d | 0d |  |  | Standard w/ French Holidays | STEREO | IMPACT | Boom Suite | SWEA | SWEA/STE-D and STE-U | SWEA | CESR |  |  |  |
| 73 | 2.5.3.1 | SWEA FM 2 HV Coupling & Amplis Board Testing | 20d | 2003-05-21 A | 2003-06-25 | 60, 68 | 30% | 14d | 2003-04-14 | 2003-05-16 | 20d | 44d | 0d | start no earlier than 2003-04-30 | Standard w/ French Holidays | STEREO | IMPACT | Boom Suite | SWEA | SWEA/STE-D and STE-U | SWEA |  |  |  |  |
| 74 | 2.5.3.2 | SWEA FM 2 HV Board Integration & Test | 10d | 2003-06-26 | 2003-07-09 | 61, 73 |  |  | 2003-06-02 | 2003-06-13 | 10d | 44d | 37d | start no earlier than 2003-06-02 | Standard w/ French Holidays | STEREO | IMPACT | Boom Suite | SWEA | SWEA/STE-D and STE-U | SWEA |  |  | FM 2 Front End HV Board I & T Complete |  |
| 75 | 2.5.3.3 | SWEA FM 2 Electrical/Thermal Testing | 10d | 2003-09-18 | 2003-10-01 | 62 |  |  | 2003-09-01 | 2003-09-12 | 10d | 29d |  | start no earlier than 2003-09-01 | Standard w/ French Holidays | STEREO | IMPACT | Boom Suite | SWEA | SWEA/STE-D and STE-U | SWEA | CESR | Test | FM 2 Electrical/Environemntal Testing Complete |  |
| 76 | 2.5.3.4 | SWEA FM 2 Calibration | 59d | 2003-11-14 | 2004-02-16 | 75, 71 |  |  | 2003-10-13 | 2004-01-15 | 59d | 0d |  |  | Standard w/ French Holidays | STEREO | IMPACT | Boom Suite | SWEA | SWEA/STE-D and STE-U | SWEA | CESR | Cal | FM 2 Front End Calibration Complete | FM 2 Cal |

| ID | WBS | Task | Duration | Start | Finish | Predecessors | Complete | Baseline start | Baseline finish | Baseline duration | Calendar | Text11 | Text12 | Text13 | Text14 | Text16 | Text17 | Text28 | Text8 |
| --- | --- | --- | --- | --- | --- | --- | --- | --- | --- | --- | --- | --- | --- | --- | --- | --- | --- | --- | --- |
| 77 | 3 | **Emulators/Simulators/GSE** | 463d | 2000-11-07 A | 2002-08-15 A |  | 100% | 2000-11-07 | 2002-08-15 | 463d | Standard w/ French Holidays | STEREO | IMPACT | Boom Suite | SWEA | SWEA/STE-D and STE-U | SWEA | CESR |  |
| 78 | 3.1 | **GSE** | 463d | 2000-11-07 A | 2002-08-15 A |  | 100% | 2000-11-07 | 2002-08-15 | 463d | Standard w/ French Holidays | STEREO | IMPACT | Boom Suite | SWEA | SWEA/STE-D and STE-U | SWEA | CESR |  |
| 79 | 3.1.1 | Test Equipment | 151.77d | 2000-11-07 A | 2002-08-09 A | 26 | 100% | 2000-11-07 | 2002-08-09 | 151.77d | Standard w/ French Holidays | STEREO | IMPACT | Boom Suite | SWEA | SWEA/STE-D and STE-U | SWEA | CESR | Begin Test Setup |
| 80 | 3.1.2 | Calibration Setup | 333.5d | 2000-11-07 A | 2002-08-15 A | 26 | 100% | 2000-11-07 | 2002-08-15 | 333.5d | Standard w/ French Holidays | STEREO | IMPACT | Boom Suite | SWEA | SWEA/STE-D and STE-U | SWEA | CESR | Test/Cal Setup Complete |
